# MICE HALL INSTALLATION SCHEDULE

Schedule from MS Project, 2008-09-01 to 2019-09-16, costs in £, A marks actual dates.
Daresbury Laboratory

## Calendars

- Standard: Mon-Fri 08:00-12:00, 13:00-17:00; Sat-Sun off. Exceptions (off unless hours are given): 2011-11-22 to 2011-11-25 08:00-12:00, 13:00-17:00, 2011-11-28 to 2011-12-02 08:00-12:00, 13:00-17:00, 2011-12-05 to 2011-12-09 08:00-12:00, 13:00-17:00, 2011-12-12 to 2011-12-16 08:00-12:00, 13:00-17:00, 2011-12-19 to 2011-12-22 08:00-12:00, 13:00-17:00, 2012-02-21 to 2012-02-24 08:00-12:00, 13:00-17:00, 2012-02-27 to 2012-03-02 08:00-12:00, 13:00-17:00, 2012-03-05 to 2012-03-09 08:00-12:00, 13:00-17:00, 2012-03-12 to 2012-03-16 08:00-12:00, 13:00-17:00, 2012-03-19 to 2012-03-23 08:00-12:00, 13:00-17:00, 2012-03-26 to 2012-03-29 08:00-12:00, 13:00-17:00, 2012-05-15 to 2012-05-18 08:00-12:00, 13:00-17:00, 2012-05-21 to 2012-05-25 08:00-12:00, 13:00-17:00, 2012-05-28 to 2012-06-01 08:00-12:00, 13:00-17:00, 2012-06-04 to 2012-06-08 08:00-12:00, 13:00-17:00, 2012-06-11 to 2012-06-14 08:00-12:00, 13:00-17:00, 2012-07-10 to 2012-07-13 08:00-12:00, 13:00-17:00, 2012-07-16 to 2012-07-20 08:00-12:00, 13:00-17:00, 2012-07-23 to 2012-07-27 08:00-12:00, 13:00-17:00, 2012-07-30 to 2012-08-03 08:00-12:00, 13:00-17:00, 2012-08-06 to 2012-08-09 08:00-12:00, 13:00-17:00, 2012-10-02 to 2012-10-05 08:00-12:00, 13:00-17:00, 2012-10-08 to 2012-10-12 08:00-12:00, 13:00-17:00, 2012-10-15 to 2012-10-19 08:00-12:00, 13:00-17:00, 2012-10-22 to 2012-10-26 08:00-12:00, 13:00-17:00, 2012-10-29 to 2012-11-01 08:00-12:00, 13:00-17:00, 2012-11-20 to 2012-11-23 08:00-12:00, 13:00-17:00, 2012-11-26 to 2012-11-30 08:00-12:00, 13:00-17:00, 2012-12-03 to 2012-12-07 08:00-12:00, 13:00-17:00, 2012-12-10 to 2012-12-14 08:00-12:00, 13:00-17:00, 2012-12-17 to 2012-12-20 08:00-12:00, 13:00-17:00, 2013-02-19 to 2013-02-22 08:00-12:00, 13:00-17:00, 2013-02-25 to 2013-03-01 08:00-12:00, 13:00-17:00, 2013-03-04 to 2013-03-08 08:00-12:00, 13:00-17:00, 2013-03-11 to 2013-03-15 08:00-12:00, 13:00-17:00, 2013-03-18 to 2013-03-21 08:00-12:00, 13:00-17:00.
- 7 day: Mon-Fri 08:00-12:00, 13:00-17:00; Sat-Sun off. Exceptions (off unless hours are given): 2012-06-01 to 2013-05-01 08:00-12:00, 13:00-17:00 (7 Day Working, recurring).
- ISIS Run Cycle: Mon-Fri 08:00-12:00, 13:00-17:00; Sat-Sun off. Exceptions (off unless hours are given): 2011-07-05 to 2011-08-12 08:00-12:00, 13:00-17:00, 2011-09-20 to 2011-10-27 08:00-12:00, 13:00-17:00, 2011-11-15 to 2011-12-22 08:00-12:00, 13:00-17:00, 2012-02-07 to 2012-03-29 08:00-12:00, 13:00-17:00, 2012-05-15 to 2012-06-14 08:00-12:00, 13:00-17:00, 2012-07-10 to 2012-08-09 08:00-12:00, 13:00-17:00, 2012-10-02 to 2012-11-01 08:00-12:00, 13:00-17:00, 2012-11-20 to 2012-12-20 08:00-12:00, 13:00-17:00, 2013-02-19 to 2013-03-21 08:00-12:00, 13:00-17:00.
- Shipping: Mon-Fri 08:00-12:00, 13:00-17:00; Sat-Sun off.

## Resources

| Resource | Group | Unit | Rate |
| --- | --- | --- | --- |
| N.Rimmer |  |  |  |
| A.Moss |  |  |  |
| Vac Lab |  |  |  |
| W Spensley |  |  |  |
| W.Spensley |  |  |  |
| Electrical Engineer |  |  |  |
| Electrical Designer |  |  |  |
| Electrical Technician |  |  |  |
| Elec Technician |  |  |  |
| Elec Engineer |  |  |  |
| Mech Technician |  |  |  |
| RF Engineer |  |  |  |
| Mech Technician(75%) |  |  |  |
| RF Engineer(50%) |  |  |  |
| Tim Hayler | STFC |  | 59.26 |
| Andy Lintern | STFC |  | 47.23 |
| Peter Lau | Oxford |  | 23.57 |
| Geoff Barber | Imperial |  |  |
| Mike Bell | STFC |  | 37.76 |
| Eamonn Capocci | STFC |  | 37.76 |
| Craig McWaters | STFC |  | 47.23 |
| Merit1 | Merit |  | 30 |
| Merit2 | Merit |  | 30 |
| Merit3 | Merit |  | 30 |
| Designer (STFC) | STFC |  | 47.23 |
| Roger Hare | Imperial |  |  |
| Ken Long | Imperial |  |  |
| Paul Kyberd |  |  | 49.38 |
| Malcolm Ellis |  |  |  |
| Henry Nebrensky |  |  |  |
| David Forrest |  |  |  |
| Paul Soler |  |  |  |
| Adam Dobbs |  |  | 11.74 |
| Peter Dornan | Imperial |  |  |
| James Leaver |  |  |  |
| Marco Appollonio |  |  |  |
| Becky Seviour |  |  |  |
| Ray Gamet |  |  |  |
| John Cobb |  |  |  |
| Mark Raynor |  |  |  |
| Chris Booth |  |  |  |
| Paul Hodgson |  |  |  |
| Paul Smith |  |  |  |
| David Adey |  |  | 4.79 |
| Student |  | & | 15000 |
| Research Assistant |  |  | 46.78 |
| John Back | Warwick |  |  |
| Stewart | Warwick |  |  |
| Project Manager |  |  | 47 |
| STFC |  |  | 47.23 |
| Andy Nichols |  |  | 72.14 |
| Willie Spensley |  |  | 37 |
| Steve Griffiths |  |  | 72.14 |
| Jason Tarrant |  |  | 59.26 |
| Pierrick Hanlet |  |  |  |
| PH's Students |  |  |  |
| Jean-Sebastien Graulich |  |  |  |
| Mike Courthold |  |  | 59.26 |
| miceiocpc2 |  |  | 500 |
| miceecserv2 |  |  | 2000 |
| miceopipc2 |  |  | 555 |
| miceopipc3 |  |  | 555 |
| Steve Virostek | LBL |  |  |
| Allan DeMello | LBL |  |  |
| Matt Hills | STFC |  | 47.23 |
| Merit Staff (three people) |  |  | 90 |
| RFCC floor support |  |  | 35000 |
| AFC floor support |  |  | 35000 |
| Survey effort |  |  | 47.23 |
| INFN staff |  |  | 47.23 |
| Bolts & hardware |  |  | 2000 |
| Flanges & valves |  |  | 5000 |
| RF waveguide hardware |  |  | 50000 |
| AFC #3 cost |  |  | 356000 |
| Andy Moss |  |  | 60.98 |
| RF Engineer (DL) |  |  | 47.23 |
| Bellows |  |  | 10000 |
| LH2 system #3 |  |  |  |
| Tom Bradshaw | STFC |  | 88.89 |
| Wing Lau | OU |  |  |
| Mech tech (OU) | OU |  |  |
| Elec tech (OU) | OU |  |  |
| Post Doc (OU) | OU |  | 46.87 |
| John Tacon | OU |  |  |
| Dawson | OU |  |  |
| Electrical Engineer (DL) | DL |  | 47.23 |
| Electrical Designer (DL) | DL |  | 47.23 |
| Electrical Technician (DL) | DL |  | 47.23 |
| Mech Technician (DL) | DL |  | 47.23 |
| RF Engineer (DL) | DL |  | 47.23 |
| STG (obsolete) |  |  | 46 |
| Excel (obsolete) |  |  | 46 |
| MET |  |  | 46 |
| TEC |  |  | 46 |
| SHEFF |  |  | 46 |
| OM (obsolete) |  |  | 46 |
| Harry (obsolete) |  |  | 46 |
| EMcC (obsolete) |  |  | 46 |
| MG |  |  | 46 |
| Richard (obsolete) |  |  | 40.18 |
| Chris |  |  | 64.2 |
| Daresbury |  |  | 47.23 |
| Paul |  |  | 34.82 |
| Sheffield Workshop |  |  | 46.22 |
| Nick Bulmer |  |  | 40 |
| Controls Technician (DL) |  |  | 47.23 |
| Mike Tacon |  |  | 45 |
| Mech Technician (STFC) |  |  | 45 |
| Blackmore |  |  | 45 |
| Phil Warburton |  |  | 47.23 |
| Ian Mullacrane |  |  | 59.26 |
| David Matthewson |  |  | 53.78 |
| Contractor (OPUS) |  |  | 30 |
| Electrical Technician (STFC) |  |  | 47.23 |
| Stephen Watson |  |  | 37.76 |
| Cryo Technician (STFC) |  |  | 47.23 |
| Malcolm Ellis (FY10/11) |  |  | 48.51 |
| Paul Kyberd (FY10/11) |  |  |  |
| Henry Nebrensky (FY10/11) |  |  | 35.46 |
| Paul Soler (FY10/11) |  |  | 22.09 |
| James Leaver (FY10/11) |  |  | 24.92 |
| Ken Long (FY10/11) |  |  | 130.51 |
| Marco Appollonio (FY10/11) |  |  | 124.59 |
| John Cobb (FY10/11) |  |  | 18.52 |
| Chris Booth (FY10/11) |  |  | 22.78 |
| Paul Hodgson (FY10/11) |  |  | 88.72 |
| Paul Smith (FY10/11) |  |  | 52.71 |
| John Back (FY10/11) |  |  | 21.13 |
| Stewart (FY10/11) |  |  | 182.1 |
| Peter Dornan (FY10/11) |  |  | 1.02 |
| Geoff Barber (FY2010/11) |  |  | 17.02 |
| Roger Hare (FY2010/11) |  |  | 2.44 |
| Wing Lau (FY2010/11) |  |  | 14.41 |
| Mtech |  |  | 45 |
| Dawson (FY2010/11) |  |  | 7.53 |
| David Forrest (FY2010/11) |  |  | 8.63 |
| Brian Martlew |  |  | 72.14 |
| Roy Preece |  |  | 59.26 |
| W Spensley / Merrit |  |  | 180550 |
| Mary Shrewry |  |  | 45.59 |
| Alan Grant |  |  | 72.14 |
| Vishal Francis |  |  | 59.26 |
| System Engineer |  |  | 59.26 |
| STEP V - TIARA |  |  |  |
| RF System |  |  |  |
| Alan Muir |  |  |  |
| Gordon Stanford |  |  |  |
| Cryo Technician |  |  |  |
| Hyrogen |  |  |  |
| Hydrogen System |  |  |  |
| Electrical Infrastucture |  |  |  |
| Mechanical Infrastructure |  |  |  |
| Step IV |  |  |  |
| Step V |  |  |  |
| StepVI |  |  |  |
| EMR |  |  |  |
| TOF |  |  |  |
| Mechanical Integration |  |  |  |
| Focus Coils |  |  |  |
| Spectrometer |  |  |  |
| Milestones |  |  |  |
| Step VI |  |  |  |
| ISIS Run Cycle |  |  |  |
| Shipping |  |  |  |
| Pre Installation Work |  |  |  |
| Installation |  |  |  |
| Commissioning |  |  |  |
| Survey |  |  |  |
| Magnet Measurement |  |  |  |
| Air Conditioning |  |  |  |
| Diffuser |  |  |  |
| Tracker |  |  |  |
| Craig M |  |  |  |
| Linas P |  |  |  |
| Paul H |  |  |  |
| Mike N |  |  |  |
| Marcio Z |  |  |  |

## Schedule

| ID | WBS | Task | Type | Duration | Start | Finish | Predecessors | Complete | Remaining | Baseline start | Baseline finish | Baseline duration | Total slack | Constraint | Resources | Work | Cost |
| --- | --- | --- | --- | --- | --- | --- | --- | --- | --- | --- | --- | --- | --- | --- | --- | --- | --- |
| 1 | 1 | MICE HALL INSTALLATION SCHEDULE | milestone | 0d | 2008-09-01 A | 2008-09-01 A |  | 100% |  |  |  |  |  |  |  |  |  |
| 3 | 2 | **Milestones - Top Level** |  | 2881d | 2008-09-01 A | 2019-09-16 |  |  | 2881d |  |  |  | 0d |  | Milestones | 64912h | 1,500 |
| 4 | 2.1 | **Mechanical Integration** |  | 335d | 2009-10-05 A | 2011-01-17 |  |  | 335d |  |  |  | 2261d |  | Mechanical Infrastructure | 2680h |  |
| 5 | 2.1.1 | Rolling platforms ready for Step II | milestone | 0d | 2009-10-05 A | 2009-10-05 A | 138 | 100% |  | 2009-05-15 | 2009-05-15 | 0d |  | start no earlier than 2009-10-05 |  |  |  |
| 6 | 2.1.2 | TOF2 at RAL | milestone | 0d | 2009-11-24 A | 2009-11-24 A | 141 | 100% |  | 2009-06-30 | 2009-06-30 | 0d |  | start no earlier than 2009-11-24 |  |  |  |
| 7 | 2.1.3 | Step IV floor preparations begin | milestone | 0d | 2011-01-17 A | 2011-01-17 A |  | 100% |  |  |  |  |  | start no earlier than 2011-01-17 |  |  |  |
| 8 | 2.1.4 | Solid Lithium Hydride absorber at Fermilab | milestone | 0d | 2010-02-15 | 2010-02-15 |  |  |  | 2009-08-03 | 2009-08-03 | 0d | 2501d | start no earlier than 2010-02-15 |  |  |  |
| 9 | 2.2 | **Liquid hydrogen System** |  | 2472d | 2008-09-01 A | 2018-02-20 |  |  | 2472d |  |  |  | 409d |  | Hydrogen System | 19776h |  |
| 10 | 2.2.1 | **System A/R&D System** |  | 466d | 2010-12-16 A | 2012-09-28 |  |  | 466d |  |  |  | 1817d |  |  |  |  |
| 11 | 2.2.1.1 | LH2 R&D Delivery system at RAL (from AS scientific) | milestone | 0d | 2010-12-16 A | 2010-12-16 A | 130 | 100% |  |  |  |  |  | start no earlier than 2010-12-16 |  |  |  |
| 12 | 2.2.1.2 | Installation of System A/R&D Infrastructure complete | milestone | 0d | 2011-12-22 | 2011-12-22 | 571 |  |  |  |  |  | 2017d |  |  |  |  |
| 13 | 2.2.1.3 | Installation of System A/R&D components complete | milestone | 0d | 2011-08-08 | 2011-08-08 | 612 |  |  |  |  |  | 2115d |  |  |  |  |
| 14 | 2.2.1.4 | R&D Tests of System A/R&D complete | milestone | 0d | 2012-08-14 | 2012-08-14 | 1095 |  |  |  |  |  | 1849d |  |  |  |  |
| 15 | 2.2.1.5 | LH2 absorber #1 at RAL (KEK) | milestone | 0d | 2012-01-26 | 2012-01-26 | 131 |  |  | 2010-02-26 | 2010-02-26 | 0d | 1993d | start no earlier than 2012-01-26 |  |  |  |
| 16 | 2.2.1.6 | LH2 absorber #2 at RAL (KEK) | milestone | 0d | 2012-09-28 | 2012-09-28 | 132 |  |  | 2010-08-27 | 2010-08-27 | 0d | 1817d | start no earlier than 2012-09-28 |  |  |  |
| 17 | 2.2.2 | **System B** |  | 2147d | 2008-09-01 | 2016-11-22 |  |  |  |  |  |  | 734d |  |  |  |  |
| 18 | 2.2.2.1 | R&D Tests with KEK absorber | milestone | 0d | 2008-09-01 | 2008-09-01 |  |  |  |  |  |  | 2881d |  |  |  |  |
| 19 | 2.2.2.2 | Heater/Chiller Unit Delivery to RAL | milestone | 0d | 2012-11-05 | 2012-11-05 | 133 |  |  |  |  |  | 1791d |  |  |  |  |
| 20 | 2.2.2.3 | Hydride Bed Delivery to RAL | milestone | 0d | 2013-01-28 | 2013-01-28 | 134 |  |  |  |  |  | 1731d |  |  |  |  |
| 21 | 2.2.2.4 | Installation of System B Infrastructure complete | milestone | 0d | 2016-09-28 | 2016-09-28 | 630 |  |  |  |  |  | 773d |  |  |  |  |
| 22 | 2.2.2.5 | Installation of System B components complete | milestone | 0d | 2016-09-22 | 2016-09-22 | 640 |  |  |  |  |  | 777d |  |  |  |  |
| 23 | 2.2.2.6 | Commissioning of System B with AFC complete | milestone | 0d | 2016-11-22 | 2016-11-22 | 1120 |  |  |  |  |  | 734d |  |  |  |  |
| 24 | 2.2.3 | **System C** |  | 1132d | 2013-10-21 | 2018-02-20 |  |  |  |  |  |  | 409d |  |  |  |  |
| 25 | 2.2.3.1 | Heater/Chiller Unit Delivery to RAL | milestone | 0d | 2013-10-21 | 2013-10-21 | 135 |  |  |  |  |  | 1541d |  |  |  |  |
| 26 | 2.2.3.2 | Hydride Bed Delivery to RAL | milestone | 0d | 2014-01-06 | 2014-01-06 | 136 |  |  |  |  |  | 1486d |  |  |  |  |
| 27 | 2.2.3.3 | Installation of System C Infrastructure complete | milestone | 0d | 2017-12-25 | 2017-12-25 | 650 |  |  |  |  |  | 450d |  |  |  |  |
| 28 | 2.2.3.4 | Installation of System C components complete | milestone | 0d | 2017-12-01 | 2017-12-01 | 660 |  |  |  |  |  | 466d |  |  |  |  |
| 29 | 2.2.3.5 | Commissioning of System C with AFC complete | milestone | 0d | 2018-02-20 | 2018-02-20 | 1136 |  |  |  |  |  | 409d |  |  |  |  |

| ID | WBS | Task | Type | Duration | Start | Finish | Predecessors | Complete | Baseline start | Baseline finish | Baseline duration | Total slack | Free slack | Constraint | Resources | Work | Cost |
| --- | --- | --- | --- | --- | --- | --- | --- | --- | --- | --- | --- | --- | --- | --- | --- | --- | --- |
| 30 | 2.3 | **RF system** |  | 1296d | 2013-01-16 | 2018-01-05 |  |  |  |  |  | 442d |  |  | RF System | 10368h | 1,500 |
| 31 | 2.3.1 | Amplifier system #1 Delivered | milestone | 0d | 2013-03-04 | 2013-03-04 | 100 |  |  |  |  | 1705d |  |  |  |  |  |
| 32 | 2.3.2 | Amplfier#1 installation complete | milestone | 0d | 2013-03-18 | 2013-03-18 | 822 |  |  |  |  | 1695d |  |  |  |  |  |
| 33 | 2.3.3 | Waveguides & dummy loads system #1 delivered | milestone | 0d | 2013-01-16 | 2013-01-16 | 113 |  |  |  |  | 1738d |  |  |  |  |  |
| 34 | 2.3.4 | Waveguides & dummy loads system #2 delivered | milestone | 0d | 2013-01-16 | 2013-01-16 | 116 |  |  |  |  | 1738d |  |  |  |  |  |
| 35 | 2.3.5 | Amplifier system #2 Delivered | milestone | 0d | 2013-10-02 | 2013-10-02 | 103 |  |  |  |  | 1553d |  |  |  |  | 500 |
| 36 | 2.3.6 | Amplifier system #3 Delivered | milestone | 0d | 2014-05-06 | 2014-05-06 | 106 |  |  |  |  | 1399d |  |  |  |  | 500 |
| 37 | 2.3.7 | Amplifier system #4 Delivered | milestone | 0d | 2014-11-04 | 2014-11-04 | 109 |  |  |  |  | 1269d |  |  |  |  | 500 |
| 38 | 2.3.8 | Amplfier#2 installation complete | milestone | 0d | 2013-10-16 | 2013-10-16 | 825 |  |  |  |  | 1543d |  |  |  |  |  |
| 39 | 2.3.9 | Amplfier#3 installation complete | milestone | 0d | 2014-05-20 | 2014-05-20 | 828 |  |  |  |  | 1389d |  |  |  |  |  |
| 40 | 2.3.10 | Amplfier#4 installation complete | milestone | 0d | 2014-11-18 | 2014-11-18 | 831 |  |  |  |  | 1259d |  |  |  |  |  |
| 41 | 2.3.11 | Cavity & RFCC module #1 delivered to RAL | milestone | 0d | 2017-01-03 | 2017-01-03 | 143 |  |  |  |  | 705d |  |  |  |  |  |
| 42 | 2.3.12 | Cavity & RFCC module #2 delivered to RAL | milestone | 0d | 2018-01-05 | 2018-01-05 | 144 |  |  |  |  | 442d |  |  |  |  |  |
| 43 | 2.4 | **Spectrometer Solenoids (Tracker)** |  | 0d | 2013-08-23 | 2013-08-23 |  |  |  |  |  | 1392.06d |  |  | Spectrometer |  |  |
| 44 | 2.4.1 | Upstream Solenoid arrives at RAL | milestone | 0d | 2013-08-23 | 2013-08-23 | 121 |  |  |  |  | 1392.06d | 0d |  |  |  |  |
| 45 | 2.4.2 | Downstream Solenoid arrives at RAL | milestone | 0d | 2013-08-23 | 2013-08-23 | 125 |  |  |  |  | 1581d |  |  |  |  |  |
| 46 | 2.5 | **AFC - Focus coils** |  | 98d | 2012-10-31 | 2013-03-18 |  |  |  |  |  | 1696d |  |  | Focus Coils | 784h |  |
| 47 | 2.5.1 | FC module #1 at RAL | milestone | 0d | 2012-10-31 | 2012-10-31 | 127 |  | 2010-02-26 | 2010-02-26 | 0d | 1794d |  |  |  |  |  |
| 48 | 2.5.2 | AFC #1 installed in R9 ready for field mapping | milestone | 0d | 2012-12-25 | 2012-12-25 | 173 |  |  |  |  | 1754.37d |  |  |  |  |  |
| 49 | 2.5.3 | AFC #1 field mapping in R9 complete | milestone | 0d | 2013-01-08 | 2013-01-08 | 177 |  |  |  |  | 1744.37d |  |  |  |  |  |
| 50 | 2.5.4 | AFC #1 ready for installation in MICE Hall | milestone | 0d | 2013-01-17 | 2013-01-17 | 182 |  |  |  |  | 1737.37d |  |  |  |  |  |
| 51 | 2.5.5 | Focus coil magnet measured in step IV position | milestone | 0d | 2013-03-11 | 2013-03-11 | 1085 |  |  |  |  | 1700.37d |  |  |  |  |  |
| 52 | 2.5.6 | FC module #2 at RAL | milestone | 0d | 2013-03-18 | 2013-03-18 | 128 |  | 2010-08-27 | 2010-08-27 | 0d | 1696d |  |  |  |  |  |
| 53 | 2.6 | **TOF** |  | 0d | 2009-11-24 A | 2009-11-24 A |  | 100% |  |  |  |  |  |  | TOF |  |  |
| 54 | 2.6.1 | TOF2 at RAL | milestone | 0d | 2009-11-24 A | 2009-11-24 A |  | 100% | 2009-06-30 | 2009-06-30 | 0d |  |  | start no earlier than 2009-11-24 |  |  |  |

| ID | WBS | Task | Type | Duration | Start | Finish | Predecessors | Complete | Remaining | Total slack | Resources | Work |
| --- | --- | --- | --- | --- | --- | --- | --- | --- | --- | --- | --- | --- |
| 55 | 2.7 | **MICE Step IV Installation & commissioning** |  | 2068d | 2008-09-01 A | 2016-08-03 |  |  | 2068d | 813d | Step IV | 16544h |
| 56 | 2.7.1 | Step IV base plate installation complete | milestone | 0d | 2011-12-06 A | 2011-12-06 A | 861 | 100% |  |  |  |  |
| 57 | 2.7.2 | AFC#1 rail system installation complete | milestone | 0d | 2012-01-20 A | 2012-01-20 A | 867 | 100% |  |  |  |  |
| 58 | 2.7.3 | Spectrometer Solenoid rolling platform installation complete | milestone | 0d | 2008-09-01 A | 2008-09-01 A | 873 | 100% |  |  |  |  |
| 59 | 2.7.4 | AFC #1 magnet measured in step IV position | milestone | 0d | 2013-05-09 | 2013-05-09 | 890 |  |  | 1657d |  |  |
| 60 | 2.7.5 | Upstream Spectrometer Solenoid & Virostek plate Installation Complete | milestone | 0d | 2013-10-04 | 2013-10-04 | 920 |  |  | 1551d |  |  |
| 61 | 2.7.6 | Spectrometer Solenoid (Upstream) magnet measured in step IV position | milestone | 0d | 2013-11-25 | 2013-11-25 | 925 |  |  | 1515d |  |  |
| 62 | 2.7.7 | Upstream Tracker & Solenoid Installation complete | milestone | 0d | 2014-01-31 | 2014-01-31 | 954 |  |  | 1466d |  |  |
| 63 | 2.7.8 | Downstream Spectrometer Solenoid Installation Complete | milestone | 0d | 2013-12-23 | 2013-12-23 | 957 |  |  | 1495d |  |  |
| 64 | 2.7.9 | Spectrometer Solenoid (Downstream) magnet measured in step IV position | milestone | 0d | 2014-02-11 | 2014-02-11 | 962 |  |  | 1459d |  |  |
| 65 | 2.7.10 | Tracker #1 Installation complete | milestone | 0d | 2014-04-18 | 2014-04-18 | 987 |  |  | 1411d |  |  |
| 66 | 2.7.11 | MICE step IV installation complete | milestone | 0d | 2014-06-04 | 2014-06-04 | 991 |  |  | 1378d |  |  |
| 67 | 2.7.12 | MICE step IV commissioning complete | milestone | 0d | 2016-08-03 | 2016-08-03 | 1187 |  |  | 813d |  |  |
| 68 | 2.8 | **MICE Step V Installation & commissioning** |  | 261d | 2016-10-28 | 2017-10-30 |  |  |  | 490d | Step V | 2088h |
| 69 | 2.8.1 | Step V base plate installation complete | milestone | 0d | 2016-10-28 | 2016-10-28 | 1016 |  |  | 751d |  |  |
| 70 | 2.8.2 | AFC #2 Installation complete | milestone | 0d | 2017-01-12 | 2017-01-12 | 1017 |  |  | 697d |  |  |
| 71 | 2.8.3 | RFCC #1 Installation complete | milestone | 0d | 2017-05-29 | 2017-05-29 | 1024 |  |  | 600d |  |  |
| 72 | 2.8.4 | Step V Spectrometer Solenoid # 2 Installation Complete | milestone | 0d | 2017-06-19 | 2017-06-19 | 1033 |  |  | 585d |  |  |
| 73 | 2.8.5 | MICE step V installation complete | milestone | 0d | 2017-06-26 | 2017-06-26 | 1035 |  |  | 580d |  |  |
| 74 | 2.8.6 | MICE step V commissioning complete | milestone | 0d | 2017-10-30 | 2017-10-30 | 1203 |  |  | 490d |  |  |
| 75 | 2.9 | **MICE Step VI Installation & commissioning** |  | 431d | 2018-01-19 | 2019-09-16 |  |  |  | 0d | Step VI | 3448h |
| 76 | 2.9.1 | Step VI base plate installation complete | milestone | 0d | 2018-01-19 | 2018-01-19 | 1043 |  |  | 431d |  |  |
| 77 | 2.9.2 | RFCC #2 Installation complete | milestone | 0d | 2018-05-31 | 2018-05-31 | 1063 |  |  | 337d |  |  |
| 78 | 2.9.3 | AFC #3 Installation complete | milestone | 0d | 2018-08-20 | 2018-08-20 | 1072 |  |  | 280d |  |  |
| 79 | 2.9.4 | Step VI Spectrometer Solenoid # 2 Installation Complete | milestone | 0d | 2018-09-10 | 2018-09-10 | 1079 |  |  | 265d |  |  |
| 80 | 2.9.5 | MICE step VI installation complete | milestone | 0d | 2018-09-17 | 2018-09-17 | 1081 |  |  | 260d |  |  |
| 81 | 2.9.6 | MICE step VI commissioning complete | milestone | 0d | 2019-09-16 | 2019-09-16 | 1220 |  |  | 0d |  |  |

| ID | WBS | Task | Type | Duration | Start | Finish | Predecessors | Remaining | Total slack | Free slack | Constraint | Calendar | Resources | Work | Actual work | Cost | Actual cost |
| --- | --- | --- | --- | --- | --- | --- | --- | --- | --- | --- | --- | --- | --- | --- | --- | --- | --- |
| 83 | 3 | **ISIS Run Cycle** |  | 1010d | 2011-07-12 | 2015-01-29 |  |  | 1207d |  |  | ISIS Run Cycle | ISIS Run Cycle | 7128h |  |  |  |
| 84 | 3.1 | Cycle 2011/02 |  | 31d | 2011-07-12 | 2011-08-11 |  |  | 2186d |  | start no earlier than 2011-07-12 | ISIS Run Cycle |  |  |  |  |  |
| 85 | 3.2 | Cycle 2011/03 |  | 31d | 2011-09-27 | 2011-10-27 |  |  | 2121d |  | start no earlier than 2011-09-27 | ISIS Run Cycle |  |  |  |  |  |
| 86 | 3.3 | Cycle 2011/04 |  | 31d | 2011-11-22 | 2011-12-22 |  |  | 2071d |  | start no earlier than 2011-11-22 | ISIS Run Cycle |  |  |  |  |  |
| 87 | 3.4 | Cycle 2011/05 |  | 38d | 2012-02-21 | 2012-03-29 |  |  | 1987d |  | finish no earlier than 2012-03-29 | ISIS Run Cycle |  |  |  |  |  |
| 88 | 3.5 | Cycle 2012/01 |  | 31d | 2012-05-15 | 2012-06-14 |  |  | 1924d |  | start no earlier than 2012-05-15 | ISIS Run Cycle |  |  |  |  |  |
| 89 | 3.6 | Cycle 2012/02 |  | 31d | 2012-07-10 | 2012-08-09 |  |  | 1876d |  | start no earlier than 2012-07-10 | ISIS Run Cycle |  |  |  |  |  |
| 90 | 3.7 | Cycle 2012/03 |  | 31d | 2012-10-02 | 2012-11-01 |  |  | 1808d |  | start no earlier than 2012-10-02 | ISIS Run Cycle |  |  |  |  |  |
| 91 | 3.8 | Cycle 2012/04 |  | 31d | 2012-11-20 | 2012-12-20 |  |  | 1765d |  | start no earlier than 2012-11-20 | ISIS Run Cycle |  |  |  |  |  |
| 92 | 3.9 | Cycle 2012/05 |  | 31d | 2013-02-19 | 2013-03-21 |  |  | 1692d |  | start no earlier than 2013-02-19 | ISIS Run Cycle |  |  |  |  |  |
| 93 | 3.10 | Long shutdown 2014/15 |  | 128d | 2014-08-05 | 2015-01-29 |  |  | 1207d |  | finish no earlier than 2015-01-29 | ISIS Run Cycle |  |  |  |  |  |
| 95 | 4 | **Shipping** |  | 2154d | 2009-10-05 A | 2018-01-05 |  | 2154d | 442d |  |  | Shipping | Shipping | 40832h | 3560h | 31,500 | 30,000 |
| 96 | 4.1 | **RF system** |  | 474d | 2013-01-10 | 2014-11-04 |  |  | 1259d |  |  | Shipping | RF System | 3864h |  | 1,500 |  |
| 98 | 4.1.1 | **Amplifiers** |  | 2d | 2013-03-01 | 2013-03-04 |  |  | 1658d |  |  | Shipping | STEP V - TIARA | 16h |  |  |  |
| 99 | 4.1.1.1 | **Ship Amplifier system #1 to RAL from DL** |  | 2d | 2013-03-01 | 2013-03-04 |  |  | 1658d | 0d | start no earlier than 2013-03-01 | Shipping |  |  |  |  |  |
| 100 | 4.1.1.1.1 | Amplifier system #1 Delivered | milestone | 0d | 2013-03-04 | 2013-03-04 | 99 |  | 1658d | 0d |  | Shipping |  |  |  |  |  |
| 101 | 4.1.1.2 | **System #2** |  | 2d | 2013-10-01 | 2013-10-02 |  |  | 1506d |  |  | Shipping | STEP V - TIARA | 16h |  | 500 |  |
| 102 | 4.1.1.2.1 | Ship Amplifier system #2 to RAL from DL |  | 2d | 2013-10-01 | 2013-10-02 |  |  | 1506d | 0d | start no earlier than 2013-10-01 | Shipping |  |  |  |  |  |
| 103 | 4.1.1.2.2 | Amplifier system #2 Delivered | milestone | 0d | 2013-10-02 | 2013-10-02 | 102 |  | 1506d | 0d |  | Shipping |  |  |  | 500 |  |
| 104 | 4.1.1.3 | **System #3** |  | 2d | 2014-05-05 | 2014-05-06 |  |  | 1352d |  |  | Shipping |  |  |  | 500 |  |
| 105 | 4.1.1.3.1 | Ship Amplifier system #3 to RAL from DL |  | 2d | 2014-05-05 | 2014-05-06 |  |  | 1352d | 0d | start no earlier than 2014-05-05 | Shipping |  |  |  |  |  |
| 106 | 4.1.1.3.2 | Amplifier system #3 Delivered | milestone | 0d | 2014-05-06 | 2014-05-06 | 105 |  | 1352d | 0d |  | Shipping |  |  |  | 500 |  |
| 107 | 4.1.1.4 | **System #4** |  | 2d | 2014-11-03 | 2014-11-04 |  |  | 1222d |  |  | Shipping |  |  |  | 500 |  |
| 108 | 4.1.1.4.1 | Ship Amplifier system #4 to RAL from DL |  | 2d | 2014-11-03 | 2014-11-04 |  |  | 1222d | 0d | start no earlier than 2014-11-03 | Shipping |  |  |  |  |  |
| 109 | 4.1.1.4.2 | Amplifier system #4 Delivered | milestone | 0d | 2014-11-04 | 2014-11-04 | 108 |  | 1222d | 0d |  | Shipping |  |  |  | 500 |  |

| ID | WBS | Task | Type | Duration | Start | Finish | Predecessors | Complete | Remaining | Baseline start | Baseline finish | Baseline duration | Total slack | Free slack | Constraint | Calendar | Resources | Work |
| --- | --- | --- | --- | --- | --- | --- | --- | --- | --- | --- | --- | --- | --- | --- | --- | --- | --- | --- |
| 110 | 4.1.2 | **Waveguides** |  | 5d | 2013-01-10 | 2013-01-16 |  |  |  |  |  |  | 1728d |  |  | Shipping |  | 40h |
| 111 | 4.1.2.1 | **System#1** |  | 5d | 2013-01-10 | 2013-01-16 |  |  |  |  |  |  | 1728d |  |  | Shipping | STEP V - TIARA | 40h |
| 112 | 4.1.2.1.1 | Delivery of waveguides & dummy loads system #1 |  | 5d | 2013-01-10 | 2013-01-16 |  |  |  |  |  |  | 1728d | 0d | start no earlier than 2013-01-10 | Shipping |  |  |
| 113 | 4.1.2.1.2 | Waveguides & dummy loads system #1 delivered | milestone | 0d | 2013-01-16 | 2013-01-16 | 112 |  |  |  |  |  | 1728d | 0d |  | Shipping |  |  |
| 114 | 4.1.2.2 | **System#2** |  | 5d | 2013-01-10 | 2013-01-16 |  |  |  |  |  |  | 1728d |  |  | Shipping |  |  |
| 115 | 4.1.2.2.1 | Delivery of waveguides & dummy loads system #2 |  | 5d | 2013-01-10 | 2013-01-16 |  |  |  |  |  |  | 1728d | 0d | start no earlier than 2013-01-10 | Shipping |  |  |
| 116 | 4.1.2.2.2 | Waveguides & dummy loads system #2 delivered | milestone | 0d | 2013-01-16 | 2013-01-16 | 115 |  |  |  |  |  | 1728d | 0d |  | Shipping |  |  |
| 117 | 4.2 | **Spectrometer Solenoids (Tracker)** |  | 341d | 2012-05-04 | 2013-08-23 |  |  |  |  |  |  | 73d |  |  | Shipping | Spectrometer | 2784h |
| 118 | 4.2.1 | **Spectrometer Solenoid Upstream** |  | 341d | 2012-05-04 | 2013-08-23 |  |  |  |  |  |  | 7d |  |  | Shipping | STEP V - TIARA | 56h |
| 119 | 4.2.1.1 | Package Upstream solenoid |  | 1w | 2012-05-04 | 2012-05-10 |  |  |  |  |  |  | 303d | 231d | start no earlier than 2012-05-04 | Shipping |  |  |
| 120 | 4.2.1.2 | Ship Upstream Solenoid to UK |  | 8w | 2013-07-01 | 2013-08-23 | 119 |  |  |  |  |  | 7d |  | start no earlier than 2013-07-01 | Shipping |  |  |
| 121 | 4.2.1.3 | Upstream Solenoid arrives at RAL | milestone | 0d | 2013-08-23 | 2013-08-23 | 120 |  |  |  |  |  | 7d | 0d | start no earlier than 2012-12-21 | Shipping |  |  |
| 122 | 4.2.2 | **Spectrometer Solenoid Downstream** |  | 126d | 2013-03-01 | 2013-08-23 |  |  |  |  |  |  | 73d |  |  | Shipping |  |  |
| 123 | 4.2.2.1 | Package Downstream Solenoid |  | 1w | 2013-03-01 | 2013-03-07 |  |  |  |  |  |  | 154d | 81d | start no earlier than 2013-03-01 | Shipping |  |  |
| 124 | 4.2.2.2 | Ship Downstream Solenoid to UK |  | 8w | 2013-07-01 | 2013-08-23 | 123 |  |  |  |  |  | 73d | 0d | start no earlier than 2013-07-01 | Shipping |  |  |
| 125 | 4.2.2.3 | Downstream Solenoid arrives at RAL | milestone | 0d | 2013-08-23 | 2013-08-23 | 124 |  |  |  |  |  | 73d | 0d | start no earlier than 2013-01-31 | Shipping |  |  |
| 126 | 4.3 | **AFC - Focus coils - Tesla** |  | 98d | 2012-10-31 | 2013-03-18 |  |  |  |  |  |  | 190.37d |  |  | Shipping | Focus Coils | 784h |
| 127 | 4.3.1 | FC module #1 at RAL | milestone | 0d | 2012-10-31 | 2012-10-31 |  |  |  | 2010-02-26 | 2010-02-26 | 0d | 190.37d | 0d | start no earlier than 2012-10-31 | Shipping |  |  |
| 128 | 4.3.2 | FC module #2 at RAL | milestone | 0d | 2013-03-18 | 2013-03-18 |  |  |  | 2010-08-27 | 2010-08-27 | 0d | 1696d | 0d | start no earlier than 2013-03-18 | Shipping |  |  |
| 129 | 4.4 | **Liquid Hydrogen System** |  | 836d | 2010-10-22 A | 2014-01-06 |  |  | 836d |  |  |  | 1486d |  |  | Shipping | Hydrogen System | 6688h |
| 130 | 4.4.1 | LH2 R&D Delivery system at RAL (from AS scientific) | milestone | 0d | 2010-10-22 A | 2010-10-22 A |  | 100% |  |  |  |  |  |  | start no earlier than 2010-10-22 | Shipping |  |  |
| 131 | 4.4.2 | LH2 absorber #1 at RAL (KEK) | milestone | 0d | 2011-07-01 | 2011-07-01 |  |  |  | 2010-02-26 | 2010-02-26 | 0d | 2142d | 149d | start no earlier than 2011-07-01 | Shipping |  |  |
| 132 | 4.4.3 | LH2 absorber #2 at RAL (KEK) | milestone | 0d | 2012-09-28 | 2012-09-28 |  |  |  | 2010-08-27 | 2010-08-27 | 0d | 1817d | 0d | start no earlier than 2012-09-28 | Shipping |  |  |
| 133 | 4.4.4 | Heater/Chiller Unit Delivery to RAL (sys B) | milestone | 0d | 2012-11-05 | 2012-11-05 |  |  |  |  |  |  | 1791d | 0d | start no earlier than 2012-11-05 | Shipping |  |  |
| 134 | 4.4.5 | Hydride Bed Delivery to RAL (sys B) | milestone | 0d | 2013-01-28 | 2013-01-28 |  |  |  |  |  |  | 1731d | 0d | start no earlier than 2013-01-28 | Shipping |  |  |
| 135 | 4.4.6 | Heater/Chiller Unit Delivery to RAL (sys C) | milestone | 0d | 2013-10-21 | 2013-10-21 |  |  |  |  |  |  | 1541d | 0d | start no earlier than 2013-10-21 | Shipping |  |  |
| 136 | 4.4.7 | Hydride Bed Delivery to RAL (sys C) | milestone | 0d | 2014-01-06 | 2014-01-06 |  |  |  |  |  |  | 1486d | 0d | start no earlier than 2014-01-06 | Shipping |  |  |

| ID | WBS | Task | Type | Duration | Start | Finish | Predecessors | Complete | Remaining | Baseline start | Baseline finish | Baseline duration | Total slack | Free slack | Constraint | Calendar | Resources | Work | Actual work | Cost | Actual cost |
| --- | --- | --- | --- | --- | --- | --- | --- | --- | --- | --- | --- | --- | --- | --- | --- | --- | --- | --- | --- | --- | --- |
| 137 | 4.5 | **Mechanical integration Components** |  | 445d | 2009-10-05 A | 2011-06-20 A |  | 100% |  | 2008-07-21 | 2011-05-02 | 727d? |  |  |  | Shipping | Mechanical Infrastructure | 3560h | 3560h | 30,000 | 30,000 |
| 138 | 4.5.1 | Rolling platforms ready for Step II | milestone | 0d | 2009-10-05 A | 2009-10-05 A |  | 100% |  | 2009-05-15 | 2009-05-15 | 0d |  |  | start no earlier than 2009-10-05 | Shipping |  |  |  |  |  |
| 139 | 4.5.2 | Deliver rail system for AFC and RFCC (Rolling platform replacement)-Norbert | milestone | 0d | 2011-06-20 A | 2011-06-20 A |  | 100% |  |  |  |  |  |  | start no earlier than 2011-06-20 | Shipping |  |  |  | 30,000 | 30,000 |
| 140 | 4.6 | **TOF 01 & 02** |  | 0d | 2009-11-24 A | 2009-11-24 A |  | 100% |  |  |  |  |  |  |  | Shipping | TOF |  |  |  |  |
| 141 | 4.6.1 | TOF2 at RAL | milestone | 0d | 2009-11-24 A | 2009-11-24 A |  | 100% |  | 2009-06-30 | 2009-06-30 | 0d |  |  | start no earlier than 2009-11-24 | Shipping |  |  |  |  |  |
| 142 | 4.7 | **Cavities & RFCC's** |  | 263d | 2017-01-03 | 2018-01-05 |  |  |  |  |  |  | 0d |  |  | Shipping | RF System | 2104h |  |  |  |
| 143 | 4.7.1 | Cavity & RFCC module #1 delivered to RAL | milestone | 0d | 2017-01-03 | 2017-01-03 |  |  |  |  |  |  | 2d | 0d | start no earlier than 2017-01-03 | Shipping |  |  |  |  |  |
| 144 | 4.7.2 | Cavity & RFCC module #2 delivered to RAL | milestone | 0d | 2018-01-05 | 2018-01-05 |  |  |  |  |  |  | 0d |  | start no earlier than 2018-01-05 | Shipping |  |  |  |  |  |
| 145 | 4.8 | **EMR** |  | 477d | 2011-06-01 A | 2013-03-29 |  |  | 477d |  |  |  | 147d |  |  | Shipping | EMR | 3816h |  |  |  |
| 146 | 4.8.1 | EMR at RAL for initial tests | milestone | 0d | 2011-06-01 A | 2011-06-01 A |  | 100% |  |  |  |  |  |  | start no earlier than 2011-06-01 | Shipping |  |  |  |  |  |
| 147 | 4.8.2 | EMR at RAL final delivery | milestone | 0d | 2013-03-29 | 2013-03-29 |  |  |  |  |  |  | 147d | 0d | start no earlier than 2013-03-29 | Shipping |  |  |  |  |  |
| 148 | 4.9 | **Diffuser** |  | 0d | 2012-08-15 | 2012-08-15 |  |  |  |  |  |  | 1849d |  |  |  | Diffuser |  |  |  |  |
| 149 | 4.9.1 | Diffuser delivered to RAL | milestone | 0d | 2012-08-15 | 2012-08-15 |  |  |  |  |  |  | 1849d |  | start no earlier than 2012-08-15 |  |  |  |  |  |  |
| 151 | 5 | **Pre Installation Work** |  | 426.63d | 2011-06-01 A | 2013-01-17 |  | 59% | 174.28d |  |  |  | 190.37d |  |  |  | Pre Installation Work | 5205.33h | 2069.59h |  |  |
| 152 | 5.1 | **EMR** |  | 58d | 2011-06-01 A | 2011-08-19 A |  | 100% |  |  |  |  |  |  |  |  | EMR | 696h | 696h |  |  |
| 153 | 5.1.1 | Install EMR (3 modules in Box) behind KL |  | 4w | 2011-06-01 A | 2011-06-28 A | 146 | 100% |  |  |  |  |  |  |  |  |  |  |  |  |  |
| 154 | 5.1.2 | EMR pre testing |  | 39d | 2011-07-05 A | 2011-08-12 A | 153 | 100% |  |  |  |  |  |  |  | ISIS Run Cycle | ISIS Run Cycle [74.4%] | 232h | 232h |  |  |
| 155 | 5.1.3 | EMR pre testing complete | milestone | 0d | 2011-08-12 A | 2011-08-12 A | 154 | 100% |  |  |  |  |  |  |  |  |  |  |  |  |  |
| 156 | 5.1.4 | Ship EMR back to CERN |  | 5d | 2011-08-15 A | 2011-08-19 A | 155 | 100% |  |  |  |  |  |  |  |  |  |  |  |  |  |
| 157 | 5.2 | **AFC#1 Field tests R9** |  | 56.63d | 2012-10-31 | 2013-01-17 |  |  |  |  |  |  | 190.37d |  |  |  | Focus Coils | 848.27h |  |  |  |
| 158 | 5.2.1 | Installation & connection of services |  | 10d | 2012-10-31 | 2012-11-13 | 127 |  |  |  |  |  | 190.37d | 0d |  |  |  |  |  |  |  |
| 159 | 5.2.2 | **Commissioning test at RAL** |  | 22.63d | 2012-11-14 | 2012-12-14 |  |  |  |  |  |  | 190.37d |  |  |  |  | 395.2h |  |  |  |
| 160 | 5.2.2.1 | System wiring and comissiong test setup |  | 3d | 2012-11-14 | 2012-11-16 | 158 |  |  |  |  |  | 190.37d | 0d |  |  | Craig M; Linas P | 48h |  |  |  |
| 161 | 5.2.2.2 | Cooldown to 80K using LN2 |  | 4.5d | 2012-11-19 | 2012-11-23 | 160 |  |  |  |  |  | 190.37d | 0d |  |  | Paul H; Linas P | 72h |  |  |  |
| 162 | 5.2.2.3 | Cooldown from 80K to 4K using 1000litre of Lhe |  | 1.5w | 2012-11-23 | 2012-12-04 | 161 |  |  |  |  |  | 190.37d | 0d |  |  | Mike N; Linas P | 120h |  |  |  |
| 163 | 5.2.2.4 | Ramp up to a low current and operation check of Quench protection system |  | 0.5d | 2012-12-05 | 2012-12-05 | 162 |  |  |  |  |  | 190.37d | 0d |  |  | Mike N; Linas P | 8h |  |  |  |
| 164 | 5.2.2.5 | Cooldown to 4K again |  | 1.5d | 2012-12-05 | 2012-12-06 | 163 |  |  |  |  |  | 190.37d | 0d |  |  | Mike N; Linas P | 24h |  |  |  |
| 165 | 5.2.2.6 | Step by step ramp up to full current with Flip mode |  | 2d | 2012-12-07 | 2012-12-10 | 164 |  |  |  |  |  | 190.37d | 0d |  |  | Mike N; Craig M; Linas P | 48h |  |  |  |
| 166 | 5.2.2.7 | Ramp down to 0A |  | 0.1d | 2012-12-11 | 2012-12-11 | 165 |  |  |  |  |  | 190.37d | 0d |  |  | Mike N; Craig M; Linas P | 2.4h |  |  |  |
| 167 | 5.2.2.8 | Step by step ramp up to full current with Non Flip mode |  | 2d | 2012-12-11 | 2012-12-13 | 166 |  |  |  |  |  | 190.37d | 0d |  |  | Mike N; Craig M; Marcio Z | 48h |  |  |  |
| 168 | 5.2.2.9 | Ramp down to 0A |  | 0.03d | 2012-12-13 | 2012-12-13 | 167 |  |  |  |  |  | 190.37d | 0d |  |  | Mike N; Craig M; Marcio Z | 0.8h |  |  |  |
| 169 | 5.2.2.10 | Mount Absorber module and safety windows |  | 0.5d | 2012-12-13 | 2012-12-13 | 168 |  |  |  |  |  | 190.37d | 0d |  |  | Paul H; Marcio Z | 8h |  |  |  |
| 170 | 5.2.2.11 | Final vacuum leak check of Absorber space and vacuum insulation space |  | 1d | 2012-12-13 | 2012-12-14 | 169 |  |  |  |  |  | 190.37d | 0d |  |  | Paul H; Linas P | 16h |  |  |  |
| 171 | 5.2.3 | Cool down |  | 5d | 2012-12-14 | 2012-12-21 | 170 |  |  |  |  |  | 190.37d | 0d |  |  |  |  |  |  |  |
| 172 | 5.2.4 | Ramp up current |  | 2d | 2012-12-21 | 2012-12-25 | 171 |  |  |  |  |  | 190.37d | 0d |  |  |  |  |  |  |  |
| 173 | 5.2.5 | AFC installed in R9 ready for field mapping | milestone | 0d | 2012-12-25 | 2012-12-25 | 172 |  |  |  |  |  | 190.37d | 0d |  |  |  |  |  |  |  |

Notes:
- 143: Need to confirm this shipping date!!
- 144: Need to confirm this shipping date!!
- 159: Commissioning test shedule provided by TESLA 1/6/12

| ID | WBS | Task | Type | Duration | Start | Finish | Predecessors | Complete | Remaining | Total slack | Free slack | Constraint | Resources | Work | Actual work | Cost | Actual cost |
| --- | --- | --- | --- | --- | --- | --- | --- | --- | --- | --- | --- | --- | --- | --- | --- | --- | --- |
| 174 | 5.2.6 | **Field Mapping at full field** |  | 10d | 2012-12-25 | 2013-01-08 | 173 |  |  | 190.37d | 0d |  |  |  |  |  |  |
| 175 | 5.2.6.1 | Set-up |  | 5d | 2012-12-25 | 2013-01-01 |  |  |  | 190.37d | 0d |  |  |  |  |  |  |
| 176 | 5.2.6.2 | Mapping |  | 5d | 2013-01-01 | 2013-01-08 | 175 |  |  | 190.37d | 0d |  |  |  |  |  |  |
| 177 | 5.2.6.3 | AFC #1 field mapping in R9 complete | milestone | 0d | 2013-01-08 | 2013-01-08 | 176 |  |  | 190.37d | 0d |  |  |  |  |  |  |
| 178 | 5.2.7 | **Dismantle AFC#1 in R9** |  | 7d | 2013-01-08 | 2013-01-17 | 177 |  |  | 190.37d |  |  |  |  |  |  |  |
| 179 | 5.2.7.1 | warm up |  | 2d | 2013-01-08 | 2013-01-10 |  |  |  | 190.37d | 0d |  |  |  |  |  |  |
| 180 | 5.2.7.2 | Disconnect all services |  | 3d | 2013-01-10 | 2013-01-15 | 179 |  |  | 190.37d | 0d |  |  |  |  |  |  |
| 181 | 5.2.7.3 | Transfer to MICE Hall |  | 2d | 2013-01-15 | 2013-01-17 | 180 |  |  | 190.37d | 0d |  |  |  |  |  |  |
| 182 | 5.2.7.4 | AFC#1 ready for installation in MICE Hall | milestone | 0d | 2013-01-17 | 2013-01-17 | 181 |  |  | 190.37d | 0d |  |  |  |  |  |  |
| 183 | 5.3 | **Survey** |  | 13d | 2012-01-19 A | 2012-02-06 A |  | 100% |  |  |  |  | Survey | 208h | 208h |  |  |
| 184 | 5.3.1 | Confirm dimensions/position of south mezzanine floor |  | 2d | 2012-01-19 A | 2012-01-20 A |  | 100% |  |  |  | start no earlier than 2012-01-19 | Survey | 16h | 16h |  |  |
| 185 | 5.3.2 | Survey current position of KL |  | 1d | 2012-01-23 A | 2012-01-23 A | 184 | 100% |  |  |  |  | Survey | 8h | 8h |  |  |
| 186 | 5.3.3 | Create survey map of existing survey targets on MICE hall wall |  | 10d | 2012-01-24 A | 2012-02-06 A | 185 | 100% |  |  |  |  | Survey | 80h | 80h |  |  |
| 187 | 5.3.4 | Survey map of existing survey targets on MICE hall wall complete | milestone | 0d | 2012-02-06 A | 2012-02-06 A | 186 | 100% |  |  |  |  |  |  |  |  |  |
| 188 | 5.4 | **Air Conditioning Units** |  | 5d | 2012-02-01 A | 2012-02-07 A |  | 100% |  |  |  |  | Air Conditioning | 40h | 40h |  |  |
| 189 | 5.4.1 | Re-position air con units in MICE hall |  | 5d | 2012-02-01 A | 2012-02-07 A |  | 100% |  |  |  | start no earlier than 2012-02-01 |  |  |  |  |  |
| 190 | 5.4.2 | Air Conditioning Unit Repositioning complete | milestone | 0d | 2012-02-07 A | 2012-02-07 A | 189 | 100% |  |  |  |  |  |  |  |  |  |
| 192 | 6 | **Installation** |  | 2635.5d | 2008-09-01 A | 2018-10-08 |  | 48% | 1361.24d | 245.5d |  |  | Installation | 130105h | 8867.1h | 1,011,059.12 | 463,072.24 |
| 193 | 6.1 | **Infrastructure** |  | 2635.5d | 2008-09-01 A | 2018-10-08 |  | 59% | 1084.13d | 245.5d |  |  |  | 36956.1h | 4246.32h | 648,000 | 315,170 |
| 194 | 6.1.1 | **Mechanical** |  | 887d | 2010-04-01 A | 2013-08-23 |  | 61% | 342.94d | 1581d |  |  | Mechanical Infrastructure | 7176h |  | 451,000 | 158,520 |
| 195 | 6.1.1.1 | Radiation shield design, manufacture and integration (Norbert) |  | 347d | 2011-02-01 A | 2012-07-02 |  | 90% | 34.7d | 1880d |  | finish no earlier than 2012-07-02 |  |  |  | 20,000 | 18,000 |
| 196 | 6.1.1.2 | Managing compressor stands & high pressure hoses |  | 553d | 2010-04-01 A | 2012-06-04 |  | 28% | 400.5d | 1900d |  | finish no earlier than 2012-06-04 |  |  |  | 5,000 | 1,400 |
| 197 | 6.1.1.3 | Patch panel interfaces and stand (tracker, Geoff Barber) | milestone | 0d | 2013-08-23 | 2013-08-23 | 121 |  |  | 1581d |  | start no earlier than 2010-04-01 |  |  |  | 1,000 |  |
| 198 | 6.1.1.4 | Trellises for fibre optices (tracker, Geoff Barber) | milestone | 0d | 2013-08-23 | 2013-08-23 | 121 |  |  | 1581d |  | start no earlier than 2010-04-01 |  |  |  | 2,000 |  |
| 199 | 6.1.1.5 | He window manufacture |  | 153d | 2011-09-01 A | 2012-04-02 A |  | 100% |  |  |  | finish no earlier than 2012-04-02 |  |  |  | 5,000 | 5,000 |
| 200 | 6.1.1.6 | Drill jigs for drilling solenoid interfaces (tracker, Geoff Barber) | milestone | 0d | 2013-08-23 | 2013-08-23 | 121 |  |  | 1581d |  | start no earlier than 2010-04-01 |  |  |  | 1,000 |  |
| 201 | 6.1.1.7 | Steel structure for supporting fume stacks for Hydrogen system |  | 230d | 2010-04-01 A | 2011-03-01 A |  | 100% |  |  |  | finish no earlier than 2011-03-01 |  |  |  |  |  |
| 202 | 6.1.1.8 | Vacuum pump enclosure |  | 230d | 2010-04-01 A | 2011-03-01 A |  | 100% |  |  |  | finish no earlier than 2011-03-01 |  |  |  | 31,000 | 31,000 |
| 203 | 6.1.1.9 | Retaining wall for LH2 vents |  | 127d | 2010-04-01 A | 2010-09-24 A |  | 100% |  |  |  | finish no earlier than 2010-09-24 |  |  |  | 10,000 | 10,000 |
| 204 | 6.1.1.10 | Mezzanine for Electronics racks (Next to Q7,Q8,Q9) |  | 115d | 2010-08-16 A | 2011-01-21 A |  | 100% |  |  |  | finish no earlier than 2011-01-21 |  |  |  | 40,000 | 40,000 |
| 205 | 6.1.1.11 | Security fence around the MICE roof |  | 56d | 2010-08-16 A | 2010-11-01 A |  | 100% |  |  |  | finish no earlier than 2010-11-01 |  |  |  | 20,000 | 20,000 |
| 206 | 6.1.1.12 | Hand rail around the MICE roof |  | 36d | 2011-01-07 A | 2011-02-25 A |  | 100% |  |  |  | finish no earlier than 2011-02-25 |  |  |  | 5,000 | 5,000 |
| 207 | 6.1.1.13 | Walkway from the concrete steps to the MICE roof |  | 53d | 2010-09-15 A | 2010-11-26 A |  | 100% |  |  |  | finish no earlier than 2010-11-26 |  |  |  | 6,000 | 6,000 |
| 208 | 6.1.1.14 | PPS fences and gates for RF enclosure |  | 48d | 2010-08-16 A | 2010-10-20 A |  | 100% |  |  |  | finish no earlier than 2010-10-20 |  |  |  | 5,000 | 5,000 |
| 209 | 6.1.1.15 | Checker plate the false floor |  | 50d | 2011-04-04 | 2011-06-10 |  |  |  | 2156d |  | start no earlier than 2011-04-04 |  |  |  | 20,000 |  |
| 210 | 6.1.1.16 | Walkway behind the south shield wall at mezzanine level |  | 105d | 2010-09-08 A | 2011-02-01 A |  | 100% |  |  |  | start no earlier than 2010-09-08 |  |  |  | 6,000 | 6,000 |
| 211 | 6.1.1.17 | Gas bottle rack outside the MICE hall needs access crane or similar |  | 422d | 2010-10-01 A | 2012-05-14 |  | 4% | 407d | 1915d |  | finish no earlier than 2012-05-14 |  |  |  | 3,000 | 120 |
| 212 | 6.1.1.18 | Mono rail hoist |  | 48d | 2010-08-16 A | 2010-10-20 A |  | 100% |  |  |  | finish no earlier than 2010-10-20 |  |  |  | 5,000 | 5,000 |
| 213 | 6.1.1.19 | MICE main door refurbishment |  | 95d | 2010-08-16 A | 2010-12-24 A |  | 100% |  |  |  | start no earlier than 2010-08-16 |  |  |  | 6,000 | 6,000 |

| ID | WBS | Task | Type | Duration | Start | Finish | Predecessors | Complete | Remaining | Total slack | Free slack | Constraint | Resources | Work | Cost |
| --- | --- | --- | --- | --- | --- | --- | --- | --- | --- | --- | --- | --- | --- | --- | --- |
| 214 | 6.1.1.20 | **Magnetic shield walls** |  | 215d | 2012-05-07 | 2013-03-01 |  |  |  | 1706d |  |  |  |  | 260,000 |
| 215 | 6.1.1.20.1 | Vector fields Analysis |  | 15d | 2012-05-07 | 2012-05-25 |  |  |  | 1706d | 0d | start no earlier than 2012-05-07 |  |  | 10,000 |
| 216 | 6.1.1.20.2 | Build new steel walls |  | 200d | 2012-05-28 | 2013-03-01 | 215 |  |  | 1706d |  |  |  |  | 250,000 |
| 217 | 6.1.1.21 | **South Side Mezzanine Floor** |  | 478d | 2011-09-26 A | 2013-07-24 |  | 56% | 210.32d | 39d |  |  |  |  |  |
| 218 | 6.1.1.21.1 | Water pipe move |  | 1d | 2011-09-26 A | 2011-09-26 A |  | 100% |  |  |  | start no earlier than 2011-09-26 |  |  |  |
| 219 | 6.1.1.21.2 | Cable tray |  | 1d | 2011-09-26 A | 2011-09-26 A |  | 100% |  |  |  | start no earlier than 2011-09-26 |  |  |  |
| 220 | 6.1.1.21.3 | H2 services & supports |  | 1d | 2011-09-26 A | 2011-09-26 A |  | 100% |  |  |  | start no earlier than 2011-09-26 |  |  |  |
| 221 | 6.1.1.21.4 | South Mezz change dwg |  | 1d | 2013-07-24 A | 2013-07-24 A | 109, 110, 111 | 100% |  |  |  | start no earlier than 2011-09-27 |  |  |  |
| 222 | 6.1.1.21.5 | Dimensional check of South Mezz |  | 1d | 2013-01-17 A | 2013-01-17 A | 112 | 100% |  |  |  | start no earlier than 2011-09-28 |  |  |  |
| 223 | 6.1.1.21.6 | Installation Sequence for Opus |  | 1d | 2011-09-26 A | 2011-09-26 A |  | 100% |  |  |  | start no earlier than 2011-09-26 |  |  |  |
| 224 | 6.1.1.21.7 | Engineered drawings |  | 1d | 2011-09-26 A | 2011-09-26 A |  | 100% |  |  |  | start no earlier than 2011-09-26 |  |  |  |
| 225 | 6.1.1.21.8 | Quotes (concurrent to sign off) |  | 1d | 2011-09-26 A | 2011-09-26 A |  | 100% |  |  |  | start no earlier than 2011-09-26 |  |  |  |
| 226 | 6.1.1.21.9 | Structural Sign Off |  | 2d | 2011-09-27 A | 2011-09-28 A | 225 | 100% |  |  |  |  |  |  |  |
| 227 | 6.1.1.21.10 | Safety Sign Off |  | 2d | 2011-09-29 A | 2011-09-30 A | 226 | 100% |  |  |  | start no earlier than 2011-09-28 |  |  |  |
| 228 | 6.1.1.21.11 | Order materials & premade parts |  | 2d | 2011-10-03 A | 2011-10-04 A | 227 | 100% |  |  |  | start no earlier than 2011-09-26 |  |  |  |
| 229 | 6.1.1.21.12 | Contractor (Regal?) to fit |  | 10d | 2012-09-24 | 2012-10-05 | 228, 1119FS+10d |  |  | 246d | 0d | start no earlier than 2012-09-24 |  |  |  |
| 230 | 6.1.1.21.13 | Review & snagging |  | 1d | 2012-10-08 | 2012-10-08 | 229 |  |  | 246d | 0d | start no earlier than 2011-09-26 |  |  |  |
| 231 | 6.1.1.21.14 | South Mezzanine Floormodification complete | milestone | 0d | 2012-10-08 | 2012-10-08 | 230 |  |  | 246d | 239d |  |  |  |  |
| 232 | 6.1.1.22 | **Solenoid frame installation - Upstream** |  | 5d | 2012-08-29 | 2012-09-04 |  |  |  | 270d |  |  | Spectrometer | 40h |  |
| 233 | 6.1.1.22.1 | Position solenoid frame on MICE floor |  | 2d | 2012-08-29 | 2012-08-30 | 1119FS+10d |  |  | 270d | 0d |  |  |  |  |
| 234 | 6.1.1.22.2 | Survey frame into position and fix to floor |  | 3d | 2012-08-31 | 2012-09-04 | 233 |  |  | 270d | 0d |  |  |  |  |
| 235 | 6.1.1.22.3 | Upstream solenoid frame installation complete | milestone | 0d | 2012-09-04 | 2012-09-04 | 234 |  |  | 270d | 0d |  |  |  |  |
| 236 | 6.1.1.23 | **Solenoid frame installation - Downstream** |  | 5d | 2012-09-05 | 2012-09-11 |  |  |  | 321d |  |  | Spectrometer | 40h |  |
| 237 | 6.1.1.23.1 | Position solenoid frame on MICE floor |  | 2d | 2012-09-05 | 2012-09-06 | 235 |  |  | 321d | 0d |  |  |  |  |
| 238 | 6.1.1.23.2 | Survey frame into position and fix to floor |  | 3d | 2012-09-07 | 2012-09-11 | 237 |  |  | 321d | 0d |  |  |  |  |
| 239 | 6.1.1.23.3 | Upstream solenoid frame installation complete | milestone | 0d | 2012-09-11 | 2012-09-11 | 238 |  |  | 321d | 314d |  |  |  |  |

| ID | WBS | Task | Type | Duration | Start | Finish | Predecessors | Complete | Remaining | Baseline start | Baseline finish | Baseline duration | Total slack | Free slack | Constraint | Resources | Work | Actual work | Cost | Baseline cost | Actual cost |
| --- | --- | --- | --- | --- | --- | --- | --- | --- | --- | --- | --- | --- | --- | --- | --- | --- | --- | --- | --- | --- | --- |
| 240 | 6.1.2 | **Electrical** |  | 2635.5d | 2008-09-01 A | 2018-10-08 |  | 53% | 1225.87d |  |  |  | 245.5d |  |  | Electrical Infrastucture | 29780.1h | 4246.32h | 197,000 |  | 156,650 |
| 241 | 6.1.2.1 | **Personnel Safety** |  | 1247d | 2008-09-01 A | 2013-06-11 |  | 71% | 360.76d | 2009-06-15 | 2012-12-18 | 917d? | 1634d |  |  |  | 2004.5h | 1372.5h | 23,500 | 93,086 | 17,500 |
| 242 | 6.1.2.1.1 | DSA Modifications and additions |  | 5d | 2009-12-01 A | 2009-12-08 A |  | 100% |  | 2009-10-26 | 2009-10-30 | 5d |  |  | start no earlier than 2009-10-05 | Electrical Designer | 40h | 40h | 7,500 | 9,380 | 7,500 |
| 243 | 6.1.2.1.2 | DSA installation |  | 4d | 2009-12-08 A | 2009-12-14 A | 242 | 100% |  | 2009-11-02 | 2009-11-05 | 4d |  |  |  | Electrical Technician | 32h | 32h |  | 1,504 |  |
| 244 | 6.1.2.1.3 | Electrical Commission DAS PPS |  | 3d | 2009-12-14 A | 2009-12-17 A | 243 | 100% |  | 2009-11-06 | 2009-11-10 | 3d |  |  | start no earlier than 2009-10-12 | Electrical Designer | 24h | 24h |  | 1,128 |  |
| 245 | 6.1.2.1.4 | DSA PPS Electrical Ready | milestone | 0d | 2009-12-17 A | 2009-12-17 A | 244 | 100% |  | 2009-11-10 | 2009-11-10 | 0d |  |  | start no earlier than 2008-12-29 |  |  |  |  |  |  |
| 246 | 6.1.2.1.5 | PPS Safety Office commissions DSA |  | 3d | 2010-11-30 A | 2010-12-03 A | 256 | 100% |  |  |  |  |  |  |  |  |  |  |  |  |  |
| 247 | 6.1.2.1.6 | **Hall electrical design** |  | 1247d | 2008-09-01 A | 2013-06-11 |  | 69% | 383.9d | 2009-06-15 | 2012-12-18 | 917d? | 1634d |  |  |  | 1908.5h | 1276.5h | 16,000 | 81,074 | 10,000 |
| 248 | 6.1.2.1.6.1 | **PPS** |  | 340.15d | 2009-06-15 A | 2010-10-04 A |  | 100% |  | 2009-06-15 | 2009-06-15 | 0d |  |  |  |  | 1202.5h | 1202.5h | 10,000 | 10,000 | 10,000 |
| 249 | 6.1.2.1.6.1.1 | PPS electrical design generated |  | 37d | 2009-06-15 A | 2009-08-04 A |  | 100% |  | 2009-06-15 | 2009-07-24 | 30d |  |  |  | Electrical Designer | 296h | 296h |  | 11,280 |  |
| 250 | 6.1.2.1.6.1.2 | PPS Hall Drawings provisionally accepted |  | 4.62d | 2009-08-05 A | 2009-08-11 A | 249 | 100% |  |  |  |  |  |  |  | Electrical Designer | 37h | 37h |  |  |  |
| 251 | 6.1.2.1.6.1.3 | Step II Hall installation |  | 55.5d | 2009-08-11 A | 2010-07-01 A | 250 | 100% |  | 2009-07-27 | 2009-10-06 | 52d |  |  | start no earlier than 2009-06-22 | Electrical Technician; Electrical Designer [25%] | 555h | 555h |  | 20,680 |  |
| 252 | 6.1.2.1.6.1.4 | PPS Rack termination diagrams generated |  | 18.5d | 2010-05-17 A | 2010-06-10 A |  | 100% |  |  |  |  |  |  | start no earlier than 2010-05-17 | Electrical Designer | 148h | 148h |  |  |  |
| 253 | 6.1.2.1.6.1.5 | PPS Rack termination approved |  | 4.62d | 2010-06-10 A | 2010-06-17 A | 252 | 100% |  |  |  |  |  |  |  |  |  |  |  |  |  |
| 254 | 6.1.2.1.6.1.6 | PPS Rack terminations in MLCR |  | 13.88d | 2010-07-01 A | 2010-09-29 A | 251, 253 | 100% |  |  |  |  |  |  |  | Electrical Technician; Electrical Designer [25%] | 138.75h | 138.75h |  |  |  |
| 255 | 6.1.2.1.6.1.7 | Electrical commissioning |  | 2.77d | 2010-09-29 A | 2010-10-04 A | 254 | 100% |  | 2009-10-07 | 2009-10-09 | 3d |  |  | start no earlier than 2008-12-15 | Electrical Designer; Electrical Technician [25%] | 27.75h | 27.75h |  | 1,410 |  |
| 256 | 6.1.2.1.6.2 | Personnel Safety Officer commissioning |  | 18.5d | 2010-10-04 A | 2010-11-30 A | 255 | 100% |  | 2009-10-12 | 2009-10-23 | 10d |  |  | start no earlier than 2009-08-31 | Electrical Technician [25%]; Electrical Designer [25%] | 74h | 74h |  |  |  |
| 257 | 6.1.2.1.6.3 | Personnel Safety Office commissions and approves |  | 1.85d | 2008-09-01 A | 2008-09-02 A |  | 100% |  |  |  |  |  |  |  |  |  |  |  |  |  |
| 258 | 6.1.2.1.6.4 | PPS integrated and tested with ISIS system |  | 4.62d | 2008-09-02 A | 2008-09-09 A | 257 | 100% |  |  |  |  |  |  |  |  |  |  |  |  |  |
| 259 | 6.1.2.1.6.5 | Hall PPS Step II ready | milestone | 0d | 2009-09-21 A | 2009-09-21 A | 258 | 100% |  | 2009-10-23 | 2009-10-23 | 0d |  |  | start no earlier than 2009-09-21 |  |  |  |  |  |  |
| 260 | 6.1.2.1.6.6 | **PPS Step IV** |  | 24d | 2011-09-12 | 2011-10-13 |  |  |  | 2011-04-27 | 2011-05-24 | 20d | 2067d |  |  |  | 192h |  | 2,000 | 9,332 |  |
| 261 | 6.1.2.1.6.6.1 | Review mods required to PPS |  | 5d | 2011-09-12 | 2011-09-16 |  |  |  | 2011-04-27 | 2011-05-03 | 5d | 2067d | 0d | start no earlier than 2011-09-12 | Electrical Designer | 40h |  | 2,000 | 3,880 |  |
| 262 | 6.1.2.1.6.6.2 | PPS electrical designs generated |  | 5d | 2011-09-19 | 2011-09-23 | 261 |  |  | 2011-05-04 | 2011-05-10 | 5d | 2067d | 0d |  | Electrical Designer | 40h |  |  | 1,880 |  |
| 263 | 6.1.2.1.6.6.3 | PPS Hall Drawings provisionally accepted |  | 3d | 2011-09-26 | 2011-09-28 | 262 |  |  |  |  |  | 2067d | 0d |  | Electrical Designer | 24h |  |  |  |  |
| 264 | 6.1.2.1.6.6.4 | Step IV Hall installation |  | 5d | 2011-09-29 | 2011-10-05 | 263 |  |  | 2011-05-11 | 2011-05-17 | 5d | 2067d | 0d |  | Electrical Technician | 40h |  |  | 1,880 |  |
| 265 | 6.1.2.1.6.6.5 | Electrical commissioning |  | 3d | 2011-10-06 | 2011-10-10 | 264 |  |  | 2011-05-18 | 2011-05-20 | 3d | 2067d | 0d |  | Electrical Designer; Electrical Technician [50%] | 36h |  |  | 1,692 |  |
| 266 | 6.1.2.1.6.6.6 | Personnel Safety Officer commissioning |  | 3d | 2011-10-11 | 2011-10-13 | 265 |  |  | 2011-05-23 | 2011-05-24 | 2d | 2067d | 0d |  | Electrical Technician [25%]; Electrical Designer [25%] | 12h |  |  |  |  |
| 267 | 6.1.2.1.6.6.7 | Hall PPS Step IV ready | milestone | 0d | 2011-10-13 | 2011-10-13 | 266 |  |  | 2011-05-24 | 2011-05-24 | 0d | 2067d |  |  |  |  |  |  |  |  |

| ID | WBS | Task | Type | Duration | Start | Finish | Predecessors | Complete | Remaining | Baseline start | Baseline finish | Baseline duration | Total slack | Free slack | Constraint | Resources | Work | Actual work | Cost | Baseline cost | Actual cost |
| --- | --- | --- | --- | --- | --- | --- | --- | --- | --- | --- | --- | --- | --- | --- | --- | --- | --- | --- | --- | --- | --- |
| 268 | 6.1.2.1.6.7 | **PPS Step V** |  | 24d | 2012-12-06 | 2013-01-08 |  |  |  | 2012-04-18 | 2012-05-15 | 20d | 1744d |  |  |  | 220h |  | 2,000 | 9,520 |  |
| 269 | 6.1.2.1.6.7.1 | Review mods required to PPS |  | 5d | 2012-12-06 | 2012-12-12 |  |  |  | 2012-04-18 | 2012-04-24 | 5d | 1744d | 0d | start no earlier than 2012-12-06 | Electrical Designer | 40h |  | 2,000 | 3,880 |  |
| 270 | 6.1.2.1.6.7.2 | PPS electrical designs generated |  | 5d | 2012-12-13 | 2012-12-19 | 269 |  |  | 2012-04-25 | 2012-05-01 | 5d | 1744d | 0d |  | Electrical Designer | 40h |  |  | 1,880 |  |
| 271 | 6.1.2.1.6.7.3 | PPS Hall Drawings provisionally accepted |  | 3d | 2012-12-20 | 2012-12-24 | 270 |  |  |  |  |  | 1744d | 0d |  | Electrical Designer | 24h |  |  |  |  |
| 272 | 6.1.2.1.6.7.4 | Step V Hall installation |  | 5d | 2012-12-25 | 2012-12-31 | 271 |  |  | 2012-05-02 | 2012-05-08 | 5d | 1744d | 0d |  | Electrical Technician; Electrical Designer [25%] | 50h |  |  | 2,350 |  |
| 273 | 6.1.2.1.6.7.5 | Electrical commissioning |  | 3d | 2013-01-01 | 2013-01-03 | 272 |  |  | 2012-05-09 | 2012-05-11 | 3d | 1744d | 0d |  | Electrical Designer; Electrical Technician [25%] | 30h |  |  | 1,410 |  |
| 274 | 6.1.2.1.6.7.6 | Personnel Safety Officer commissioning |  | 3d | 2013-01-04 | 2013-01-08 | 273 |  |  | 2012-05-14 | 2012-05-15 | 2d | 1744d | 0d |  | Electrical Designer; Electrical Technician [50%] | 36h |  |  |  |  |
| 275 | 6.1.2.1.6.7.7 | Hall PPS Step V ready | milestone | 0d | 2013-01-08 | 2013-01-08 | 274 |  |  | 2012-05-15 | 2012-05-15 | 0d | 1744d |  |  | Electrical Technician [25%]; Electrical Designer [25%] |  |  |  |  |  |
| 276 | 6.1.2.1.6.8 | **PPS Step VI** |  | 24d | 2013-05-09 | 2013-06-11 |  |  |  | 2012-11-21 | 2012-12-18 | 20d? | 1634d |  |  |  | 220h |  | 2,000 | 9,520 |  |
| 277 | 6.1.2.1.6.8.1 | Review mods required to PPS |  | 5d | 2013-05-09 | 2013-05-15 |  |  |  | 2012-11-21 | 2012-11-27 | 5d | 1634d | 0d | start no earlier than 2013-05-09 | Electrical Designer | 40h |  | 2,000 | 3,880 |  |
| 278 | 6.1.2.1.6.8.2 | PPS electrical designs generated |  | 5d | 2013-05-16 | 2013-05-22 | 277 |  |  | 2012-11-28 | 2012-12-04 | 5d | 1634d | 0d |  | Electrical Designer | 40h |  |  | 1,880 |  |
| 279 | 6.1.2.1.6.8.3 | PPS Hall Drawings provisionally accepted |  | 3d | 2013-05-23 | 2013-05-27 | 278 |  |  |  |  |  | 1634d | 0d |  | Electrical Designer | 24h |  |  |  |  |
| 280 | 6.1.2.1.6.8.4 | Step V Hall installation |  | 5d | 2013-05-28 | 2013-06-03 | 279 |  |  | 2012-12-05 | 2012-12-11 | 5d | 1634d | 0d |  | Electrical Technician; Electrical Designer [25%] | 50h |  |  | 2,350 |  |
| 281 | 6.1.2.1.6.8.5 | Electrical commissioning |  | 3d | 2013-06-04 | 2013-06-06 | 280 |  |  | 2012-12-12 | 2012-12-14 | 3d | 1634d | 0d |  | Electrical Designer; Electrical Technician [25%] | 30h |  |  | 1,410 |  |
| 282 | 6.1.2.1.6.8.6 | Personnel Safety Officer commissioning |  | 3d | 2013-06-07 | 2013-06-11 | 281 |  |  | 2012-12-17 | 2012-12-18 | 2d | 1634d | 0d |  | Electrical Designer; Electrical Technician [50%] | 36h |  |  |  |  |
| 283 | 6.1.2.1.6.8.7 | Hall PPS Step V ready | milestone | 0d | 2013-06-11 | 2013-06-11 | 282 |  |  | 2012-12-18 | 2012-12-18 | 0d | 1634d |  |  | Electrical Technician [25%]; Electrical Designer [25%] |  |  |  |  |  |
| 284 | 6.1.2.2 | **MICE Hall compressors** |  | 1187.4d | 2009-02-11 A | 2013-08-30 |  | 90% | 120.94d | 2009-03-09 | 2010-05-24 | 316d | 1576.6d |  |  |  | 652.2h | 587.4h | 21,000 | 44,688 | 20,800 |
| 285 | 6.1.2.2.1 | Compressor Hardware Fixed and Agreed | milestone | 0d | 2009-03-09 A | 2009-03-09 A |  | 100% |  | 2009-03-09 | 2009-03-09 | 0d |  |  | start no earlier than 2009-03-09 |  |  |  | 17,000 | 17,000 | 17,000 |
| 286 | 6.1.2.2.2 | Design AC distribution |  | 10d | 2009-03-09 A | 2009-03-20 A | 285 | 100% |  | 2009-03-09 | 2009-03-20 | 10d |  |  | start no earlier than 2009-01-26 | Electrical Designer | 80h | 80h |  | 3,760 |  |
| 287 | 6.1.2.2.3 | Design/ agree equipment layout |  | 10d | 2009-04-13 A | 2009-04-24 A | 286 | 100% |  | 2009-04-13 | 2009-04-24 | 10d |  |  | start no earlier than 2009-04-13 | Electrical Designer | 80h | 80h |  | 3,760 |  |
| 288 | 6.1.2.2.4 | Install main cable management |  | 15d | 2009-06-08 A | 2009-06-26 A | 287 | 100% |  | 2009-06-08 | 2009-06-26 | 15d |  |  | start no earlier than 2009-06-08 | Electrical Technician | 120h | 120h |  | 5,640 |  |
| 289 | 6.1.2.2.5 | Install main sub distribution boards |  | 9.25d | 2009-11-02 A | 2009-11-13 A | 288 | 100% |  |  |  |  |  |  | start no earlier than 2009-11-02 | Electrical Technician | 74h | 74h |  |  |  |
| 290 | 6.1.2.2.6 | Test and energise main sub-distribution boards |  | 0.93d | 2010-03-04 A | 2010-03-04 A | 289 | 100% |  |  |  |  |  |  | start no earlier than 2010-03-04 | Electrical Technician | 7.4h | 7.4h |  |  |  |
| 291 | 6.1.2.2.7 | Compressor cooling system review requirements |  | 1.85d | 2010-03-18 A | 2010-03-22 A | 290FS+9.25d | 100% |  |  |  |  |  |  |  | Electrical Designer | 14.8h | 14.8h |  |  |  |

| ID | WBS | Task | Type | Duration | Start | Finish | Predecessors | Complete | Remaining | Baseline start | Baseline finish | Baseline duration | Total slack | Free slack | Constraint | Resources | Work | Actual work | Cost | Baseline cost | Actual cost |
| --- | --- | --- | --- | --- | --- | --- | --- | --- | --- | --- | --- | --- | --- | --- | --- | --- | --- | --- | --- | --- | --- |
| 292 | 6.1.2.2.8 | **Tracker # 1 Compressors** |  | 533.98d | 2010-03-22 A | 2012-04-06 | 291 | 99% | 0d | 2009-09-24 | 2009-10-02 | 7d | 1942d |  |  |  | 37h | 37h | 1,000 | 3,632 | 1,000 |
| 293 | 6.1.2.2.8.1 | Install local cable management |  | 0.93d | 2010-03-22 A | 2010-03-22 A |  | 100% |  | 2009-09-24 | 2009-09-25 | 2d |  |  | start no earlier than 2009-09-24 | Electrical Technician | 7.4h | 7.4h | 1,000 | 1,752 | 1,000 |
| 294 | 6.1.2.2.8.2 | Install cables to local outlet |  | 1.85d | 2010-03-22 A | 2010-03-24 A | 293 | 100% |  | 2009-09-28 | 2009-09-30 | 3d |  |  |  | Electrical Technician | 14.8h | 14.8h |  | 1,128 |  |
| 295 | 6.1.2.2.8.3 | Compressors available for installation | milestone | 0d | 2012-04-06 | 2012-04-06 | 294 |  |  | 2009-09-30 | 2009-09-30 | 0d | 1942d |  | start no earlier than 2012-04-06 |  |  |  |  |  |  |
| 296 | 6.1.2.2.8.4 | Terminate and install local ac cables |  | 1.85d | 2010-03-23 A | 2010-03-24 A |  | 100% |  | 2009-10-01 | 2009-10-02 | 2d |  |  | start no earlier than 2010-03-23 | Electrical Technician | 14.8h | 14.8h |  | 752 |  |
| 297 | 6.1.2.2.8.5 | Tracker#1 compressor electrical complete | milestone | 0d | 2012-04-06 A | 2012-04-06 A | 295 | 100% |  |  |  |  |  |  |  |  |  |  |  |  |  |
| 298 | 6.1.2.2.9 | **Spectrometer Soleniod Compressors # 1** |  | 429.4d | 2012-01-09 A | 2013-08-30 | 296, 44 | 56% | 188.94d | 2009-12-01 | 2009-12-09 | 7d | 1576.6d |  |  |  | 80h | 44.8h | 1,000 | 3,632 | 800 |
| 299 | 6.1.2.2.9.1 | Install local cable management |  | 3d | 2012-01-09 A | 2013-08-26 |  | 80% | 0.6d | 2009-12-01 | 2009-12-02 | 2d | 1576.6d | 0d | start no earlier than 2009-12-01 | Electrical Technician | 24h | 19.2h | 1,000 | 1,752 | 800 |
| 300 | 6.1.2.2.9.2 | Install cables |  | 4d | 2012-01-12 A | 2013-08-27 | 299 | 80% | 0.8d | 2009-12-03 | 2009-12-07 | 3d | 1576.6d | 0d |  | Electrical Technician | 32h | 25.6h |  | 1,128 |  |
| 301 | 6.1.2.2.9.3 | Compressors available for installation | milestone | 0d | 2013-08-27 | 2013-08-27 | 300 |  |  | 2009-12-07 | 2009-12-07 | 0d | 1576.6d | 0d | start no earlier than 2009-12-07 |  |  |  |  |  |  |
| 302 | 6.1.2.2.9.4 | Terminate and install local ac cables |  | 3d | 2013-08-27 | 2013-08-30 | 301 |  |  | 2009-12-08 | 2009-12-09 | 2d | 1576.6d | 0d |  | Electrical Technician | 24h |  |  | 752 |  |
| 303 | 6.1.2.2.9.5 | Spectrometer Soleniod # 1 compressors complete | milestone | 0d | 2013-08-30 | 2013-08-30 | 302 |  |  |  |  |  | 1576.6d |  |  |  |  |  |  |  |  |
| 304 | 6.1.2.2.10 | **Tracker # 2 Compressors** |  | 4.62d | 2012-08-08 A | 2012-08-14 |  | 20% | 3.7d | 2010-01-28 | 2010-02-05 | 7d | 1849.38d |  |  |  | 37h | 7.4h | 1,000 | 3,632 | 1,000 |
| 305 | 6.1.2.2.10.1 | Install local cable management |  | 0.93d | 2012-08-08 A | 2012-08-08 A | 986 | 100% |  | 2010-01-28 | 2010-01-29 | 2d |  |  | start no earlier than 2010-01-28 | Electrical Technician | 7.4h | 7.4h | 1,000 | 1,752 | 1,000 |
| 306 | 6.1.2.2.10.2 | Install cables |  | 1.85d | 2012-08-08 | 2012-08-10 | 305 |  |  | 2010-02-01 | 2010-02-03 | 3d | 1849.38d | 0d |  | Electrical Technician | 14.8h |  |  | 1,128 |  |
| 307 | 6.1.2.2.10.3 | Compressors available for installation | milestone | 0d | 2012-08-10 | 2012-08-10 | 306 |  |  | 2010-02-03 | 2010-02-03 | 0d | 1849.38d | 0d | start no earlier than 2009-09-28 |  |  |  |  |  |  |
| 308 | 6.1.2.2.10.4 | Terminate cables |  | 1.85d | 2012-08-10 | 2012-08-14 | 307 |  |  | 2010-02-04 | 2010-02-05 | 2d | 1849.38d | 0d |  | Electrical Technician | 14.8h |  |  | 752 |  |
| 309 | 6.1.2.2.10.5 | Tracker#2 electrical complete | milestone | 0d | 2012-08-14 | 2012-08-14 | 308 |  |  |  |  |  | 1849.38d |  |  |  |  |  |  |  |  |
| 310 | 6.1.2.2.11 | **Spectrometer Soleniod Compressors # 2** |  | 4d | 2009-02-11 A | 2009-02-16 A | 308 | 100% |  | 2010-05-14 | 2010-05-24 | 7d |  |  |  |  | 48h | 48h |  | 3,632 |  |
| 311 | 6.1.2.2.11.1 | Produce AC distribution for systems |  | 4d | 2009-02-11 A | 2009-02-16 A |  | 100% |  | 2009-02-11 | 2009-02-16 | 4d |  |  |  | Electrical Designer; Electrical Engineer [50%] | 48h | 48h |  | 2,256 |  |
| 312 | 6.1.2.2.12 | **DSA** |  | 82.78d | 2009-06-08 A | 2009-09-30 A |  | 100% |  | 2009-10-26 | 2009-11-10 | 12d |  |  |  |  | 74h | 74h | 1,000 | 12,012 | 1,000 |
| 313 | 6.1.2.2.12.1 | **PPS Step II** |  | 2.77d | 2009-06-08 A | 2009-06-10 A |  | 100% |  | 2009-06-15 | 2009-10-23 | 95d |  |  |  |  | 22.2h | 22.2h | 1,000 | 43,370 | 1,000 |
| 314 | 6.1.2.2.12.1.1 | Install local cable management |  | 2.77d | 2009-06-08 A | 2009-06-10 A |  | 100% |  | 2010-05-14 | 2010-05-17 | 2d |  |  | start no earlier than 2009-06-08 | Electrical Technician | 22.2h | 22.2h | 1,000 | 1,752 | 1,000 |
| 315 | 6.1.2.2.12.2 | Install cables |  | 3.7d | 2009-06-10 A | 2009-06-16 A | 314 | 100% |  | 2010-05-18 | 2010-05-20 | 3d |  |  |  | Electrical Technician | 29.6h | 29.6h |  | 1,128 |  |
| 316 | 6.1.2.2.12.3 | Compressors available for installation | milestone | 0d | 2009-09-28 A | 2009-09-28 A | 315 | 100% |  | 2010-05-20 | 2010-05-20 | 0d |  |  | start no earlier than 2009-09-28 |  |  |  |  |  |  |
| 317 | 6.1.2.2.12.4 | Terminate cables |  | 2.77d | 2009-09-28 A | 2009-09-30 A | 316 | 100% |  | 2010-05-21 | 2010-05-24 | 2d |  |  |  | Electrical Technician | 22.2h | 22.2h |  | 752 |  |

| ID | WBS | Task | Type | Duration | Start | Finish | Predecessors | Complete | Remaining | Baseline start | Baseline finish | Baseline duration | Total slack | Free slack | Constraint | Resources | Work | Actual work | Cost | Baseline cost | Actual cost |
| --- | --- | --- | --- | --- | --- | --- | --- | --- | --- | --- | --- | --- | --- | --- | --- | --- | --- | --- | --- | --- | --- |
| 318 | 6.1.2.3 | **Vacuum System (Matt Hills& Mike Courtold)** |  | 70d | 2011-05-02 | 2011-08-05 |  |  |  |  |  |  | 2116d |  |  |  | 544h |  | 3,000 |  |  |
| 319 | 6.1.2.3.1 | Review Vacuum requirements |  | 5d | 2011-05-02 | 2011-05-06 |  |  |  |  |  |  | 2116d | 0d | start no earlier than 2011-05-02 | Electrical Designer | 40h |  |  |  |  |
| 320 | 6.1.2.3.2 | Design Vacuum system and racks |  | 19d | 2011-05-09 | 2011-06-02 | 319 |  |  |  |  |  | 2116d | 0d |  | Electrical Designer | 152h |  |  |  |  |
| 321 | 6.1.2.3.3 | Assembe Vacuum racks |  | 24d | 2011-06-03 | 2011-07-06 | 320 |  |  |  |  |  | 2116d | 0d |  | Electrical Technician | 192h |  | 3,000 |  |  |
| 322 | 6.1.2.3.4 | Test Vacuum system |  | 5d | 2011-07-07 | 2011-07-13 | 321 |  |  |  |  |  | 2116d | 0d |  | Electrical Designer | 40h |  |  |  |  |
| 323 | 6.1.2.3.5 | Transfer Vacuum system to RAL |  | 2d | 2011-07-14 | 2011-07-15 | 322 |  |  |  |  |  | 2116d | 0d |  |  |  |  |  |  |  |
| 324 | 6.1.2.3.6 | Install Vacuum system in MICE Hall |  | 10d | 2011-07-18 | 2011-07-29 | 323 |  |  |  |  |  | 2116d | 0d |  | Electrical Technician | 80h |  |  |  |  |
| 325 | 6.1.2.3.7 | Commission Vacuum system |  | 5d | 2011-08-01 | 2011-08-05 | 324 |  |  |  |  |  | 2116d | 0d |  | Electrical Designer | 40h |  |  |  |  |
| 326 | 6.1.2.3.8 | Vacuum System Ready for operation | milestone | 0d | 2011-08-05 | 2011-08-05 | 325 |  |  |  |  |  | 2116d |  |  |  |  |  |  |  |  |
| 327 | 6.1.2.4 | **Hall HV AC Network Upgrade (JW Morris- Build Proj Group)** |  | 717d | 2008-09-01 A | 2011-05-31 A |  | 100% |  |  |  |  |  |  |  |  | 297.2h | 297.2h | 80,000 |  | 80,000 |
| 328 | 6.1.2.4.1 | Finance approved | milestone | 0d | 2010-09-20 A | 2010-09-20 A |  | 100% |  |  |  |  |  |  | start no earlier than 2010-09-20 |  |  |  | 80,000 |  | 80,000 |
| 329 | 6.1.2.4.2 | Tender exercise |  | 55.5d | 2008-09-01 A | 2008-11-17 A |  | 100% |  |  |  |  |  |  |  | Electrical Engineer [20%] | 88.8h | 88.8h |  |  |  |
| 330 | 6.1.2.4.3 | Review and award contract |  | 10d | 2008-11-17 A | 2008-12-01 A | 329 | 100% |  |  |  |  |  |  |  | Electrical Engineer | 80h | 80h |  |  |  |
| 331 | 6.1.2.4.4 | Procurement period |  | 111d | 2010-03-04 A | 2010-08-05 A | 330 | 100% |  |  |  |  |  |  | start no earlier than 2010-03-04 | Electrical Engineer [5%] | 44.4h | 44.4h |  |  |  |
| 332 | 6.1.2.4.5 | MICE Hall AC Network installation preparation |  | 5d | 2010-08-06 A | 2010-08-12 A | 331 | 100% |  |  |  |  |  |  |  | Electrical Technician | 40h | 40h |  |  |  |
| 333 | 6.1.2.4.6 | Agreed date for installation to start | milestone | 0d | 2011-05-13 A | 2011-05-13 A |  | 100% |  |  |  |  |  |  | start no earlier than 2011-05-13 |  |  |  |  |  |  |
| 334 | 6.1.2.4.7 | HV Network installation by contractors |  | 5d | 2011-05-13 A | 2011-05-19 A | 333 | 100% |  |  |  |  |  |  |  | Electrical Engineer [50%] | 20h | 20h |  |  |  |
| 335 | 6.1.2.4.8 | Install Fencing |  | 5d | 2011-05-20 A | 2011-05-26 A | 334 | 100% |  |  |  |  |  |  |  |  |  |  |  |  |  |
| 336 | 6.1.2.4.9 | Commission and Handover of system |  | 3d | 2011-05-27 A | 2011-05-31 A | 335 | 100% |  |  |  |  |  |  |  | Electrical Engineer | 24h | 24h |  |  |  |
| 337 | 6.1.2.4.10 | HV AC Network Upgrade complete | milestone | 0d | 2011-05-31 A | 2011-05-31 A | 336 | 100% |  |  |  |  |  |  |  |  |  |  |  |  |  |
| 338 | 6.1.2.5 | **TOF 01 & 02** |  | 2337.47d | 2009-10-05 A | 2018-09-19 |  | 42% | 1345.74d | 2009-12-10 | 2012-11-07 | 760d | 258.52d |  |  |  | 331.4h | 144h | 4,500 | 20,796 | 1,500 |
| 339 | 6.1.2.5.1 | **TOF 01** |  | 7d | 2009-10-05 A | 2009-10-13 A |  | 100% |  | 2009-12-10 | 2009-12-18 | 7d |  |  |  |  | 56h | 56h | 500 | 3,132 | 500 |
| 340 | 6.1.2.5.1.1 | Define new cable management routes |  | 2d | 2009-10-05 A | 2009-10-06 A |  | 100% |  | 2009-12-10 | 2009-12-11 | 2d |  |  | start no earlier than 2009-10-05 | Electrical Designer | 16h | 16h | 500 | 1,252 | 500 |
| 341 | 6.1.2.5.1.2 | Install additional cable management |  | 2d | 2009-10-07 A | 2009-10-08 A | 340 | 100% |  | 2009-12-14 | 2009-12-15 | 2d |  |  |  | Electrical Technician | 16h | 16h |  | 752 |  |
| 342 | 6.1.2.5.1.3 | Re-route cables |  | 3d | 2009-10-09 A | 2009-10-13 A | 341 | 100% |  | 2009-12-16 | 2009-12-18 | 3d |  |  |  | Electrical Technician | 24h | 24h |  | 1,128 |  |
| 343 | 6.1.2.5.1.4 | TOF 01 electrical complete | milestone | 0d | 2009-10-13 A | 2009-10-13 A | 342 | 100% |  | 2009-12-18 | 2009-12-18 | 0d |  |  |  |  |  |  |  |  |  |

| ID | WBS | Task | Type | Duration | Start | Finish | Predecessors | Complete | Remaining | Baseline start | Baseline finish | Baseline duration | Total slack | Free slack | Constraint | Resources | Work | Actual work | Cost | Baseline cost | Actual cost |
| --- | --- | --- | --- | --- | --- | --- | --- | --- | --- | --- | --- | --- | --- | --- | --- | --- | --- | --- | --- | --- | --- |
| 344 | 6.1.2.5.2 | **TOF 02** |  | 593d | 2009-11-02 A | 2012-02-08 | 343 | 69% | 185.31d | 2009-12-21 | 2012-11-07 | 753d | 1983d |  |  |  | 120h | 88h | 1,000 | 17,664 | 1,000 |
| 345 | 6.1.2.5.2.1 | Produce electrical design |  | 2d | 2009-11-02 A | 2009-11-03 A |  | 100% |  | 2009-12-21 | 2009-12-22 | 2d |  |  | start no earlier than 2009-11-02 | Electrical Designer | 16h | 16h | 1,000 | 1,752 | 1,000 |
| 346 | 6.1.2.5.2.2 | Evaluate cable / system requirements TOF2 |  | 2d | 2009-11-04 A | 2009-11-05 A | 345 | 100% |  | 2009-12-23 | 2009-12-24 | 2d |  |  | start no earlier than 2009-05-18 | Electrical Designer | 16h | 16h |  | 752 |  |
| 347 | 6.1.2.5.2.3 | Cables Supplied / Delivered | milestone | 0d | 2009-11-05 A | 2009-11-05 A | 346 | 100% |  | 2009-12-24 | 2009-12-24 | 0d |  |  |  |  |  |  |  |  |  |
| 348 | 6.1.2.5.2.4 | Install additional cable management |  | 2d | 2009-11-06 A | 2009-11-09 A | 347 | 100% |  | 2009-12-25 | 2009-12-28 | 2d |  |  |  | Electrical Technician | 16h | 16h |  | 752 |  |
| 349 | 6.1.2.5.2.5 | Install cables |  | 5d | 2009-11-10 A | 2009-11-16 A | 348 | 100% |  | 2009-12-29 | 2010-01-04 | 5d |  |  |  | Electrical Technician | 40h | 40h |  | 1,880 |  |
| 350 | 6.1.2.5.2.6 | TOF 02 electrical complete - temporary position | milestone | 0d | 2009-11-16 A | 2009-11-16 A | 349 | 100% |  | 2010-01-04 | 2010-01-04 | 0d |  |  |  |  |  |  |  |  |  |
| 351 | 6.1.2.5.2.7 | TOF02 Ready for repositioning | milestone | 0d | 2012-02-01 A | 2012-02-01 A | 350 | 100% |  |  |  |  |  |  |  |  |  |  |  |  |  |
| 352 | 6.1.2.5.2.8 | Disconnect TOF02 and install additional cable tray |  | 2d | 2012-02-02 | 2012-02-03 | 351 |  |  |  |  |  | 1983d | 0d |  | Electrical Technician | 16h |  |  |  |  |
| 353 | 6.1.2.5.2.9 | Reposition TOF 02 |  | 1d | 2012-02-06 | 2012-02-06 | 352 |  |  |  |  |  | 1983d | 0d |  |  |  |  |  |  |  |
| 354 | 6.1.2.5.2.10 | Recable to new position |  | 2d | 2012-02-07 | 2012-02-08 | 353 |  |  |  |  |  | 1983d | 0d |  | Electrical Technician | 16h |  |  |  |  |
| 355 | 6.1.2.5.2.11 | TOF02 Step IV electrical complete | milestone | 0d | 2012-02-08 | 2012-02-08 | 354 |  |  |  |  |  | 1983d |  |  |  |  |  |  |  |  |
| 356 | 6.1.2.5.3 | **TOF 02 - Step IV** |  | 6.47d | 2010-04-12 | 2010-04-20 |  |  |  | 2011-04-05 | 2011-04-13 | 7d | 2454.53d |  |  |  | 51.8h |  | 1,000 | 3,132 |  |
| 357 | 6.1.2.5.3.1 | Define new cable management routes |  | 1.85d | 2010-04-12 | 2010-04-13 |  |  |  | 2011-04-05 | 2011-04-06 | 2d | 2454.53d | 0d | start no earlier than 2010-04-12 | Electrical Designer | 14.8h |  | 1,000 | 1,252 |  |
| 358 | 6.1.2.5.3.2 | Install additional cable management |  | 1.85d | 2010-04-13 | 2010-04-15 | 357 |  |  | 2011-04-07 | 2011-04-08 | 2d | 2454.53d | 0d |  | Electrical Technician | 14.8h |  |  | 752 |  |
| 359 | 6.1.2.5.3.3 | Re-route cables |  | 2.77d | 2010-04-15 | 2010-04-20 | 358 |  |  | 2011-04-11 | 2011-04-13 | 3d | 2454.53d | 0d |  | Electrical Technician | 22.2h |  |  | 1,128 |  |
| 360 | 6.1.2.5.3.4 | TOF 02 electrical complete | milestone | 0d | 2010-04-20 | 2010-04-20 | 359 |  |  | 2011-04-13 | 2011-04-13 | 0d | 2454.53d |  |  |  |  |  |  |  |  |
| 361 | 6.1.2.5.4 | **TOF 02 - Step V** |  | 6.47d | 2017-06-20 | 2017-06-28 |  |  |  | 2012-03-27 | 2012-04-04 | 7d | 578.52d |  |  |  | 51.8h |  | 1,000 | 3,132 |  |
| 362 | 6.1.2.5.4.1 | Define new cable management routes |  | 1.85d | 2017-06-20 | 2017-06-21 | 1034SS |  |  | 2012-03-27 | 2012-03-28 | 2d | 578.52d | 0d | start no earlier than 2010-04-12 | Electrical Designer | 14.8h |  | 1,000 | 1,252 |  |
| 363 | 6.1.2.5.4.2 | Install additional cable management |  | 1.85d | 2017-06-21 | 2017-06-23 | 362 |  |  | 2012-03-29 | 2012-03-30 | 2d | 578.52d | 0d |  | Electrical Technician | 14.8h |  |  | 752 |  |
| 364 | 6.1.2.5.4.3 | Re-route cables |  | 2.77d | 2017-06-23 | 2017-06-28 | 363 |  |  | 2012-04-02 | 2012-04-04 | 3d | 578.52d | 0d |  | Electrical Technician | 22.2h |  |  | 1,128 |  |
| 365 | 6.1.2.5.4.4 | TOF 02 electrical complete | milestone | 0d | 2017-06-28 | 2017-06-28 | 364 |  |  | 2012-04-04 | 2012-04-04 | 0d | 578.52d |  |  |  |  |  |  |  |  |
| 366 | 6.1.2.5.5 | **TOF 02 - Step VI** |  | 6.47d | 2018-09-11 | 2018-09-19 |  |  |  | 2012-10-30 | 2012-11-07 | 7d | 258.52d |  |  |  | 51.8h |  | 1,000 | 3,132 |  |
| 367 | 6.1.2.5.5.1 | Define new cable management routes |  | 1.85d | 2018-09-11 | 2018-09-12 | 1080SS |  |  | 2012-10-30 | 2012-10-31 | 2d | 258.52d | 0d | start no earlier than 2010-04-12 | Electrical Designer | 14.8h |  | 1,000 | 1,252 |  |
| 368 | 6.1.2.5.5.2 | Install additional cable management |  | 1.85d | 2018-09-12 | 2018-09-14 | 367 |  |  | 2012-11-01 | 2012-11-02 | 2d | 258.52d | 0d |  | Electrical Technician | 14.8h |  |  | 752 |  |
| 369 | 6.1.2.5.5.3 | Re-route cables |  | 2.77d | 2018-09-14 | 2018-09-19 | 368 |  |  | 2012-11-05 | 2012-11-07 | 3d | 258.52d | 0d |  | Electrical Technician | 22.2h |  |  | 1,128 |  |
| 370 | 6.1.2.5.5.4 | TOF 02 electrical complete | milestone | 0d | 2018-09-19 | 2018-09-19 | 369 |  |  | 2012-11-07 | 2012-11-07 | 0d | 258.52d |  |  |  |  |  |  |  |  |

| ID | WBS | Task | Type | Duration | Start | Finish | Predecessors | Complete | Remaining | Baseline start | Baseline finish | Baseline duration | Total slack | Free slack | Constraint | Resources | Work | Actual work | Cost | Baseline cost | Actual cost |
| --- | --- | --- | --- | --- | --- | --- | --- | --- | --- | --- | --- | --- | --- | --- | --- | --- | --- | --- | --- | --- | --- |
| 371 | 6.1.2.6 | **Tracker / Spectrometer Soleniod # 1** |  | 788d | 2009-03-02 A | 2012-03-07 |  | 52% | 381.07d | 2009-03-02 | 2010-01-15 | 230d | 1963d |  |  |  | 2546.4h | 1469.22h | 41,000 | 107,640 | 32,850 |
| 372 | 6.1.2.6.1 | Prepare Hall and cable ducts for installation |  | 5d | 2009-04-20 A | 2009-04-24 A |  | 100% |  | 2009-04-20 | 2009-04-24 | 5d |  |  | start no earlier than 2009-04-20 | Electrical Technician | 40h | 40h |  | 1,880 |  |
| 373 | 6.1.2.6.2 | **Tracker** |  | 643d | 2009-09-14 A | 2012-02-29 |  | 58% | 272.42d | 2009-09-14 | 2010-01-15 | 90d | 1968d |  |  |  | 278h | 222h | 3,500 | 11,400 | 2,000 |
| 374 | 6.1.2.6.2.1 | Produce rack layout drawings |  | 9.25d | 2009-09-14 A | 2010-03-15 A | 372 | 100% |  | 2009-09-14 | 2009-10-28 | 33d |  |  | start no earlier than 2009-09-14 | Electrical Designer | 74h | 74h | 2,000 | 5,760 | 2,000 |
| 375 | 6.1.2.6.2.2 | Tracker system available for modification | milestone | 0d | 2010-07-19 A | 2010-07-19 A |  | 100% |  |  |  |  |  |  | start no earlier than 2010-07-19 |  |  |  |  |  |  |
| 376 | 6.1.2.6.2.3 | Re-house equipment in new rack |  | 4.62d | 2010-07-19 A | 2010-07-23 A | 374, 375 | 100% |  | 2009-10-29 | 2009-11-04 | 5d |  |  | start no earlier than 2010-04-14 | Electrical Technician | 37h | 37h |  | 1,880 |  |
| 377 | 6.1.2.6.2.4 | Agree/ design Control interface |  | 9.25d | 2010-07-23 A | 2010-08-05 A | 376 | 100% |  | 2009-11-05 | 2009-11-09 | 3d |  |  |  | Electrical Designer; Electrical Technician [50%] | 111h | 111h |  | 1,128 |  |
| 378 | 6.1.2.6.2.5 | Tracker rack available for installation | milestone | 0d | 2011-02-14 A | 2011-02-14 A | 377 | 100% |  |  |  |  |  |  | start no earlier than 2011-02-14 |  |  |  |  |  |  |
| 379 | 6.1.2.6.2.6 | Install Tracker rack in MICE Hall |  | 2d | 2011-03-14 | 2011-03-15 | 374, 378 |  |  | 2009-11-10 | 2009-11-11 | 2d | 2219d |  | start no earlier than 2011-03-14 | Electrical Technician | 16h |  |  | 752 |  |
| 380 | 6.1.2.6.2.7 | Tracker Installation |  | 10d | 2012-02-09 | 2012-02-22 | 375, 439, 413SS+14.8d |  |  | 2010-01-11 | 2010-01-11 | 0d | 1968d | 0d | start no earlier than 2010-01-11 |  |  |  |  |  |  |
| 381 | 6.1.2.6.2.8 | Install cables and terminate |  | 5d | 2012-02-23 | 2012-02-29 | 377, 380 |  |  | 2010-01-11 | 2010-01-15 | 5d | 1968d | 5d |  | Electrical Technician | 40h |  | 1,500 | 1,880 |  |
| 382 | 6.1.2.6.3 | **Diffuser** |  | 557d | 2009-05-11 A | 2011-06-28 |  | 61% | 217.63d | 2009-05-11 | 2009-08-10 | 66d | 2144d |  |  |  | 126.8h | 62.8h | 1,500 | 7,392 | 1,000 |
| 383 | 6.1.2.6.3.1 | Understand requirements |  | 3d | 2009-05-11 A | 2009-05-13 A |  | 100% |  | 2009-05-11 | 2009-05-13 | 3d |  |  | start no earlier than 2009-05-11 | Electrical Designer | 24h | 24h | 1,000 | 2,128 | 1,000 |
| 384 | 6.1.2.6.3.2 | Design rack layout / cable schedule |  | 3d | 2009-05-14 A | 2009-05-18 A | 383 | 100% |  | 2009-05-14 | 2009-05-18 | 3d |  |  |  | Electrical Designer | 24h | 24h |  | 1,128 |  |
| 385 | 6.1.2.6.3.3 | Clarification of rack space availability | milestone | 0d | 2010-04-12 A | 2010-04-12 A | 384 | 100% |  |  |  |  |  |  | start no earlier than 2010-04-12 |  |  |  |  |  |  |
| 386 | 6.1.2.6.3.4 | Provide assembled rack for equipment population |  | 1.85d | 2010-05-18 A | 2010-05-19 A | 385 | 100% |  | 2009-07-27 | 2009-07-29 | 3d |  |  | start no earlier than 2010-05-18 | Electrical Technician | 14.8h | 14.8h |  | 1,128 |  |
| 387 | 6.1.2.6.3.5 | Modify and populate rack |  | 4.62d | 2010-10-18 A | 2010-10-22 A | 386 | 100% |  |  |  |  |  |  | start no earlier than 2010-10-18 |  |  |  |  |  |  |
| 388 | 6.1.2.6.3.6 | Install diffuser rack |  | 2d | 2011-06-17 | 2011-06-20 |  |  |  | 2009-07-30 | 2009-08-03 | 3d | 2144d | 0d | start no earlier than 2011-06-17 | Electrical Technician | 16h |  |  | 1,128 |  |
| 389 | 6.1.2.6.3.7 | Diffuser installed | milestone | 0d | 2011-06-20 | 2011-06-20 | 388 |  |  |  |  |  | 2144d | 0d | start no earlier than 2010-05-10 |  |  |  |  |  |  |
| 390 | 6.1.2.6.3.8 | Install cables and terminate |  | 6d | 2011-06-21 | 2011-06-28 | 389 |  |  | 2009-08-04 | 2009-08-10 | 5d | 2144d | 0d |  | Electrical Technician | 48h |  | 500 | 1,880 |  |
| 391 | 6.1.2.6.3.9 | Diffuser electrical complete | milestone | 0d | 2011-06-28 | 2011-06-28 | 390 |  |  | 2009-08-10 | 2009-08-10 | 0d | 2144d | 181d |  |  |  |  |  |  |  |
| 392 | 6.1.2.6.4 | **AC Distribution - Main circuits to racks** |  | 123d | 2009-08-17 A | 2010-02-03 |  | 89% | 13.06d | 2009-08-17 | 2009-10-21 | 48d | 2508d |  |  |  | 188.4h | 168.4h | 2,000 | 8,016 | 2,000 |
| 393 | 6.1.2.6.4.1 | Understand AC distribution requirements |  | 5.55d | 2009-08-17 A | 2009-08-24 A |  | 100% |  | 2009-08-17 | 2009-08-21 | 5d |  |  | start no earlier than 2009-08-17 | Electrical Designer | 44.4h | 44.4h | 2,000 | 3,880 | 2,000 |
| 394 | 6.1.2.6.4.2 | Design AC infrastructure and layout |  | 8d | 2009-11-18 A | 2009-11-27 A | 393 | 100% |  | 2009-08-24 | 2009-09-01 | 7d |  |  | start no earlier than 2009-11-18 | Electrical Designer | 64h | 64h |  | 2,632 |  |
| 395 | 6.1.2.6.4.3 | Install AC distribution |  | 10d | 2009-11-30 A | 2010-02-03 | 394 | 75% | 2.5d | 2009-10-16 | 2009-10-21 | 4d | 2508d |  | start no earlier than 2009-10-16 | Electrical Technician | 80h | 60h |  | 1,504 |  |

| ID | WBS | Task | Type | Duration | Start | Finish | Predecessors | Complete | Remaining | Baseline start | Baseline finish | Baseline duration | Total slack | Free slack | Constraint | Resources | Work | Actual work | Cost | Baseline cost | Actual cost |
| --- | --- | --- | --- | --- | --- | --- | --- | --- | --- | --- | --- | --- | --- | --- | --- | --- | --- | --- | --- | --- | --- |
| 396 | 6.1.2.6.5 | **AC Distribution - Local outlets/sockets** |  | 25d | 2010-10-11 A | 2010-11-12 A |  | 100% |  |  |  |  |  |  |  |  | 120h | 120h |  |  |  |
| 397 | 6.1.2.6.5.1 | Design local distribution for cooling channel racks / circuits |  | 5d | 2010-10-11 A | 2010-10-15 A | 395 | 100% |  |  |  |  |  |  | start no earlier than 2010-10-11 | Electrical Designer | 40h | 40h |  |  |  |
| 398 | 6.1.2.6.5.2 | Procure / assemble distribution equipment |  | 5d | 2010-10-18 A | 2010-10-22 A | 397 | 100% |  |  |  |  |  |  |  | Electrical Designer | 40h | 40h |  |  |  |
| 399 | 6.1.2.6.5.3 | Assemble distribution rack / cabinet |  | 10d | 2010-10-25 A | 2010-11-05 A | 398 | 100% |  |  |  |  |  |  |  |  |  |  |  |  |  |
| 400 | 6.1.2.6.5.4 | Install local rack / AC distribution in Hall |  | 3d | 2010-11-08 A | 2010-11-10 A | 399 | 100% |  |  |  |  |  |  |  | Electrical Technician | 24h | 24h |  |  |  |
| 401 | 6.1.2.6.5.5 | Test local AC distribution in MICE Hall |  | 2d | 2010-11-11 A | 2010-11-12 A | 400 | 100% |  |  |  |  |  |  |  | Electrical Designer | 16h | 16h |  |  |  |
| 402 | 6.1.2.6.6 | **Spectrometer Soleniod** |  | 770d | 2009-03-02 A | 2012-02-10 |  | 34% | 507.23d | 2009-03-02 | 2009-12-09 | 203d | 1981d |  |  |  | 752.8h | 326.52h | 7,500 | 19,736 | 2,850 |
| 403 | 6.1.2.6.6.1 | Evaluate cable / system requirements |  | 14.8d | 2009-03-02 A | 2009-05-25 A |  | 100% |  | 2009-03-02 | 2009-05-25 | 61d |  |  |  | Electrical Designer | 118.4h | 118.4h | 1,500 | 7,140 | 1,500 |
| 404 | 6.1.2.6.6.2 | Electrical rack design and assembly |  | 9.25d | 2009-05-26 A | 2009-06-26 A | 403 | 100% |  | 2009-05-26 | 2009-06-26 | 24d |  |  |  | Electrical Designer | 74h | 74h |  | 3,760 |  |
| 405 | 6.1.2.6.6.3 | Racks issued to WANG for population |  | 5.55d | 2009-06-29 A | 2009-07-06 A | 404 | 100% |  | 2009-06-29 | 2009-07-03 | 5d |  |  |  | Electrical Technician | 44.4h | 44.4h |  | 1,880 |  |
| 406 | 6.1.2.6.6.4 | Review cable management |  | 3d | 2010-06-07 A | 2010-06-09 | 405, 433 | 56% | 1.33d | 2009-07-06 | 2009-07-08 | 3d | 2418d |  | start no earlier than 2010-01-25 | Electrical Designer | 24h | 13.32h |  | 1,128 |  |
| 407 | 6.1.2.6.6.5 | **Spectrometer soleniod power interface** |  | 25d | 2010-11-15 A | 2010-12-17 |  | 21% | 19.75d |  |  |  | 2281d |  |  |  | 200h | 42h | 3,000 |  | 1,050 |
| 408 | 6.1.2.6.6.5.1 | **Power electronics control sequence interface** |  | 25d | 2010-11-15 A | 2010-12-17 |  | 21% | 19.75d |  |  |  | 2281d |  |  |  | 200h | 42h | 3,000 |  | 1,050 |
| 409 | 6.1.2.6.6.5.1.1 | Review power electronic interlock signals |  | 5d | 2010-11-15 A | 2010-11-19 |  | 35% | 3.25d |  |  |  | 2284.5d | 0d | start no earlier than 2010-11-15 | Electrical Engineer | 40h | 14h | 3,000 |  | 1,050 |
| 410 | 6.1.2.6.6.5.1.2 | Design controller interface |  | 10d | 2010-11-22 A | 2010-12-03 | 409 | 35% | 6.5d |  |  |  | 2281d | 0d |  | Electrical Designer | 80h | 28h |  |  |  |
| 411 | 6.1.2.6.6.5.1.3 | Assemble controller interface |  | 5d | 2010-12-06 | 2010-12-10 | 410 |  |  |  |  |  | 2281d | 0d |  | Electrical Technician | 40h |  |  |  |  |
| 412 | 6.1.2.6.6.5.1.4 | Test controller interface |  | 5d | 2010-12-13 | 2010-12-17 | 411 |  |  |  |  |  | 2281d |  |  | Electrical Engineer | 40h |  |  |  |  |
| 413 | 6.1.2.6.6.6 | Spectrometer soleniod delivered | milestone | 0d | 2012-01-06 | 2012-01-06 |  |  |  | 2009-11-09 | 2009-11-09 | 0d | 1963d | 0d | start no earlier than 2012-01-06 |  |  |  |  |  |  |
| 414 | 6.1.2.6.6.7 | Mechanical installation of soleniod |  | 24d | 2012-01-06 | 2012-02-08 | 413 |  |  |  |  |  | 1963d | 0d |  |  |  |  |  |  |  |
| 415 | 6.1.2.6.6.8 | **Spectrometer Soleniod Power Supply racks** |  | 24d | 2012-01-06 | 2012-02-08 |  |  |  |  |  |  | 1973d |  |  |  | 180h |  | 2,000 |  |  |
| 416 | 6.1.2.6.6.8.1 | Delivery Spectrometer soleniod racks to DL |  | 2d | 2012-01-06 | 2012-01-09 | 413 |  |  |  |  |  | 1973d | 0d |  |  |  |  | 2,000 |  |  |
| 417 | 6.1.2.6.6.8.2 | Finalise electrical design |  | 5d | 2012-01-10 | 2012-01-16 | 416 |  |  | 2009-11-09 | 2009-11-13 | 5d | 1973d | 0d |  | Electrical Designer; Electrical Engineer [50%] | 60h |  |  | 2,820 |  |
| 418 | 6.1.2.6.6.8.3 | Modify Spectrometer soleniod Power Supply racks |  | 10d | 2012-01-17 | 2012-01-30 | 417 |  |  |  |  |  | 1973d | 0d |  | Electrical Technician | 80h |  |  |  |  |
| 419 | 6.1.2.6.6.8.4 | Test Spectrometer soleniod power supply racks |  | 5d | 2012-01-31 | 2012-02-06 | 418 |  |  |  |  |  | 1973d | 0d |  | Electrical Engineer | 40h |  |  |  |  |
| 420 | 6.1.2.6.6.8.5 | Deliver Spectrometer soleniod Power Supply rack to RAL |  | 2d | 2012-02-07 | 2012-02-08 | 419 |  |  |  |  |  | 1973d | 0d |  |  |  |  |  |  |  |

| ID | WBS | Task | Type | Duration | Start | Finish | Predecessors | Complete | Remaining | Baseline start | Baseline finish | Baseline duration | Total slack | Free slack | Constraint | Resources | Work | Actual work | Cost | Baseline cost | Actual cost |
| --- | --- | --- | --- | --- | --- | --- | --- | --- | --- | --- | --- | --- | --- | --- | --- | --- | --- | --- | --- | --- | --- |
| 421 | 6.1.2.6.6.9 | **MICE Hall Preparation** |  | 16d | 2012-01-20 A | 2012-02-10 |  | 31% | 11.09d |  |  |  | 1981d |  |  |  | 112h | 34.4h | 1,000 |  | 300 |
| 422 | 6.1.2.6.6.9.1 | Install cable management and DC magnet cables |  | 10d | 2012-01-20 A | 2012-02-02 | 413FS+10d | 30% | 7d | 2009-11-30 | 2009-12-09 | 8d | 1986.3d | 0d |  | Electrical Technician | 80h | 24h | 1,000 | 3,008 | 300 |
| 423 | 6.1.2.6.6.9.2 | Install AC distribution |  | 2d | 2012-02-03 A | 2012-02-06 | 422 | 65% | 0.7d |  |  |  | 1985d |  |  | Electrical Technician | 16h | 10.4h |  |  |  |
| 424 | 6.1.2.6.6.9.3 | Install Spectrometer soleniod Power supply rack |  | 2d | 2012-02-09 | 2012-02-10 | 420 |  |  |  |  |  | 1981d |  |  | Electrical Technician | 16h |  |  |  |  |
| 425 | 6.1.2.6.7 | **Cooling Channel Controls System** |  | 618d | 2009-10-26 A | 2012-03-07 |  | 47% | 328.42d | 2009-06-24 | 2009-12-28 | 134d | 1963d |  |  |  | 1040.4h | 529.5h | 26,500 | 59,216 | 25,000 |
| 426 | 6.1.2.6.7.1 | Agree control system format | milestone | 0d | 2009-10-26 A | 2009-10-26 A |  | 100% |  | 2009-06-24 | 2009-06-24 | 0d |  |  | start no earlier than 2009-10-26 |  |  |  | 25,000 | 25,000 | 25,000 |
| 427 | 6.1.2.6.7.2 | Agree control system funding | milestone | 0d | 2009-10-26 A | 2009-10-26 A | 426 | 100% |  | 2009-08-03 | 2009-08-03 | 0d |  |  | start no earlier than 2009-08-03 |  |  |  |  |  |  |
| 428 | 6.1.2.6.7.3 | Identify equipment interface requirements |  | 22d | 2009-10-26 A | 2009-11-24 A | 427 | 100% |  | 2009-08-03 | 2009-09-01 | 22d |  |  |  | Electrical Designer | 176h | 176h |  | 8,272 |  |
| 429 | 6.1.2.6.7.4 | Design preliminary control system layout |  | 10d | 2009-11-25 A | 2009-12-08 A | 428 | 100% |  | 2009-09-02 | 2009-09-15 | 10d |  |  |  | Electrical Designer | 80h | 80h |  | 3,760 |  |
| 430 | 6.1.2.6.7.5 | Design control system wiring diagrams |  | 15d | 2009-12-09 A | 2009-12-29 A |  | 100% |  | 2009-09-16 | 2009-10-06 | 15d |  |  |  | Electrical Designer | 120h | 120h |  | 5,640 |  |
| 431 | 6.1.2.6.7.6 | Visit LBNL for discussions |  | 4.62d | 2010-02-22 A | 2010-02-26 A | 430 | 100% |  |  |  |  |  |  | start no earlier than 2010-02-22 | Electrical Designer | 37h | 37h |  |  |  |
| 432 | 6.1.2.6.7.7 | Controls review after LBNL visit |  | 4.62d | 2010-02-26 A | 2010-03-05 A | 431 | 100% |  |  |  |  |  |  |  | Electrical Designer | 37h | 37h |  |  |  |
| 433 | 6.1.2.6.7.8 | Approval of Finances and work package | milestone | 0d | 2010-06-07 A | 2010-06-07 A | 432 | 100% |  |  |  |  |  |  | start no earlier than 2010-06-07 |  |  |  |  |  |  |
| 434 | 6.1.2.6.7.9 | Update control system design |  | 10d | 2010-06-07 A | 2010-06-18 | 433 | 30% | 7d |  |  |  | 2342.94d | 0d |  | Electrical Designer | 80h | 24h |  |  |  |
| 435 | 6.1.2.6.7.10 | Controls design review and modifications |  | 14d | 2010-06-21 | 2010-07-08 | 434 |  |  |  |  |  | 2342.94d | 0d |  | Electrical Designer [20%] | 22.4h |  |  |  |  |
| 436 | 6.1.2.6.7.11 | Cooling Channel Controls design approval | milestone | 0d | 2010-07-08 | 2010-07-08 | 435 |  |  |  |  |  | 2342.94d | 0d |  |  |  |  |  |  |  |
| 437 | 6.1.2.6.7.12 | Assemble controls rack |  | 28d | 2010-07-08 A | 2010-08-17 | 436 | 25% | 21.06d | 2009-10-07 | 2009-11-17 | 30d | 2336.88d | 0d |  | Electrical Technician | 224h | 55.5h |  | 11,280 |  |
| 438 | 6.1.2.6.7.13 | Test controls rack |  | 10d | 2010-08-17 | 2010-08-31 | 437 |  |  | 2009-11-18 | 2009-11-24 | 5d | 2336.88d | 0d |  | Electrical Designer | 80h |  |  | 1,880 |  |
| 439 | 6.1.2.6.7.14 | Soleniod Mechanical installation complete | milestone | 0d | 2012-02-08 | 2012-02-08 | 414 |  |  | 2009-12-18 | 2009-12-18 | 0d | 1963d | 0d | start no earlier than 2009-12-18 |  |  |  |  |  |  |
| 440 | 6.1.2.6.7.15 | Install controls rack |  | 3d | 2010-08-31 | 2010-09-03 | 438 |  |  | 2009-11-25 | 2009-11-26 | 2d | 2336.88d | 373.88d |  | Electrical Technician | 24h |  |  | 752 |  |
| 441 | 6.1.2.6.7.16 | Install cables and terminate |  | 10d | 2012-02-09 | 2012-02-22 | 439, 440 |  |  | 2009-12-18 | 2009-12-23 | 4d | 1963d | 0d |  | Electrical Technician | 80h |  | 1,500 | 1,504 |  |
| 442 | 6.1.2.6.7.17 | Commission system with installed plant |  | 10d | 2012-02-23 | 2012-03-07 | 401, 420, 441 |  |  | 2009-12-24 | 2009-12-28 | 3d | 1963d | 0d |  | Electrical Designer | 80h |  |  | 1,128 |  |
| 443 | 6.1.2.6.7.18 | Cooling channel controls complete | milestone | 0d | 2012-03-07 | 2012-03-07 | 422, 442 |  |  |  |  |  | 1963d | 0d |  |  |  |  |  |  |  |
| 444 | 6.1.2.6.7.19 | Cooling Channel electrical complete Step II | milestone | 0d | 2012-03-07 | 2012-03-07 | 381, 391, 443 |  |  |  |  |  | 1963d |  |  |  |  |  |  |  |  |

| ID | WBS | Task | Type | Duration | Start | Finish | Predecessors | Complete | Remaining | Baseline start | Baseline finish | Baseline duration | Total slack | Free slack | Constraint | Resources | Work | Actual work | Cost | Baseline cost | Actual cost |
| --- | --- | --- | --- | --- | --- | --- | --- | --- | --- | --- | --- | --- | --- | --- | --- | --- | --- | --- | --- | --- | --- |
| 445 | 6.1.2.7 | **Tracker / Spectrometer Soleniod # 2** |  | 1005.23d | 2010-05-19 A | 2014-03-26 |  | 4% | 962.27d | 2009-04-20 | 2010-08-09 | 341d | 1428d |  |  |  | 672h | 40h | 8,500 | 45,044 | 2,000 |
| 446 | 6.1.2.7.1 | **Tracker** |  | 1005.23d | 2010-05-19 A | 2014-03-26 |  | 18% | 825.72d | 2009-10-26 | 2010-01-15 | 60d | 1428d |  |  |  | 152h | 40h | 2,500 | 8,204 | 2,000 |
| 447 | 6.1.2.7.1.1 | Prepare Hall and cable ducts for installation |  | 3d | 2012-12-19 | 2012-12-21 |  |  |  | 2009-04-20 | 2009-04-24 | 5d | 1746d | 0d | start no earlier than 2012-12-19 | Electrical Technician | 24h |  |  | 1,880 |  |
| 448 | 6.1.2.7.1.2 | Re-house equipment in new rack |  | 5d | 2010-05-19 A | 2010-05-26 A |  | 100% |  | 2009-10-26 | 2009-10-30 | 5d |  |  | start no earlier than 2009-10-26 | Electrical Technician | 40h | 40h | 2,000 | 3,880 | 2,000 |
| 449 | 6.1.2.7.1.3 | Tracker system available for installation | milestone | 0d | 2013-12-23 | 2013-12-23 | 957 |  |  |  |  |  | 1495d |  | finish no earlier than 2010-06-21 |  |  |  |  |  |  |
| 450 | 6.1.2.7.1.4 | Agree/ design Control interface |  | 2d | 2012-12-24 | 2012-12-25 | 447 |  |  | 2009-11-02 | 2009-11-04 | 3d | 1746d | 0d |  | Electrical Designer; Electrical Engineer [50%] | 24h |  |  | 1,692 |  |
| 451 | 6.1.2.7.1.5 | Install Tracker rack in MICE Hall |  | 2d | 2012-12-26 | 2012-12-27 | 450 |  |  | 2009-11-05 | 2009-11-06 | 2d | 1746d | 318d |  | Electrical Technician | 16h |  |  | 752 |  |
| 452 | 6.1.2.7.1.6 | Tracker Installation |  | 10d | 2014-03-05 | 2014-03-18 | 973 |  |  | 2010-01-11 | 2010-01-11 | 0d | 1428d | 0d | start no earlier than 2010-01-11 |  |  |  |  |  |  |
| 453 | 6.1.2.7.1.7 | Install cables and terminate |  | 6d | 2014-03-19 | 2014-03-26 | 451, 452 |  |  | 2010-01-11 | 2010-01-15 | 5d | 1428d | 0d |  | Electrical Technician | 48h |  | 500 | 1,880 |  |
| 454 | 6.1.2.7.2 | **Spectrometer Soleniod #2** |  | 627d | 2011-05-16 | 2013-10-08 |  |  |  | 2010-02-22 | 2010-07-27 | 112d | 1549d |  |  |  | 380h |  | 5,000 | 22,996 |  |
| 455 | 6.1.2.7.2.1 | Fast discharge circuit review |  | 2d | 2011-05-16 | 2011-05-17 |  |  |  |  |  |  | 2156d | 0d | start no earlier than 2011-05-16 |  |  |  |  |  |  |
| 456 | 6.1.2.7.2.2 | **Power electronics control sequence interface** |  | 18d | 2011-05-18 | 2011-06-10 |  |  |  |  |  |  | 2156d |  |  |  | 144h |  | 2,000 |  |  |
| 457 | 6.1.2.7.2.2.1 | Review power electronic interlock signals |  | 3d | 2011-05-18 | 2011-05-20 | 455 |  |  |  |  |  | 2156d | 0d |  | Electrical Engineer | 24h |  |  |  |  |
| 458 | 6.1.2.7.2.2.2 | Design controller interface |  | 5d | 2011-05-23 | 2011-05-27 | 457 |  |  |  |  |  | 2156d | 0d |  | Electrical Designer | 40h |  | 2,000 |  |  |
| 459 | 6.1.2.7.2.2.3 | Assemble controller interface |  | 5d | 2011-05-30 | 2011-06-03 | 458 |  |  |  |  |  | 2156d | 0d |  | Electrical Technician | 40h |  |  |  |  |
| 460 | 6.1.2.7.2.2.4 | Test controller interface |  | 5d | 2011-06-06 | 2011-06-10 | 459 |  |  |  |  |  | 2156d |  |  | Electrical Engineer | 40h |  |  |  |  |
| 461 | 6.1.2.7.2.3 | Spectrometer soleniod delivered | milestone | 0d | 2013-08-23 | 2013-08-23 | 125 |  |  | 2009-11-09 | 2009-11-09 | 0d | 1541d | 0d |  |  |  |  |  |  |  |
| 462 | 6.1.2.7.2.4 | Mechanical installation of soleniod |  | 25d | 2013-08-26 | 2013-09-27 | 461 |  |  |  |  |  | 1541d | 0d | start no earlier than 2012-06-08 |  |  |  |  |  |  |
| 463 | 6.1.2.7.2.5 | **Spectrometer Soleniod Power Supply racks** |  | 22d | 2013-08-26 | 2013-09-24 |  |  |  |  |  |  | 1559d |  |  |  | 180h |  | 2,000 |  |  |
| 464 | 6.1.2.7.2.5.1 | Review design of existing spectrometer racks |  | 2d | 2013-08-26 | 2013-08-27 | 461 |  |  |  |  |  | 1559d | 0d |  |  |  |  |  |  |  |
| 465 | 6.1.2.7.2.5.2 | Finalise electrical design |  | 5d | 2013-08-28 | 2013-09-03 | 464 |  |  | 2009-11-09 | 2009-11-13 | 5d | 1559d | 0d |  | Electrical Designer; Electrical Engineer [50%] | 60h |  |  | 2,820 |  |
| 466 | 6.1.2.7.2.5.3 | Modify Spectrometer soleniod Power Supply racks |  | 10d | 2013-09-04 | 2013-09-17 | 465 |  |  |  |  |  | 1559d | 0d |  | Electrical Technician | 80h |  | 2,000 |  |  |
| 467 | 6.1.2.7.2.5.4 | Commission Spectrometer soleniod power supply racks |  | 5d | 2013-09-18 | 2013-09-24 | 466 |  |  |  |  |  | 1559d |  |  | Electrical Engineer | 40h |  |  |  |  |
| 468 | 6.1.2.7.2.6 | **MICE Hall Preparation** |  | 7d | 2013-09-30 | 2013-10-08 |  |  |  |  |  |  | 1549d |  |  |  | 56h |  | 1,000 |  |  |
| 469 | 6.1.2.7.2.6.1 | Install cable management and DC magnet cables |  | 5d | 2013-09-30 | 2013-10-04 | 462 |  |  | 2009-11-30 | 2009-12-09 | 8d | 1549d | 0d |  | Electrical Technician | 40h |  | 1,000 | 3,008 |  |
| 470 | 6.1.2.7.2.6.2 | Install AC distribution |  | 2d | 2013-10-07 | 2013-10-08 | 469 |  |  |  |  |  | 1549d |  |  | Electrical Technician | 16h |  |  |  |  |

| ID | WBS | Task | Type | Duration | Start | Finish | Predecessors | Complete | Remaining | Baseline start | Baseline finish | Baseline duration | Total slack | Free slack | Constraint | Resources | Work | Cost | Baseline cost |
| --- | --- | --- | --- | --- | --- | --- | --- | --- | --- | --- | --- | --- | --- | --- | --- | --- | --- | --- | --- |
| 471 | 6.1.2.7.3 | **Cooling Channel Controls System** |  | 128d | 2013-09-27 | 2014-03-26 |  |  |  | 2010-07-28 | 2010-08-09 | 9d | 1428d |  |  |  | 140h | 1,000 | 4,948 |
| 472 | 6.1.2.7.3.1 | Soleniod#2 mechanical installation complete | milestone | 0d | 2013-09-27 | 2013-09-27 | 462 |  |  |  |  |  | 1541d | 0d |  |  |  |  |  |
| 473 | 6.1.2.7.3.2 | Install cables and terminate |  | 10d | 2013-09-30 | 2013-10-11 | 472 |  |  | 2010-07-28 | 2010-08-04 | 6d | 1541d | 0d |  | Electrical Technician | 80h | 1,000 | 3,256 |
| 474 | 6.1.2.7.3.3 | Commission system with installed plant |  | 5d | 2013-10-14 | 2013-10-18 | 473 |  |  | 2010-08-05 | 2010-08-09 | 3d | 1541d | 113d |  | Electrical Designer; Electrical Engineer [50%] | 60h |  | 1,692 |
| 475 | 6.1.2.7.3.4 | Cooling Channel electrical complete Step III | milestone | 0d | 2014-03-26 | 2014-03-26 | 453, 474 |  |  |  |  |  | 1428d |  |  |  |  |  |  |
| 476 | 6.1.2.8 | **AFC - Focus Coils # 1** |  | 46d | 2011-09-06 A | 2011-11-08 |  | 30% | 32d | 2011-03-14 | 2011-04-04 | 16d | 2049d |  |  |  | 288h | 2,500 | 8,268 |
| 477 | 6.1.2.8.1 | Understanding system requirements |  | 5d | 2011-09-06 A | 2011-09-12 A | 127 | 100% |  |  |  |  |  |  |  |  |  |  |  |
| 478 | 6.1.2.8.2 | Design control interface |  | 10d | 2011-09-13 A | 2011-09-26 | 477 | 90% | 1d |  |  |  | 2049d | 0d |  |  |  |  |  |
| 479 | 6.1.2.8.3 | Update cable schedules / drawings |  | 10d | 2011-09-27 | 2011-10-10 | 478 |  |  | 2011-03-14 | 2011-03-16 | 3d | 2049d | 0d |  | Electrical Designer | 80h |  | 1,128 |
| 480 | 6.1.2.8.4 | Install power supplies into rack |  | 2d | 2011-10-11 | 2011-10-12 | 479 |  |  | 2011-03-17 | 2011-03-18 | 2d | 2049d | 0d |  | Electrical Technician | 16h | 1,500 | 2,252 |
| 481 | 6.1.2.8.5 | Install additional cable management |  | 2d | 2011-10-13 | 2011-10-14 | 480 |  |  | 2011-03-21 | 2011-03-22 | 2d | 2049d | 0d |  | Electrical Technician | 16h |  | 752 |
| 482 | 6.1.2.8.6 | Install DC magnet cables |  | 4d | 2011-10-17 | 2011-10-20 | 481 |  |  | 2011-03-23 | 2011-03-25 | 3d | 2049d | 0d |  | Electrical Technician | 32h |  | 1,128 |
| 483 | 6.1.2.8.7 | Install controls interface / cables |  | 8d | 2011-10-21 | 2011-11-01 | 482 |  |  | 2011-03-28 | 2011-03-31 | 4d | 2049d | 0d |  | Electrical Technician | 64h | 1,000 | 1,504 |
| 484 | 6.1.2.8.8 | Commission controls |  | 5d | 2011-11-02 | 2011-11-08 | 483 |  |  | 2011-04-01 | 2011-04-04 | 2d | 2049d |  |  | Electrical Engineer; Electrical Technician | 80h |  | 1,504 |
| 485 | 6.1.2.9 | **AFC - Focus Coils # 2** |  | 27d | 2012-09-26 | 2012-11-01 |  |  |  | 2012-03-05 | 2012-03-26 | 16d | 1792d |  |  |  | 232h | 2,500 | 8,268 |
| 486 | 6.1.2.9.1 | Update cable schedules / drawings |  | 4d | 2012-09-26 | 2012-10-01 |  |  |  | 2012-03-05 | 2012-03-07 | 3d | 1792d | 0d | start no earlier than 2012-09-26 | Electrical Designer | 32h |  | 1,128 |
| 487 | 6.1.2.9.2 | Design control interface |  | 3d | 2012-10-02 | 2012-10-04 | 486 |  |  |  |  |  | 1792d | 0d |  |  |  |  |  |
| 488 | 6.1.2.9.3 | Install power supplies into rack |  | 2d | 2012-10-05 | 2012-10-08 | 487 |  |  | 2012-03-08 | 2012-03-09 | 2d | 1792d | 0d |  | Electrical Technician | 16h | 1,500 | 2,252 |
| 489 | 6.1.2.9.4 | Install additional cable management |  | 2d | 2012-10-09 | 2012-10-10 | 488 |  |  | 2012-03-12 | 2012-03-13 | 2d | 1792d | 0d |  | Electrical Technician | 16h |  | 752 |
| 490 | 6.1.2.9.5 | Install DC magnet cables |  | 4d | 2012-10-11 | 2012-10-16 | 489 |  |  | 2012-03-14 | 2012-03-16 | 3d | 1792d | 0d |  | Electrical Technician | 32h |  | 1,128 |
| 491 | 6.1.2.9.6 | Install controls interface / cables |  | 7d | 2012-10-17 | 2012-10-25 | 490 |  |  | 2012-03-19 | 2012-03-22 | 4d | 1792d | 0d |  | Electrical Technician | 56h | 1,000 | 1,504 |
| 492 | 6.1.2.9.7 | Commission controls |  | 5d | 2012-10-26 | 2012-11-01 | 491 |  |  | 2012-03-23 | 2012-03-26 | 2d | 1792d |  |  | Electrical Engineer; Electrical Technician | 80h |  | 1,504 |
| 493 | 6.1.2.10 | **AFC - Focus Coils # 3** |  | 27d | 2013-02-28 | 2013-04-05 |  |  |  | 2012-10-08 | 2012-10-29 | 16d | 1681d |  |  |  | 232h | 2,500 | 8,268 |
| 494 | 6.1.2.10.1 | Update cable schedules / drawings |  | 4d | 2013-02-28 | 2013-03-05 |  |  |  | 2012-10-08 | 2012-10-10 | 3d | 1681d | 0d | start no earlier than 2013-02-28 | Electrical Designer | 32h |  | 1,128 |
| 495 | 6.1.2.10.2 | Design controls interface |  | 3d | 2013-03-06 | 2013-03-08 | 494 |  |  |  |  |  | 1681d | 0d |  |  |  |  |  |
| 496 | 6.1.2.10.3 | Install power supplies into rack |  | 2d | 2013-03-11 | 2013-03-12 | 495 |  |  | 2012-10-11 | 2012-10-12 | 2d | 1681d | 0d |  | Electrical Technician | 16h | 1,500 | 2,252 |
| 497 | 6.1.2.10.4 | Install additional cable management |  | 2d | 2013-03-13 | 2013-03-14 | 496 |  |  | 2012-10-15 | 2012-10-16 | 2d | 1681d | 0d |  | Electrical Technician | 16h |  | 752 |
| 498 | 6.1.2.10.5 | Install DC magnet cables |  | 4d | 2013-03-15 | 2013-03-20 | 497 |  |  | 2012-10-17 | 2012-10-19 | 3d | 1681d | 0d |  | Electrical Technician | 32h |  | 1,128 |
| 499 | 6.1.2.10.6 | Install controls interface / cables |  | 7d | 2013-03-21 | 2013-03-29 | 498 |  |  | 2012-10-22 | 2012-10-25 | 4d | 1681d | 0d |  | Electrical Technician | 56h | 1,000 | 1,504 |
| 500 | 6.1.2.10.7 | Commission controls |  | 5d | 2013-04-01 | 2013-04-05 | 499 |  |  | 2012-10-26 | 2012-10-29 | 2d | 1681d |  |  | Electrical Engineer; Electrical Technician | 80h |  | 1,504 |

| ID | WBS | Task | Type | Duration | Start | Finish | Predecessors | Complete | Remaining | Baseline start | Baseline finish | Baseline duration | Total slack | Free slack | Constraint | Resources | Work | Actual work | Cost | Baseline cost | Actual cost |
| --- | --- | --- | --- | --- | --- | --- | --- | --- | --- | --- | --- | --- | --- | --- | --- | --- | --- | --- | --- | --- | --- |
| 501 | 6.1.2.11 | **KL (MUCAL)** |  | 2319.5d | 2009-11-17 A | 2018-10-08 |  | 39% | 1424.65d | 2010-01-05 | 2012-11-20 | 751d? | 245.5d |  |  |  | 896.4h | 336h | 8,000 | 21,920 | 2,000 |
| 502 | 6.1.2.11.1 | **KL Step II** |  | 581.85d | 2009-11-17 A | 2012-02-08 |  | 73% | 158.09d | 2010-01-05 | 2010-01-15 | 9d | 1981.15d |  |  |  | 142.8h | 104h | 1,000 | 4,384 | 1,000 |
| 503 | 6.1.2.11.1.1 | Evaluate cable / system requirements |  | 3d | 2009-11-17 A | 2009-11-19 A |  | 100% |  | 2010-01-05 | 2010-01-07 | 3d |  |  | start no earlier than 2009-10-05 | Electrical Designer | 24h | 24h | 1,000 | 2,128 | 1,000 |
| 504 | 6.1.2.11.1.2 | Install additional cable management |  | 3d | 2009-11-19 A | 2009-11-24 A | 503 | 100% |  | 2010-01-08 | 2010-01-11 | 2d |  |  |  | Electrical Technician | 24h | 24h |  | 752 |  |
| 505 | 6.1.2.11.1.3 | Install cables temporary position |  | 5d | 2009-11-24 A | 2009-12-01 A | 504 | 100% |  | 2010-01-12 | 2010-01-14 | 3d |  |  |  | Electrical Technician | 40h | 40h |  | 1,128 |  |
| 506 | 6.1.2.11.1.4 | Terminate cables |  | 2d | 2009-12-01 A | 2009-12-03 A | 505 | 100% |  | 2010-01-15 | 2010-01-15 | 1d |  |  |  | Electrical Technician | 16h | 16h |  | 376 |  |
| 507 | 6.1.2.11.1.5 | KL electrical temporary position complete | milestone | 0d | 2009-12-03 A | 2009-12-03 A | 506 | 100% |  | 2010-01-15 | 2010-01-15 | 0d |  |  |  |  |  |  |  |  |  |
| 508 | 6.1.2.11.1.6 | KL ready for repositioning | milestone | 0d | 2012-02-01 A | 2012-02-01 A | 351 | 100% |  |  |  |  |  |  |  |  |  |  |  |  |  |
| 509 | 6.1.2.11.1.7 | Disconnect cabling |  | 2d | 2012-02-02 | 2012-02-03 | 508 |  |  |  |  |  | 1980d | 0d |  | Electrical Technician | 16h |  |  |  |  |
| 510 | 6.1.2.11.1.8 | Install additional cable tray |  | 1d | 2012-02-06 | 2012-02-06 | 509 |  |  |  |  |  | 1980d | 0d |  | Electrical Technician | 8h |  |  |  |  |
| 511 | 6.1.2.11.1.9 | KL Reposition | milestone | 0d | 2012-02-06 | 2012-02-06 | 510 |  |  |  |  |  | 1980d | 0d |  |  |  |  |  |  |  |
| 512 | 6.1.2.11.1.10 | Re-cable KL In new position |  | 1.85d | 2012-02-07 | 2012-02-08 | 511 |  |  |  |  |  | 1981.15d | 0d |  | Electrical Technician | 14.8h |  |  |  |  |
| 513 | 6.1.2.11.1.11 | KL electrical Step IV complete | milestone | 0d | 2012-02-08 | 2012-02-08 | 512 |  |  |  |  |  | 1981.15d | 1.15d |  |  |  |  |  |  |  |
| 514 | 6.1.2.11.2 | **KL Step IV** |  | 10.18d | 2009-11-25 | 2009-12-09 |  |  |  | 2011-04-14 | 2011-04-26 | 9d | 2538.65d |  |  |  | 81.4h |  | 1,000 | 4,384 |  |
| 515 | 6.1.2.11.2.1 | Evaluate cable / system requirements |  | 2.77d | 2009-11-25 | 2009-11-27 |  |  |  | 2011-04-14 | 2011-04-18 | 3d | 2538.65d | 0d | start no earlier than 2009-11-25 | Electrical Designer | 22.2h |  | 1,000 | 2,128 |  |
| 516 | 6.1.2.11.2.2 | Install additional cable management |  | 1.85d | 2009-11-27 | 2009-12-01 | 515 |  |  | 2011-04-19 | 2011-04-20 | 2d | 2538.65d | 0d |  | Electrical Technician | 14.8h |  |  | 752 |  |
| 517 | 6.1.2.11.2.3 | Install cables |  | 3.7d | 2009-12-01 | 2009-12-07 | 516 |  |  | 2011-04-21 | 2011-04-25 | 3d | 2538.65d | 0d |  | Electrical Technician | 29.6h |  |  | 1,128 |  |
| 518 | 6.1.2.11.2.4 | Terminate cables |  | 1.85d | 2009-12-07 | 2009-12-09 | 517 |  |  | 2011-04-26 | 2011-04-26 | 1d | 2538.65d | 0d |  | Electrical Technician | 14.8h |  |  | 376 |  |
| 519 | 6.1.2.11.2.5 | KL Step IV electrical complete | milestone | 0d | 2009-12-09 | 2009-12-09 | 518 |  |  | 2011-04-26 | 2011-04-26 | 0d | 2538.65d | 0d |  |  |  |  |  |  |  |
| 520 | 6.1.2.11.3 | **KL Step V** |  | 10.18d | 2017-06-20 | 2017-07-04 |  |  |  | 2012-04-05 | 2012-04-17 | 9d | 564.65d |  |  |  | 81.4h |  | 1,000 | 4,384 |  |
| 521 | 6.1.2.11.3.1 | Evaluate cable / system requirements |  | 2.77d | 2017-06-20 | 2017-06-22 | 1034SS |  |  | 2012-04-05 | 2012-04-09 | 3d | 564.65d | 0d | start no earlier than 2010-02-01 | Electrical Designer | 22.2h |  | 1,000 | 2,128 |  |
| 522 | 6.1.2.11.3.2 | Install additional cable management |  | 1.85d | 2017-06-22 | 2017-06-26 | 521 |  |  | 2012-04-10 | 2012-04-11 | 2d | 564.65d | 0d |  | Electrical Technician | 14.8h |  |  | 752 |  |
| 523 | 6.1.2.11.3.3 | Install cables |  | 3.7d | 2017-06-26 | 2017-06-30 | 522 |  |  | 2012-04-12 | 2012-04-16 | 3d | 564.65d | 0d |  | Electrical Technician | 29.6h |  |  | 1,128 |  |
| 524 | 6.1.2.11.3.4 | Terminate cables |  | 1.85d | 2017-06-30 | 2017-07-04 | 523 |  |  | 2012-04-17 | 2012-04-17 | 1d | 564.65d | 0d |  | Electrical Technician | 14.8h |  |  | 376 |  |
| 525 | 6.1.2.11.3.5 | KL Step V electrical complete | milestone | 0d | 2017-07-04 | 2017-07-04 | 524 |  |  | 2012-04-17 | 2012-04-17 | 0d | 564.65d | 0d |  |  |  |  |  |  |  |

| ID | WBS | Task | Type | Duration | Start | Finish | Predecessors | Complete | Remaining | Baseline start | Baseline finish | Baseline duration | Total slack | Free slack | Constraint | Resources | Work | Actual work | Cost | Baseline cost | Actual cost |
| --- | --- | --- | --- | --- | --- | --- | --- | --- | --- | --- | --- | --- | --- | --- | --- | --- | --- | --- | --- | --- | --- |
| 526 | 6.1.2.11.4 | **KL Step VI** |  | 9.32d | 2018-09-11 | 2018-09-24 |  |  |  | 2012-11-08 | 2012-11-20 | 9d? | 245.5d |  |  |  | 74.6h |  | 1,000 | 4,384 |  |
| 527 | 6.1.2.11.4.1 | Evaluate cable / system requirements |  | 2.77d | 2018-09-11 | 2018-09-13 | 1080SS |  |  | 2012-11-08 | 2012-11-12 | 3d | 245.5d | 0d | start no earlier than 2010-02-01 | Electrical Designer | 22.2h |  | 1,000 | 2,128 |  |
| 528 | 6.1.2.11.4.2 | Install additional cable management |  | 1.85d | 2018-09-13 | 2018-09-17 | 527 |  |  | 2012-11-13 | 2012-11-14 | 2d | 245.5d | 0d |  | Electrical Technician | 14.8h |  |  | 752 |  |
| 529 | 6.1.2.11.4.3 | Install cables |  | 3.7d | 2018-09-17 | 2018-09-21 | 528 |  |  | 2012-11-15 | 2012-11-19 | 3d | 245.5d | 0d |  | Electrical Technician | 29.6h |  |  | 1,128 |  |
| 530 | 6.1.2.11.4.4 | Terminate cables |  | 1d | 2018-09-21 | 2018-09-24 | 529 |  |  | 2012-11-20 | 2012-11-20 | 1d | 245.5d | 0d |  | Electrical Technician | 8h |  |  | 376 |  |
| 531 | 6.1.2.11.4.5 | KL Step VI electrical complete | milestone | 0d | 2018-09-24 | 2018-09-24 | 530 |  |  | 2012-11-20 | 2012-11-20 | 0d | 245.5d | 0d |  |  |  |  |  |  |  |
| 532 | 6.1.2.11.5 | **EMR Step II** |  | 196d | 2011-05-16 A | 2012-02-13 |  | 86% | 27.22d | 2010-01-05 | 2010-01-15 | 9d | 1980d |  |  |  | 272h | 232h | 1,000 | 4,384 | 1,000 |
| 533 | 6.1.2.11.5.1 | Design additional HV rack - mezzanine |  | 3d | 2011-05-16 A | 2011-05-18 A |  | 100% |  |  |  |  |  |  | start no earlier than 2011-05-16 | Electrical Designer | 24h | 24h |  |  |  |
| 534 | 6.1.2.11.5.2 | Assemble additional HV rack |  | 5d | 2011-05-19 A | 2011-05-25 A | 533 | 100% |  |  |  |  |  |  |  | Electrical Technician | 40h | 40h |  |  |  |
| 535 | 6.1.2.11.5.3 | Transport to RAL |  | 2d | 2011-05-26 A | 2011-05-27 A | 534 | 100% |  |  |  |  |  |  |  |  |  |  |  |  |  |
| 536 | 6.1.2.11.5.4 | Evaluate cable / system requirements |  | 3d | 2011-05-30 A | 2011-06-01 A | 535 | 100% |  | 2010-01-05 | 2010-01-07 | 3d |  |  | start no earlier than 2010-07-05 | Electrical Designer | 24h | 24h | 1,000 | 2,128 | 1,000 |
| 537 | 6.1.2.11.5.5 | Install additional HV rack |  | 2d | 2011-06-02 A | 2011-06-03 A | 536 | 100% |  |  |  |  |  |  |  | Electrical Technician | 16h | 16h |  |  |  |
| 538 | 6.1.2.11.5.6 | Install additional cable management |  | 3d | 2011-06-06 A | 2011-06-08 A | 537 | 100% |  |  |  |  |  |  |  | Electrical Technician | 24h | 24h |  |  |  |
| 539 | 6.1.2.11.5.7 | Reroute HV cables to new HV rack |  | 3d | 2011-06-09 A | 2011-06-13 A | 538 | 100% |  |  |  |  |  |  |  | Electrical Technician | 24h | 24h |  |  |  |
| 540 | 6.1.2.11.5.8 | EMR Delivered to RAL | milestone | 0d | 2011-06-13 A | 2011-06-13 A | 539 | 100% |  |  |  |  |  |  | start no earlier than 2011-02-14 |  |  |  |  |  |  |
| 541 | 6.1.2.11.5.9 | Install additional cable management |  | 3d | 2011-06-14 A | 2011-06-16 A | 540 | 100% |  | 2010-01-08 | 2010-01-11 | 2d |  |  |  | Electrical Technician | 24h | 24h |  | 752 |  |
| 542 | 6.1.2.11.5.10 | Install cables temporary position |  | 5d | 2011-06-17 A | 2011-06-23 A | 541 | 100% |  | 2010-01-12 | 2010-01-14 | 3d |  |  |  | Electrical Technician | 40h | 40h |  | 1,128 |  |
| 543 | 6.1.2.11.5.11 | Terminate cables |  | 2d | 2011-06-24 A | 2011-06-27 A | 542 | 100% |  | 2010-01-15 | 2010-01-15 | 1d |  |  |  | Electrical Technician | 16h | 16h |  | 376 |  |
| 544 | 6.1.2.11.5.12 | EMR electrical temporary position complete | milestone | 0d | 2011-06-27 A | 2011-06-27 A | 543 | 100% |  | 2010-01-15 | 2010-01-15 | 0d |  |  |  |  |  |  |  |  |  |
| 545 | 6.1.2.11.5.13 | EMR ready for repositioning | milestone | 0d | 2012-02-01 A | 2012-02-01 A | 351 | 100% |  |  |  |  |  |  | finish no earlier than 2010-08-02 |  |  |  |  |  |  |
| 546 | 6.1.2.11.5.14 | Disconnect cabling |  | 2d | 2012-02-07 | 2012-02-08 | 511, 545 |  |  |  |  |  | 1980d | 0d |  | Electrical Technician | 16h |  |  |  |  |
| 547 | 6.1.2.11.5.15 | Install additional cable tray |  | 1d | 2012-02-09 | 2012-02-09 | 546 |  |  |  |  |  | 1980d | 0d |  | Electrical Technician | 8h |  |  |  |  |
| 548 | 6.1.2.11.5.16 | EMR Reposition | milestone | 0d | 2012-02-09 | 2012-02-09 | 513, 547 |  |  |  |  |  | 1980d | 0d |  |  |  |  |  |  |  |
| 549 | 6.1.2.11.5.17 | Re-cable EMR In new position |  | 2d | 2012-02-10 | 2012-02-13 | 548 |  |  |  |  |  | 1980d | 0d |  | Electrical Technician | 16h |  |  |  |  |
| 550 | 6.1.2.11.5.18 | EMR electrical Step IV complete | milestone | 0d | 2012-02-13 | 2012-02-13 | 549 |  |  |  |  |  | 1980d |  |  |  |  |  |  |  |  |

| ID | WBS | Task | Type | Duration | Start | Finish | Predecessors | Complete | Remaining | Baseline start | Baseline finish | Baseline duration | Total slack | Free slack | Constraint | Resources | Work | Actual work | Cost | Baseline cost | Actual cost |
| --- | --- | --- | --- | --- | --- | --- | --- | --- | --- | --- | --- | --- | --- | --- | --- | --- | --- | --- | --- | --- | --- |
| 551 | 6.1.2.11.6 | **EMR Step IV** |  | 10.18d | 2009-12-09 | 2009-12-23 |  |  |  | 2011-04-14 | 2011-04-26 | 9d | 2538.65d |  |  |  | 81.4h |  | 1,000 | 4,384 |  |
| 552 | 6.1.2.11.6.1 | Evaluate cable / system requirements |  | 2.77d | 2009-12-09 | 2009-12-11 | 519 |  |  | 2011-04-14 | 2011-04-18 | 3d | 2538.65d | 0d | start no earlier than 2009-11-25 | Electrical Designer | 22.2h |  | 1,000 | 2,128 |  |
| 553 | 6.1.2.11.6.2 | Install additional cable management |  | 1.85d | 2009-12-11 | 2009-12-15 | 552 |  |  | 2011-04-19 | 2011-04-20 | 2d | 2538.65d | 0d |  | Electrical Technician | 14.8h |  |  | 752 |  |
| 554 | 6.1.2.11.6.3 | Install cables |  | 3.7d | 2009-12-15 | 2009-12-21 | 553 |  |  | 2011-04-21 | 2011-04-25 | 3d | 2538.65d | 0d |  | Electrical Technician | 29.6h |  |  | 1,128 |  |
| 555 | 6.1.2.11.6.4 | Terminate cables |  | 1.85d | 2009-12-21 | 2009-12-23 | 554 |  |  | 2011-04-26 | 2011-04-26 | 1d | 2538.65d | 0d |  | Electrical Technician | 14.8h |  |  | 376 |  |
| 556 | 6.1.2.11.6.5 | EMR Step IV electrical complete | milestone | 0d | 2009-12-23 | 2009-12-23 | 555 |  |  | 2011-04-26 | 2011-04-26 | 0d | 2538.65d |  |  |  |  |  |  |  |  |
| 557 | 6.1.2.11.7 | **EMR Step V** |  | 10.18d | 2017-07-04 | 2017-07-18 |  |  |  | 2012-04-05 | 2012-04-17 | 9d | 564.65d |  |  |  | 81.4h |  | 1,000 | 4,384 |  |
| 558 | 6.1.2.11.7.1 | Evaluate cable / system requirements |  | 2.77d | 2017-07-04 | 2017-07-06 | 525 |  |  | 2012-04-05 | 2012-04-09 | 3d | 564.65d | 0d | start no earlier than 2010-02-01 | Electrical Designer | 22.2h |  | 1,000 | 2,128 |  |
| 559 | 6.1.2.11.7.2 | Install additional cable management |  | 1.85d | 2017-07-06 | 2017-07-10 | 558 |  |  | 2012-04-10 | 2012-04-11 | 2d | 564.65d | 0d |  | Electrical Technician | 14.8h |  |  | 752 |  |
| 560 | 6.1.2.11.7.3 | Install cables |  | 3.7d | 2017-07-10 | 2017-07-14 | 559 |  |  | 2012-04-12 | 2012-04-16 | 3d | 564.65d | 0d |  | Electrical Technician | 29.6h |  |  | 1,128 |  |
| 561 | 6.1.2.11.7.4 | Terminate cables |  | 1.85d | 2017-07-14 | 2017-07-18 | 560 |  |  | 2012-04-17 | 2012-04-17 | 1d | 564.65d | 0d |  | Electrical Technician | 14.8h |  |  | 376 |  |
| 562 | 6.1.2.11.7.5 | EMR Step V electrical complete | milestone | 0d | 2017-07-18 | 2017-07-18 | 561 |  |  | 2012-04-17 | 2012-04-17 | 0d | 564.65d |  |  |  |  |  |  |  |  |
| 563 | 6.1.2.11.8 | **EMR Step VI** |  | 10.18d | 2018-09-24 | 2018-10-08 |  |  |  | 2012-11-08 | 2012-11-20 | 9d? | 245.5d |  |  |  | 81.4h |  | 1,000 | 4,384 |  |
| 564 | 6.1.2.11.8.1 | Evaluate cable / system requirements |  | 2.77d | 2018-09-24 | 2018-09-27 | 531 |  |  | 2012-11-08 | 2012-11-12 | 3d | 245.5d | 0d | start no earlier than 2010-02-01 | Electrical Designer | 22.2h |  | 1,000 | 2,128 |  |
| 565 | 6.1.2.11.8.2 | Install additional cable management |  | 1.85d | 2018-09-27 | 2018-09-28 | 564 |  |  | 2012-11-13 | 2012-11-14 | 2d | 245.5d | 0d |  | Electrical Technician | 14.8h |  |  | 752 |  |
| 566 | 6.1.2.11.8.3 | Install cables |  | 3.7d | 2018-09-28 | 2018-10-04 | 565 |  |  | 2012-11-15 | 2012-11-19 | 3d | 245.5d | 0d |  | Electrical Technician | 29.6h |  |  | 1,128 |  |
| 567 | 6.1.2.11.8.4 | Terminate cables |  | 1.85d | 2018-10-04 | 2018-10-08 | 566 |  |  | 2012-11-20 | 2012-11-20 | 1d | 245.5d | 0d |  | Electrical Technician | 14.8h |  |  | 376 |  |
| 568 | 6.1.2.11.8.5 | EMR Step VI electrical complete | milestone | 0d | 2018-10-08 | 2018-10-08 | 567 |  |  | 2012-11-20 | 2012-11-20 | 0d | 245.5d |  |  |  |  |  |  |  |  |
| 569 | 6.2 | **Hydrogen system** |  | 2016d | 2010-04-05 A | 2017-12-25 |  | 67% | 665.24d |  |  |  | 411d |  |  | Hydrogen System | 20192h | 2808h | 249,559.12 |  | 120,402.24 |
| 570 | 6.2.1 | **Hydrogen system A/R&D** |  | 449d | 2010-04-05 A | 2011-12-22 A |  | 100% |  |  |  |  |  |  |  |  | 2808h | 2808h | 120,402.24 |  | 120,402.24 |
| 571 | 6.2.1.1 | **Hydrogen System A/R&D Infrastructure** |  | 429d | 2010-05-03 A | 2011-12-22 A |  | 100% |  |  |  |  |  |  |  |  | 2364h | 2364h | 93,731.56 |  | 93,731.56 |
| 572 | 6.2.1.1.1 | **AS Scientific Contract - open work** |  | 20d | 2011-04-12 A | 2011-05-09 A |  | 100% |  |  |  |  |  |  |  |  |  |  |  |  |  |
| 573 | 6.2.1.1.1.1 | Cryostat pre-cool repair |  | 20d | 2011-04-12 A | 2011-05-09 A |  | 100% |  |  |  |  |  |  | start no earlier than 2011-04-12 |  |  |  |  |  |  |
| 574 | 6.2.1.1.2 | **Controls & Electrical (DL)** |  | 189d | 2011-04-04 A | 2011-12-22 A |  | 100% |  |  |  |  |  |  |  |  | 1356h | 1356h | 63,857.48 |  | 63,857.48 |
| 575 | 6.2.1.1.2.1 | Mods for Hydride Bed control |  | 60d | 2011-04-04 A | 2011-06-24 A |  | 100% |  |  |  |  |  |  | start no earlier than 2011-04-04 | Phil Warburton | 480h | 480h | 27,670.4 |  | 27,670.4 |
| 576 | 6.2.1.1.2.2 | Extract system controls |  | 2d | 2011-07-01 A | 2011-07-04 A | 575 | 100% |  |  |  |  |  |  | finish no earlier than 2011-07-04 | Electrical Technician [50%]; Phil Warburton | 24h | 24h | 755.68 |  | 755.68 |
| 577 | 6.2.1.1.2.3 | Vacuum system controls |  | 15d | 2011-07-05 A | 2011-07-25 A | 576 | 100% |  |  |  |  |  |  |  | Phil Warburton | 120h | 120h | 5,667.6 |  | 5,667.6 |
| 578 | 6.2.1.1.2.4 | Integrate hydrogen detection with control system |  | 10d | 2011-09-05 A | 2011-09-16 A | 577 | 100% |  |  |  |  |  |  |  | Phil Warburton | 80h | 80h | 3,778.4 |  | 3,778.4 |
| 579 | 6.2.1.1.2.5 | Test operation of hydrogen detection |  | 5d | 2011-09-19 A | 2011-09-26 A | 578 | 100% |  |  |  |  |  |  |  | Phil Warburton | 40h | 40h | 1,889.2 |  | 1,889.2 |
| 580 | 6.2.1.1.2.6 | Hydrogen Plant Controls fully installed | milestone | 0d | 2011-09-26 A | 2011-09-26 A | 579 | 100% |  |  |  |  |  |  | start no earlier than 2010-11-17 |  |  |  |  |  |  |
| 581 | 6.2.1.1.2.7 | Terminate remaining cables into Hydrogen Plant |  | 10d | 2011-09-27 A | 2011-10-10 A | 580 | 100% |  |  |  |  |  |  |  | Electrical Technician; Phil Warburton | 100h | 100h | 944.6 |  | 944.6 |
| 582 | 6.2.1.1.2.8 | Electrically commission system with Plant |  | 5d | 2011-10-11 A | 2011-10-17 A | 581 | 100% |  |  |  |  |  |  |  | Phil Warburton; Ian Mullacrane | 80h | 80h | 4,259.6 |  | 4,259.6 |
| 583 | 6.2.1.1.2.9 | Modifications to Plant during system commissioning |  | 40d | 2011-10-18 A | 2011-12-12 A | 582 | 100% |  |  |  |  |  |  |  | Phil Warburton; Electrical Technician [10%] | 352h | 352h | 15,113.6 |  | 15,113.6 |
| 584 | 6.2.1.1.2.10 | Resolve level sensor problems |  | 8d | 2011-12-13 A | 2011-12-22 A | 583 | 100% |  |  |  |  |  |  |  | Phil Warburton; Matt Hills [25%] | 80h | 80h | 3,778.4 |  | 3,778.4 |
| 585 | 6.2.1.1.2.11 | Hydrogen Plant commissioned | milestone | 0d | 2011-12-22 A | 2011-12-22 A | 584 | 100% |  |  |  |  |  |  |  |  |  |  |  |  |  |

| ID | WBS | Task | Duration | Start | Finish | Predecessors | Complete | Constraint | Resources | Work | Actual work | Cost | Actual cost |
| --- | --- | --- | --- | --- | --- | --- | --- | --- | --- | --- | --- | --- | --- |
| 586 | 6.2.1.1.3 | **Ventilation / Extraction System** | 148d | 2010-12-13 A | 2011-07-06 A |  | 100% |  |  | 248h | 248h | 5,274.08 | 5,274.08 |
| 587 | 6.2.1.1.3.1 | Lift pumps onto hall roof | 2d | 2011-04-19 A | 2011-04-20 A |  | 100% | start no earlier than 2011-04-19 |  |  |  |  |  |
| 588 | 6.2.1.1.3.2 | Install remaining external ductowork | 15d | 2011-04-21 A | 2011-05-11 A | 587 | 100% |  |  |  |  |  |  |
| 589 | 6.2.1.1.3.3 | Install remaining ducting to enclosures | 20d | 2011-05-12 A | 2011-06-08 A | 588 | 100% |  |  |  |  |  |  |
| 590 | 6.2.1.1.3.4 | Install ducting to H2 charge station | 20d | 2011-06-09 A | 2011-07-06 A | 589 | 100% |  |  |  |  |  |  |
| 591 | 6.2.1.1.3.5 | Install Extraction system controls | 10d | 2011-01-21 A | 2011-02-03 A |  | 100% | start no earlier than 2011-01-21 | Electrical Technician | 80h | 80h |  |  |
| 592 | 6.2.1.1.3.6 | Install UPS | 2d | 2011-03-24 A | 2011-03-25 A |  | 100% | start no earlier than 2011-03-24 | Ian Mullacrane [50%]; Electrical Technician | 8h | 8h | 474.08 | 474.08 |
| 593 | 6.2.1.1.3.7 | Install high level vents and extraction fans | 80d | 2010-12-13 A | 2011-04-01 A |  | 100% | start no earlier than 2010-12-13 | Merit1 [25%] | 160h | 160h | 4,800 | 4,800 |
| 594 | 6.2.1.1.3.8 | Install hydrogen detection system in Hall | 15d | 2011-05-19 A | 2011-06-08 A |  | 100% | start no earlier than 2011-05-19 |  |  |  |  |  |
| 595 | 6.2.1.1.3.9 | Test operation of hydrogen detection | 11d | 2011-04-11 A | 2011-04-25 A |  | 100% | start no earlier than 2011-04-11 |  |  |  |  |  |
| 596 | 6.2.1.1.4 | **Vacuum System** | 59d | 2011-06-23 A | 2011-09-13 A |  | 100% |  |  | 240h | 240h |  |  |
| 597 | 6.2.1.1.4.1 | Install / Terminate power feeds associated with pumping system | 39d | 2011-06-23 A | 2011-08-16 A | 611 | 100% | start no earlier than 2011-06-23 | Electrical Technician [25.6%] | 80h | 80h |  |  |
| 598 | 6.2.1.1.4.2 | Install AC cabling main feeds etc | 20d | 2011-08-17 A | 2011-09-13 A | 597 | 100% |  | Electrical Technician | 160h | 160h |  |  |
| 599 | 6.2.1.1.5 | **Pump Enclosure** | 57d | 2011-04-19 A | 2011-07-06 A |  | 100% |  |  | 40h | 40h | 15,000 | 15,000 |
| 600 | 6.2.1.1.5.1 | Lift steelwork onto roof | 2d | 2011-04-19 A | 2011-04-20 A |  | 100% | start no earlier than 2011-04-19 |  |  |  |  |  |
| 601 | 6.2.1.1.5.2 | Fabricate enclosure | 20d | 2011-04-21 A | 2011-05-18 A | 600 | 100% |  |  |  |  |  |  |
| 602 | 6.2.1.1.5.3 | Install electrical services | 20d | 2011-05-19 A | 2011-06-15 A | 601 | 100% | start no earlier than 2011-03-21 | Gordon Stanford [25%] | 40h | 40h | 15,000 | 15,000 |
| 603 | 6.2.1.1.5.4 | Install vacuum pumps and other components | 15d | 2011-06-16 A | 2011-07-06 A | 602 | 100% |  |  |  |  |  |  |
| 604 | 6.2.1.1.6 | **Supply pipework** | 40d | 2010-10-04 A | 2010-11-26 A |  | 100% |  |  | 320h | 320h | 9,600 | 9,600 |
| 605 | 6.2.1.1.6.1 | Install piping to bottle store (He and N2) | 20d | 2010-10-04 A | 2010-10-29 A |  | 100% |  | Merit1 | 160h | 160h | 4,800 | 4,800 |
| 606 | 6.2.1.1.6.2 | Install piping for charging Hydride Bed | 20d | 2010-11-01 A | 2010-11-26 A | 605 | 100% |  | Merit1 | 160h | 160h | 4,800 | 4,800 |
| 607 | 6.2.1.1.7 | **Prepare H2 Control Room** | 129d | 2010-05-03 A | 2010-10-28 A |  | 100% |  |  | 160h | 160h |  |  |
| 608 | 6.2.1.1.7.1 | Install power, lighting and network | 30d | 2010-05-03 A | 2010-06-11 A |  | 100% |  |  |  |  |  |  |
| 609 | 6.2.1.1.7.2 | Install Air-Conditioning | 20d | 2010-06-14 A | 2010-07-09 A | 608 | 100% |  |  |  |  |  |  |
| 610 | 6.2.1.1.7.3 | Install electrical feed to HLCR | 5d | 2010-10-01 A | 2010-10-07 A |  | 100% | start no earlier than 2010-10-01 | Electrical Technician | 40h | 40h |  |  |
| 611 | 6.2.1.1.7.4 | Install power distribution boards | 15d | 2010-10-08 A | 2010-10-28 A | 610 | 100% |  | Electrical Technician | 120h | 120h |  |  |

Notes:
- 606: Will this be done within the hall, or to a dedicated hydrogen storage area?

| ID | WBS | Task | Duration | Start | Finish | Predecessors | Complete | Total slack | Free slack | Constraint | Resources | Work | Actual work | Cost | Actual cost |
| --- | --- | --- | --- | --- | --- | --- | --- | --- | --- | --- | --- | --- | --- | --- | --- |
| 612 | 6.2.1.2 | **Installation of main system components sys A/R&D** | 351d | 2010-04-05 A | 2011-08-08 A |  | 100% |  |  |  |  | 444h | 444h | 26,670.68 | 26,670.68 |
| 613 | 6.2.1.2.1 | Install Gas Panel Enclosure on South Mezzanine | 3d | 2010-10-25 A | 2010-10-27 A |  | 100% |  |  | start no earlier than 2010-10-25 | Merit1 | 24h | 24h | 720 | 720 |
| 614 | 6.2.1.2.2 | **Install Heater/Chiler on South Mezzanine** | 5d | 2010-10-28 A | 2010-11-03 A |  | 100% |  |  |  |  | 36h | 36h | 1,355.68 | 1,355.68 |
| 615 | 6.2.1.2.2.1 | Position on Mezzanine | 1d | 2010-10-28 A | 2010-10-28 A | 613 | 100% |  |  |  | Merit1 [50%] | 4h | 4h | 120 | 120 |
| 616 | 6.2.1.2.2.2 | Connect to Hydride Bed and install instrumentation | 4d | 2010-10-29 A | 2010-11-03 A | 613, 615 | 100% |  |  |  | Matt Hills [50%]; Merit1 [50%] | 32h | 32h | 1,235.68 | 1,235.68 |
| 617 | 6.2.1.2.3 | **Install Test Cryostat in Hall** | 13d | 2010-10-22 A | 2010-11-09 A |  | 100% |  |  |  |  | 16h | 16h | 480 | 480 |
| 618 | 6.2.1.2.3.1 | Deliver cryostat to Hall | 1d | 2010-10-22 A | 2010-10-22 A | 130 | 100% |  |  | start no earlier than 2008-07-07 |  |  |  |  |  |
| 619 | 6.2.1.2.3.2 | Install cryocooler compressor and lines | 2d | 2010-11-04 A | 2010-11-05 A | 614, 618 | 100% |  |  |  | Merit1 [50%] | 8h | 8h | 240 | 240 |
| 620 | 6.2.1.2.3.3 | Install cryostat vacuum pump | 2d | 2010-11-08 A | 2010-11-09 A | 618, 619 | 100% |  |  |  | Merit1 [50%] | 8h | 8h | 240 | 240 |
| 621 | 6.2.1.2.4 | Design Transfer Line supports | 20d | 2010-04-05 A | 2010-04-30 A |  | 100% |  |  | start no earlier than 2010-04-05 | Alan Muir | 160h | 160h | 7,000 | 7,000 |
| 622 | 6.2.1.2.5 | Manufacture Transfer Line supports | 30d | 2010-05-03 A | 2010-06-11 A | 621 | 100% |  |  |  |  |  |  | 5,875 | 5,875 |
| 623 | 6.2.1.2.6 | Install Transfer Line supports | 2d | 2011-01-24 A | 2011-01-25 A | 613, 617 | 100% |  |  | start no earlier than 2011-01-24 | Merit1 | 16h | 16h | 480 | 480 |
| 624 | 6.2.1.2.7 | Install Transfer Line | 2d | 2011-01-26 A | 2011-01-27 A | 623 | 100% |  |  |  | Merit1 [50%] | 8h | 8h | 240 | 240 |
| 625 | 6.2.1.2.8 | **Install Vacuum System** | 23d | 2011-07-07 A | 2011-08-08 A |  | 100% |  |  |  |  | 184h | 184h | 10,520 | 10,520 |
| 626 | 6.2.1.2.8.1 | Install backing pumps in enclosure | 3d | 2011-07-07 A | 2011-07-11 A | 599 | 100% |  |  |  | Merit1 | 24h | 24h | 720 | 720 |
| 627 | 6.2.1.2.8.2 | Install turbo pumps in hall | 10d | 2011-07-12 A | 2011-07-25 A | 626 | 100% |  |  |  | Merit1 | 80h | 80h | 7,400 | 7,400 |
| 628 | 6.2.1.2.8.3 | Install vacuum piping | 10d | 2011-07-26 A | 2011-08-08 A | 627 | 100% |  |  |  | Merit1 | 80h | 80h | 2,400 | 2,400 |
| 629 | 6.2.2 | **Hydrogen system B** | 40d | 2016-08-04 | 2016-09-28 | 1171 |  | 734d |  |  |  | 628h |  | 65,165.94 |  |
| 630 | 6.2.2.1 | **Hydrogen System B Infrastructure** | 40d | 2016-08-04 | 2016-09-28 |  |  | 734d | 0d |  |  | 436h |  | 46,205.26 |  |
| 631 | 6.2.2.1.1 | **Ventilation System** | 20d | 2016-08-04 | 2016-08-31 |  |  | 754d |  |  |  | 160h |  | 4,800 |  |
| 632 | 6.2.2.1.1.1 | Install ductwork and piping | 20d | 2016-08-04 | 2016-08-31 |  |  | 754d |  | start no earlier than 2012-12-05 | Merit1 | 160h |  | 4,800 |  |
| 633 | 6.2.2.1.2 | **Vacuum System** | 40d | 2016-08-04 | 2016-09-28 |  |  | 734d |  |  |  | 16h |  | 33,260.66 |  |
| 634 | 6.2.2.1.2.1 | Procure pipework, valves and gauges | 40d | 2016-08-04 | 2016-09-28 |  |  | 734d |  | start no earlier than 2012-05-21 | Mike Courthold [5%] | 16h |  | 18,573.16 |  |
| 635 | 6.2.2.1.2.2 | Procure pump for AFC | 40d | 2016-08-04 | 2016-09-28 |  |  | 734d |  | start no earlier than 2012-05-21 |  |  |  | 14,687.5 |  |

Notes:
- 613: Hydride Bed, Gas Panel and Buffer Volume may be installed with enclosure or will be installed on base and enclosure assembled around them.
- 618: Will not be brought into hall until construction work on mezzanine floors are complete.
- 621: Dependent on design of South Mezzanine.

| ID | WBS | Task | Type | Duration | Start | Finish | Predecessors | Total slack | Free slack | Constraint | Resources | Work | Cost |
| --- | --- | --- | --- | --- | --- | --- | --- | --- | --- | --- | --- | --- | --- |
| 636 | 6.2.2.1.3 | **Supply pipework** |  | 20d | 2016-08-04 | 2016-08-31 |  | 754d |  |  |  | 260h | 8,144.6 |
| 637 | 6.2.2.1.3.1 | Identify storage areas and layout pipe routing |  | 5d | 2016-08-04 | 2016-08-10 |  | 754d | 0d | start no earlier than 2012-05-21 | Matt Hills [50%] | 20h | 944.6 |
| 638 | 6.2.2.1.3.2 | Install piping to gas panel (He and N2) |  | 15d | 2016-08-11 | 2016-08-31 | 637 | 754d |  |  | Merit1 | 120h | 3,600 |
| 639 | 6.2.2.1.3.3 | Install piping for charging Hydride Bed |  | 15d | 2016-08-11 | 2016-08-31 | 637 | 754d |  |  | Merit1 | 120h | 3,600 |
| 640 | 6.2.2.2 | **Installation of main system components sys B** |  | 36d | 2016-08-04 | 2016-09-22 |  | 738d | 0d |  |  | 192h | 18,960.68 |
| 641 | 6.2.2.2.1 | Install Gas Panel Enclosure on South Mezzanine |  | 1d | 2016-08-04 | 2016-08-04 |  | 738d | 0d | start no earlier than 2012-11-20 | Merit1 [50%] | 4h | 120 |
| 642 | 6.2.2.2.2 | Install pipework from gas panel to pump enclosure |  | 15d | 2016-08-05 | 2016-09-22 | 641 | 738d |  |  | Merit1 | 120h | 3,600 |
| 643 | 6.2.2.2.3 | **Install Heater/Chiler on South Mezzanine** |  | 9d | 2016-08-05 | 2016-08-17 |  | 764d |  |  |  | 68h | 15,240.68 |
| 644 | 6.2.2.2.3.1 | Position on Mezzanine |  | 1d | 2016-08-05 | 2016-08-05 | 641 | 764d | 0d |  | Merit1 [50%] | 4h | 120 |
| 645 | 6.2.2.2.3.2 | Connect to Hydride Bed and install instrumentation |  | 8d | 2016-08-08 | 2016-08-17 | 641, 644 | 764d | 0d |  | Matt Hills [50%]; Merit1 [50%] | 40h | 13,225.68 |
| 646 | 6.2.2.2.3.3 | Working Margin on instrumentation | milestone | 0d | 2016-08-17 | 2016-08-17 | 645 | 764d |  |  |  |  | 1,175 |
| 647 | 6.2.2.2.3.4 | Install Transfer Line supports |  | 2d | 2016-08-05 | 2016-08-08 | 641 | 769d | 0d |  | Merit1 | 16h | 480 |
| 648 | 6.2.2.2.3.5 | Install Transfer Line |  | 2d | 2016-08-09 | 2016-08-10 | 647 | 769d |  |  | Merit1 [50%] | 8h | 240 |
| 649 | 6.2.3 | **Hydrogen system C** |  | 40d | 2017-10-31 | 2017-12-25 | 1189 | 409d |  |  |  | 628h | 63,990.94 |
| 650 | 6.2.3.1 | **Hydrogen system C Infrastructure** |  | 40d | 2017-10-31 | 2017-12-25 |  | 409d | 0d |  |  | 436h | 46,205.26 |
| 651 | 6.2.3.1.1 | **Ventilation System** |  | 20d | 2017-10-31 | 2017-11-27 |  | 429d |  |  |  | 160h | 4,800 |
| 652 | 6.2.3.1.1.1 | Install ductwork and piping |  | 20d | 2017-10-31 | 2017-11-27 |  | 429d |  | start no earlier than 2013-11-15 | Merit1 | 160h | 4,800 |
| 653 | 6.2.3.1.2 | **Vacuum System** |  | 40d | 2017-10-31 | 2017-12-25 |  | 409d |  |  |  | 16h | 33,260.66 |
| 654 | 6.2.3.1.2.1 | Procure pipework, valves and gauges |  | 40d | 2017-10-31 | 2017-12-25 |  | 409d |  | start no earlier than 2013-05-01 | Mike Courthold [5%] | 16h | 18,573.16 |
| 655 | 6.2.3.1.2.2 | Procure pump for AFC |  | 40d | 2017-10-31 | 2017-12-25 |  | 409d |  | start no earlier than 2013-05-01 |  |  | 14,687.5 |
| 656 | 6.2.3.1.3 | **Supply pipework** |  | 35d | 2017-10-31 | 2017-12-18 |  | 414d |  |  |  | 260h | 8,144.6 |
| 657 | 6.2.3.1.3.1 | Identify storage areas and layout pipe routing |  | 5d | 2017-10-31 | 2017-11-06 |  | 414d | 0d | start no earlier than 2013-05-08 | Matt Hills [50%] | 20h | 944.6 |
| 658 | 6.2.3.1.3.2 | Install piping to gas panel (He and N2) |  | 15d | 2017-11-07 | 2017-11-27 | 657 | 414d | 0d |  | Merit1 | 120h | 3,600 |
| 659 | 6.2.3.1.3.3 | Install piping for charging Hydride Bed |  | 15d | 2017-11-28 | 2017-12-18 | 658 | 414d |  |  | Merit1 | 120h | 3,600 |

Notes:
- 639: Will this be done within the hall, or to a dedicated hydrogen storage area?
- 641: Hydride Bed, Gas Panel and Buffer Volume may be installed with enclosure or will be installed on base and enclosure assembled around them.
- 659: Will this be done within the hall, or to a dedicated hydrogen storage area?

| ID | WBS | Task | Type | Duration | Start | Finish | Predecessors | Complete | Remaining | Total slack | Free slack | Constraint | Resources | Work | Actual work | Cost |
| --- | --- | --- | --- | --- | --- | --- | --- | --- | --- | --- | --- | --- | --- | --- | --- | --- |
| 660 | 6.2.3.2 | **Installation of main system components sys C** |  | 24d | 2017-10-31 | 2017-12-01 |  |  |  | 425d | 0d |  |  | 192h |  | 17,785.68 |
| 661 | 6.2.3.2.1 | Install Gas Panel Enclosure on South Mezzanine |  | 1d | 2017-10-31 | 2017-10-31 |  |  |  | 425d | 0d | start no earlier than 2013-10-31 | Merit1 [50%] | 4h |  | 120 |
| 662 | 6.2.3.2.2 | Install pipework from gas panel to pump enclosure |  | 15d | 2017-11-01 | 2017-12-01 | 661 |  |  | 425d |  |  | Merit1 | 120h |  | 3,600 |
| 663 | 6.2.3.2.3 | **Install Heater/Chiler on South Mezzanine** |  | 9d | 2017-11-01 | 2017-11-13 |  |  |  | 439d |  |  |  | 68h |  | 14,065.68 |
| 664 | 6.2.3.2.3.1 | Position on Mezzanine |  | 1d | 2017-11-01 | 2017-11-01 | 661 |  |  | 439d | 0d |  | Merit1 [50%] | 4h |  | 120 |
| 665 | 6.2.3.2.3.2 | Connect to Hydride Bed and install instrumentation |  | 8d | 2017-11-02 | 2017-11-13 | 661, 664 |  |  | 439d |  |  | Matt Hills [50%]; Merit1 [50%] | 40h |  | 13,225.68 |
| 666 | 6.2.3.2.3.3 | Install Transfer Line supports |  | 2d | 2017-11-01 | 2017-11-02 | 661 |  |  | 444d | 0d |  | Merit1 | 16h |  | 480 |
| 667 | 6.2.3.2.3.4 | Install Transfer Line |  | 2d | 2017-11-03 | 2017-11-06 | 666 |  |  | 444d |  |  | Merit1 [50%] | 8h |  | 240 |
| 668 | 6.3 | **RF system** |  | 1623d | 2011-02-07 A | 2017-04-26 |  | 2% | 1584.31d | 623d |  |  | RF System | 34741.9h | 336.58h | 32,000 |
| 669 | 6.3.1 | **Infrastructure** |  | 1088.9d | 2011-02-07 A | 2015-04-09 |  | 3% | 1060.2d | 1157.1d |  |  |  | 12677.9h | 27.05h | 32,000 |
| 670 | 6.3.1.1 | **RF Hall Electrical Infrastructure** |  | 1088.9d | 2011-02-07 A | 2015-04-09 |  |  | 1087.06d | 1157.1d |  |  |  | 12677.9h | 27.05h | 32,000 |
| 671 | 6.3.1.1.1 | **RF Controls Rack #1** |  | 12d | 2013-04-08 | 2013-04-23 |  |  |  | 1157.1d |  |  | STEP V - TIARA | 192h |  |  |
| 672 | 6.3.1.1.1.1 | Install rack in MICE Hall |  | 2d | 2013-04-08 | 2013-04-09 |  |  |  | 1157.1d | 0d | start no earlier than 2013-04-08 | Electrical Technician | 16h |  |  |
| 673 | 6.3.1.1.1.2 | Install interface cable management / cable |  | 5d | 2013-04-10 | 2013-04-16 | 672 |  |  | 1669d | 0d |  | Electrical Technician | 40h |  |  |
| 674 | 6.3.1.1.1.3 | Commission system in MICE Hall |  | 5d | 2013-04-17 | 2013-04-23 | 673 |  |  | 1669d |  |  | Electrical Engineer | 40h |  |  |
| 675 | 6.3.1.1.2 | **RF Controls Rack #2** |  | 12d | 2014-01-10 | 2014-01-27 |  |  |  | 1470d |  |  | STEP V - TIARA | 192h |  |  |
| 676 | 6.3.1.1.2.1 | Install rack in MICE Hall |  | 2d | 2014-01-10 | 2014-01-13 |  |  |  | 1470d | 0d | start no earlier than 2014-01-10 | Electrical Technician | 16h |  |  |
| 677 | 6.3.1.1.2.2 | Install interface cable management / cable |  | 5d | 2014-01-14 | 2014-01-20 | 676 |  |  | 1470d | 0d |  | Electrical Technician | 40h |  |  |
| 678 | 6.3.1.1.2.3 | Commission system in MICE Hall |  | 5d | 2014-01-21 | 2014-01-27 | 677 |  |  | 1470d |  |  | Electrical Engineer | 40h |  |  |
| 679 | 6.3.1.1.3 | **RF System #1 - Installation** |  | 656d | 2011-02-07 A | 2013-08-12 |  | 1% | 650.79d | 1157.1d |  |  | STEP V - TIARA | 6718h | 27.05h | 8,000 |
| 680 | 6.3.1.1.3.1 | **4616 Amplifier system #1** |  | 613d | 2011-02-07 A | 2013-06-12 |  | 1% | 605.61d | 1157.1d |  |  |  | 870h | 16h | 4,000 |
| 681 | 6.3.1.1.3.1.1 | RF System #1 integration starts | milestone | 0d | 2011-02-07 A | 2011-02-07 A |  | 100% |  |  |  | start no earlier than 2011-02-07 |  |  |  |  |
| 682 | 6.3.1.1.3.1.2 | Design cable management |  | 2d | 2011-02-07 A | 2011-02-08 | 681 | 50% | 1d | 1687.1d | 0d |  | Electrical Engineer; Electrical Designer | 32h | 16h |  |
| 683 | 6.3.1.1.3.1.3 | Install cable management |  | 3d | 2011-02-09 | 2011-02-11 | 682 |  |  | 1687.1d | 0d |  | Electrical Designer; Electrical Technician | 48h |  | 1,000 |
| 684 | 6.3.1.1.3.1.4 | Design AC distribution |  | 2d | 2011-02-14 | 2011-02-15 | 683 |  |  | 1687.1d | 48d |  | Electrical Designer; Electrical Engineer | 32h |  |  |
| 685 | 6.3.1.1.3.1.5 | Install AC distribution |  | 10d | 2011-04-25 | 2011-05-06 | 684 |  |  | 1639.1d | 0d | start no earlier than 2011-04-25 | Electrical Technician; Electrical Designer | 160h |  | 1,000 |
| 686 | 6.3.1.1.3.1.6 | Produce cable schedules - controls interface |  | 10d | 2011-05-09 | 2011-05-20 | 685 |  |  | 1639.1d | 0d |  | Electrical Designer; Electrical Engineer | 160h |  |  |
| 687 | 6.3.1.1.3.1.7 | Install controls cables |  | 10d | 2011-05-23 | 2011-06-03 | 686 |  |  | 1639.1d | 0d |  | Electrical Designer; Electrical Technician | 160h |  | 1,500 |
| 688 | 6.3.1.1.3.1.8 | System #1 4616 Racks ready | milestone | 0d | 2011-06-03 | 2011-06-03 | 687 |  |  | 1639.1d | 482d | start no earlier than 2011-01-24 |  |  |  |  |
| 689 | 6.3.1.1.3.1.9 | Install HV Rack |  | 2d | 2013-04-10 | 2013-04-11 | 688, 672 |  |  | 1157.1d | 0d |  | Electrical Technician | 16h |  |  |
| 690 | 6.3.1.1.3.1.10 | Terminate HV Rack cables |  | 3d | 2013-04-12 | 2013-04-16 | 689 |  |  | 1157.1d | 0d |  | Electrical Technician | 24h |  |  |
| 691 | 6.3.1.1.3.1.11 | Install Auxiliary Rack |  | 2d | 2013-04-17 | 2013-04-18 | 690 |  |  | 1157.1d | 0d |  | Electrical Technician | 16h |  |  |
| 692 | 6.3.1.1.3.1.12 | Terminate Auxiliary Rack cables |  | 4d | 2013-04-19 | 2013-04-24 | 691 |  |  | 1157.1d | 0d |  | Electrical Technician | 32h |  | 500 |
| 693 | 6.3.1.1.3.1.13 | Prepare 4616 Dummy Load |  | 10d | 2013-04-25 | 2013-05-08 | 692 |  |  | 1157.1d | 0d |  | Electrical Technician; Electrical Engineer [25%] | 100h |  |  |
| 694 | 6.3.1.1.3.1.14 | Commission Electrical system |  | 5d | 2013-05-09 | 2013-05-15 | 693 |  |  | 1157.1d | 0d |  | Electrical Engineer; Electrical Technician [25%] | 50h |  |  |
| 695 | 6.3.1.1.3.1.15 | Commission RF with Dummy Load |  | 20d | 2013-05-16 | 2013-06-12 | 694 |  |  | 1157.1d | 0d |  | Electrical Engineer [25%] | 40h |  |  |

Notes:
- 661: Hydride Bed, Gas Panel and Buffer Volume may be installed with enclosure or will be installed on base and enclosure assembled around them.

| ID | WBS | Task | Type | Duration | Start | Finish | Predecessors | Total slack | Free slack | Constraint | Resources | Work | Cost |
| --- | --- | --- | --- | --- | --- | --- | --- | --- | --- | --- | --- | --- | --- |
| 696 | 6.3.1.1.3.2 | **TH116 Amplifier system #1** |  | 43d | 2013-06-13 | 2013-08-12 |  | 1157.1d |  |  |  | 600h | 4,000 |
| 697 | 6.3.1.1.3.2.1 | Design cable management |  | 2d | 2013-06-13 | 2013-06-14 | 695 | 1157.1d | 0d |  | Electrical Engineer; Electrical Designer | 32h |  |
| 698 | 6.3.1.1.3.2.2 | Install cable management |  | 3d | 2013-06-17 | 2013-06-19 | 697 | 1157.1d | 0d |  | Electrical Designer; Electrical Technician | 48h | 1,000 |
| 699 | 6.3.1.1.3.2.3 | Design AC distribution |  | 2d | 2013-06-20 | 2013-06-21 | 698 | 1157.1d | 0d |  | Electrical Designer; Electrical Engineer | 32h |  |
| 700 | 6.3.1.1.3.2.4 | Install AC distribution |  | 5d | 2013-06-24 | 2013-06-28 | 699 | 1157.1d | 0d |  | Electrical Technician; Electrical Designer | 80h | 1,000 |
| 701 | 6.3.1.1.3.2.5 | Produce cable schedules - controls interface |  | 10d | 2013-07-01 | 2013-07-12 | 700 | 1157.1d | 0d |  | Electrical Designer; Electrical Engineer | 160h |  |
| 702 | 6.3.1.1.3.2.6 | Install controls cables |  | 10d | 2013-07-15 | 2013-07-26 | 701 | 1157.1d | 0d |  | Electrical Designer; Electrical Technician | 160h | 1,500 |
| 703 | 6.3.1.1.3.2.7 | System #1 TH116 Racks ready | milestone | 0d | 2013-07-26 | 2013-07-26 | 702 | 1157.1d | 0d | start no earlier than 2011-04-11 |  |  |  |
| 704 | 6.3.1.1.3.2.8 | Install HV Rack |  | 2d | 2013-07-29 | 2013-07-30 | 703 | 1157.1d | 0d |  | Electrical Technician | 16h |  |
| 705 | 6.3.1.1.3.2.9 | Terminate HV Rack cables |  | 3d | 2013-07-31 | 2013-08-02 | 704 | 1157.1d | 0d |  | Electrical Technician | 24h |  |
| 706 | 6.3.1.1.3.2.10 | Install Auxiliary Rack |  | 2d | 2013-08-05 | 2013-08-06 | 705 | 1157.1d | 0d |  | Electrical Technician | 16h |  |
| 707 | 6.3.1.1.3.2.11 | Terminate Auxiliary Rack cables |  | 4d | 2013-08-07 | 2013-08-12 | 706 | 1157.1d | 0d |  | Electrical Technician | 32h | 500 |
| 708 | 6.3.1.1.4 | **RF System #2 - Installation** |  | 116.55d | 2013-08-12 | 2014-01-22 |  | 1157.1d |  | start no earlier than 2012-01-09 | STEP V - TIARA | 2338.4h | 8,000 |
| 709 | 6.3.1.1.4.1 | **4616 Amplifier system #2** |  | 58.27d | 2013-08-12 | 2013-11-01 | 707 | 1157.1d |  |  |  | 703h | 4,000 |
| 710 | 6.3.1.1.4.1.1 | RF System #2 integration starts | milestone | 0d | 2013-08-12 | 2013-08-12 |  | 1157.1d | 0d | start no earlier than 2011-04-04 |  |  |  |
| 711 | 6.3.1.1.4.1.2 | Design cable management |  | 1.85d | 2013-08-13 | 2013-08-14 | 710 | 1157.1d | 0d |  | Electrical Engineer; Electrical Designer | 29.6h |  |
| 712 | 6.3.1.1.4.1.3 | Install cable management |  | 2.77d | 2013-08-14 | 2013-08-19 | 711 | 1157.1d | 0d |  | Electrical Designer; Electrical Technician | 44.4h | 1,000 |
| 713 | 6.3.1.1.4.1.4 | Design AC distribution |  | 1.85d | 2013-08-19 | 2013-08-21 | 712 | 1157.1d | 0d |  | Electrical Designer; Electrical Engineer | 29.6h |  |
| 714 | 6.3.1.1.4.1.5 | Install AC distribution |  | 4.62d | 2013-08-21 | 2013-08-28 | 713 | 1157.1d | 0d |  | Electrical Technician; Electrical Designer | 74h | 1,000 |
| 715 | 6.3.1.1.4.1.6 | Produce cable schedules - controls interface |  | 9.25d | 2013-08-28 | 2013-09-10 | 714 | 1157.1d | 0d |  | Electrical Designer; Electrical Engineer | 148h |  |
| 716 | 6.3.1.1.4.1.7 | Install controls cables |  | 9.25d | 2013-09-10 | 2013-09-23 | 715 | 1157.1d | 0d |  | Electrical Designer; Electrical Technician | 148h | 1,500 |
| 717 | 6.3.1.1.4.1.8 | System #2 4616 Racks ready | milestone | 0d | 2013-09-23 | 2013-09-23 | 716 | 1157.1d | 0d | start no earlier than 2011-08-08 |  |  |  |
| 718 | 6.3.1.1.4.1.9 | Install HV Rack |  | 1.85d | 2013-09-23 | 2013-09-25 | 717 | 1157.1d | 0d |  | Electrical Technician | 14.8h |  |
| 719 | 6.3.1.1.4.1.10 | Terminate HV Rack cables |  | 2.77d | 2013-09-25 | 2013-09-30 | 718 | 1157.1d | 0d |  | Electrical Technician | 22.2h |  |
| 720 | 6.3.1.1.4.1.11 | Install Auxiliary Rack |  | 1.85d | 2013-09-30 | 2013-10-02 | 719 | 1157.1d | 0d |  | Electrical Technician | 14.8h |  |
| 721 | 6.3.1.1.4.1.12 | Terminate Auxiliary Rack cables |  | 3.7d | 2013-10-02 | 2013-10-07 | 720 | 1157.1d | 0d |  | Electrical Technician | 29.6h | 500 |
| 722 | 6.3.1.1.4.1.13 | Prepare 4616 Dummy Load |  | 9.25d | 2013-10-07 | 2013-10-21 | 721 | 1157.1d | 0d |  | Electrical Technician; Electrical Engineer [25%] | 92.5h |  |
| 723 | 6.3.1.1.4.1.14 | Commission Electrical system |  | 4.62d | 2013-10-21 | 2013-10-25 | 722 | 1157.1d | 0d |  | Electrical Engineer; Electrical Technician [25%] | 46.25h |  |
| 724 | 6.3.1.1.4.1.15 | Commission RF with Dummy Load |  | 4.62d | 2013-10-25 | 2013-11-01 | 723 | 1157.1d | 0d |  | Electrical Engineer [25%] | 9.25h |  |

| ID | WBS | Task | Type | Duration | Start | Finish | Predecessors | Total slack | Free slack | Constraint | Resources | Work | Cost |
| --- | --- | --- | --- | --- | --- | --- | --- | --- | --- | --- | --- | --- | --- |
| 725 | 6.3.1.1.4.2 | **TH116 Amplifier system #2** |  | 58.27d | 2013-11-01 | 2014-01-22 |  | 1157.1d |  |  |  | 703h | 4,000 |
| 726 | 6.3.1.1.4.2.1 | Design cable management |  | 1.85d | 2013-11-01 | 2013-11-05 | 724 | 1157.1d | 0d |  | Electrical Engineer; Electrical Designer | 29.6h |  |
| 727 | 6.3.1.1.4.2.2 | Install cable management |  | 2.77d | 2013-11-05 | 2013-11-07 | 726 | 1157.1d | 0d |  | Electrical Designer; Electrical Technician | 44.4h | 1,000 |
| 728 | 6.3.1.1.4.2.3 | Design AC distribution |  | 1.85d | 2013-11-07 | 2013-11-11 | 727 | 1157.1d | 0d |  | Electrical Designer; Electrical Engineer | 29.6h |  |
| 729 | 6.3.1.1.4.2.4 | Install AC distribution |  | 4.62d | 2013-11-11 | 2013-11-18 | 728 | 1157.1d | 0d |  | Electrical Technician; Electrical Designer | 74h | 1,000 |
| 730 | 6.3.1.1.4.2.5 | Produce cable schedules - controls interface |  | 9.25d | 2013-11-18 | 2013-11-29 | 729 | 1157.1d | 0d |  | Electrical Designer; Electrical Engineer | 148h |  |
| 731 | 6.3.1.1.4.2.6 | Install controls cables |  | 9.25d | 2013-11-29 | 2013-12-12 | 730 | 1157.1d | 0d |  | Electrical Designer; Electrical Technician | 148h | 1,500 |
| 732 | 6.3.1.1.4.2.7 | System #2 TH116 Racks ready | milestone | 0d | 2013-12-12 | 2013-12-12 | 731 | 1157.1d | 0d | start no earlier than 2011-10-17 |  |  |  |
| 733 | 6.3.1.1.4.2.8 | Install HV Rack |  | 1.85d | 2013-12-12 | 2013-12-16 | 732 | 1157.1d | 0d |  | Electrical Technician | 14.8h |  |
| 734 | 6.3.1.1.4.2.9 | Terminate HV Rack cables |  | 2.77d | 2013-12-16 | 2013-12-19 | 733 | 1157.1d | 0d |  | Electrical Technician | 22.2h |  |
| 735 | 6.3.1.1.4.2.10 | Install Auxiliary Rack |  | 1.85d | 2013-12-19 | 2013-12-23 | 734 | 1157.1d | 0d |  | Electrical Technician | 14.8h |  |
| 736 | 6.3.1.1.4.2.11 | Terminate Auxiliary Rack cables |  | 3.7d | 2013-12-23 | 2013-12-27 | 735 | 1157.1d | 0d |  | Electrical Technician | 29.6h | 500 |
| 737 | 6.3.1.1.4.2.12 | Prepare TH116 Dummy Load |  | 9.25d | 2013-12-27 | 2014-01-09 | 736 | 1157.1d | 0d |  | Electrical Technician; Electrical Engineer [25%] | 92.5h |  |
| 738 | 6.3.1.1.4.2.13 | Commission Electrical system |  | 4.62d | 2014-01-09 | 2014-01-15 | 737 | 1157.1d | 0d |  | Electrical Engineer; Electrical Technician [25%] | 46.25h |  |
| 739 | 6.3.1.1.4.2.14 | Commission RF with Dummy Load |  | 4.62d | 2014-01-15 | 2014-01-22 | 738 | 1157.1d | 0d |  | Electrical Engineer [25%] | 9.25h |  |
| 740 | 6.3.1.1.5 | **RF Waveguide -Systems #1&2** |  | 13.88d | 2014-01-22 | 2014-02-11 | 739 | 1157.1d |  |  | STEP V - TIARA | 222h |  |
| 741 | 6.3.1.1.5.1 | Review waveguide controls interface |  | 9.25d | 2014-01-22 | 2014-02-04 |  | 1157.1d | 0d | start no earlier than 2012-04-30 | Electrical Engineer | 74h |  |
| 742 | 6.3.1.1.5.2 | RF Waveguide Installation complete | milestone | 0d | 2014-02-04 | 2014-02-04 | 741 | 1157.1d | 0d | start no earlier than 2012-06-21 |  |  |  |
| 743 | 6.3.1.1.5.3 | Install Waveguide controls wiring |  | 4.62d | 2014-02-04 | 2014-02-11 | 742 | 1157.1d | 0d |  | Electrical Technician | 37h |  |
| 744 | 6.3.1.1.6 | **RF System #3 - Installation** |  | 116.55d | 2014-02-11 | 2014-07-23 |  | 1157.1d |  |  |  | 1406h | 8,000 |
| 745 | 6.3.1.1.6.1 | **4616 Amplifier system #3** |  | 58.27d | 2014-02-11 | 2014-05-02 | 743 | 1157.1d |  |  |  | 703h | 4,000 |
| 746 | 6.3.1.1.6.1.1 | RF System #3 Integration starts | milestone | 0d | 2014-02-11 | 2014-02-11 |  | 1459.58d |  |  |  |  |  |
| 747 | 6.3.1.1.6.1.2 | Design cable management |  | 1.85d | 2014-02-11 | 2014-02-13 |  | 1157.1d | 0d |  | Electrical Engineer; Electrical Designer | 29.6h |  |
| 748 | 6.3.1.1.6.1.3 | Install cable management |  | 2.77d | 2014-02-13 | 2014-02-18 | 747 | 1157.1d | 0d |  | Electrical Designer; Electrical Technician | 44.4h | 1,000 |
| 749 | 6.3.1.1.6.1.4 | Design AC distribution |  | 1.85d | 2014-02-18 | 2014-02-19 | 748 | 1157.1d | 0d |  | Electrical Designer; Electrical Engineer | 29.6h |  |
| 750 | 6.3.1.1.6.1.5 | Install AC distribution |  | 4.62d | 2014-02-19 | 2014-02-26 | 749 | 1157.1d | 0d |  | Electrical Technician; Electrical Designer | 74h | 1,000 |
| 751 | 6.3.1.1.6.1.6 | Produce cable schedules - controls interface |  | 9.25d | 2014-02-26 | 2014-03-11 | 750 | 1157.1d | 0d |  | Electrical Designer; Electrical Engineer | 148h |  |
| 752 | 6.3.1.1.6.1.7 | Install controls cables |  | 9.25d | 2014-03-11 | 2014-03-25 | 751 | 1157.1d | 0d |  | Electrical Designer; Electrical Technician | 148h | 1,500 |
| 753 | 6.3.1.1.6.1.8 | System #3 4616 Racks ready | milestone | 0d | 2014-03-25 | 2014-03-25 | 752 | 1157.1d | 0d | start no earlier than 2011-01-24 |  |  |  |
| 754 | 6.3.1.1.6.1.9 | Install HV Rack |  | 1.85d | 2014-03-25 | 2014-03-26 | 753 | 1157.1d | 0d |  | Electrical Technician | 14.8h |  |
| 755 | 6.3.1.1.6.1.10 | Terminate HV Rack cables |  | 2.77d | 2014-03-26 | 2014-03-31 | 754 | 1157.1d | 0d |  | Electrical Technician | 22.2h |  |
| 756 | 6.3.1.1.6.1.11 | Install Auxiliary Rack |  | 1.85d | 2014-03-31 | 2014-04-02 | 755 | 1157.1d | 0d |  | Electrical Technician | 14.8h |  |
| 757 | 6.3.1.1.6.1.12 | Terminate Auxiliary Rack cables |  | 3.7d | 2014-04-02 | 2014-04-08 | 756 | 1157.1d | 0d |  | Electrical Technician | 29.6h | 500 |
| 758 | 6.3.1.1.6.1.13 | Prepare 4616 Dummy Load |  | 9.25d | 2014-04-08 | 2014-04-21 | 757 | 1157.1d | 0d |  | Electrical Technician; Electrical Engineer [25%] | 92.5h |  |
| 759 | 6.3.1.1.6.1.14 | Commission Electrical system |  | 4.62d | 2014-04-21 | 2014-04-28 | 758 | 1157.1d | 0d |  | Electrical Engineer; Electrical Technician [25%] | 46.25h |  |
| 760 | 6.3.1.1.6.1.15 | Commission RF with Dummy Load |  | 4.62d | 2014-04-28 | 2014-05-02 | 759 | 1157.1d | 0d |  | Electrical Engineer [25%] | 9.25h |  |

| ID | WBS | Task | Type | Duration | Start | Finish | Predecessors | Total slack | Free slack | Constraint | Resources | Work | Cost |
| --- | --- | --- | --- | --- | --- | --- | --- | --- | --- | --- | --- | --- | --- |
| 761 | 6.3.1.1.6.2 | **TH116 Amplifier system #3** |  | 58.27d | 2014-05-02 | 2014-07-23 |  | 1157.1d |  |  |  | 703h | 4,000 |
| 762 | 6.3.1.1.6.2.1 | Design cable management |  | 1.85d | 2014-05-02 | 2014-05-06 | 760 | 1157.1d | 0d |  | Electrical Engineer; Electrical Designer | 29.6h |  |
| 763 | 6.3.1.1.6.2.2 | Install cable management |  | 2.77d | 2014-05-06 | 2014-05-09 | 762 | 1157.1d | 0d |  | Electrical Designer; Electrical Technician | 44.4h | 1,000 |
| 764 | 6.3.1.1.6.2.3 | Design AC distribution |  | 1.85d | 2014-05-09 | 2014-05-13 | 763 | 1157.1d | 0d |  | Electrical Designer; Electrical Engineer | 29.6h |  |
| 765 | 6.3.1.1.6.2.4 | Install AC distribution |  | 4.62d | 2014-05-13 | 2014-05-19 | 764 | 1157.1d | 0d |  | Electrical Technician; Electrical Designer | 74h | 1,000 |
| 766 | 6.3.1.1.6.2.5 | Produce cable schedules - controls interface |  | 9.25d | 2014-05-19 | 2014-06-02 | 765 | 1157.1d | 0d |  | Electrical Designer; Electrical Engineer | 148h |  |
| 767 | 6.3.1.1.6.2.6 | Install controls cables |  | 9.25d | 2014-06-02 | 2014-06-13 | 766 | 1157.1d | 0d |  | Electrical Designer; Electrical Technician | 148h | 1,500 |
| 768 | 6.3.1.1.6.2.7 | System #3 TH116 Racks ready | milestone | 0d | 2014-06-13 | 2014-06-13 | 767 | 1157.1d | 0d | start no earlier than 2011-10-17 |  |  |  |
| 769 | 6.3.1.1.6.2.8 | Install HV Rack |  | 1.85d | 2014-06-13 | 2014-06-17 | 768 | 1157.1d | 0d |  | Electrical Technician | 14.8h |  |
| 770 | 6.3.1.1.6.2.9 | Terminate HV Rack cables |  | 2.77d | 2014-06-17 | 2014-06-19 | 769 | 1157.1d | 0d |  | Electrical Technician | 22.2h |  |
| 771 | 6.3.1.1.6.2.10 | Install Auxiliary Rack |  | 1.85d | 2014-06-19 | 2014-06-23 | 770 | 1157.1d | 0d |  | Electrical Technician | 14.8h |  |
| 772 | 6.3.1.1.6.2.11 | Terminate Auxiliary Rack cables |  | 3.7d | 2014-06-23 | 2014-06-27 | 771 | 1157.1d | 0d |  | Electrical Technician | 29.6h | 500 |
| 773 | 6.3.1.1.6.2.12 | Prepare TH116 Dummy Load |  | 9.25d | 2014-06-27 | 2014-07-10 | 772 | 1157.1d | 0d |  | Electrical Technician; Electrical Engineer [25%] | 92.5h |  |
| 774 | 6.3.1.1.6.2.13 | Commission Electrical system |  | 4.62d | 2014-07-10 | 2014-07-17 | 773 | 1157.1d | 0d |  | Electrical Engineer; Electrical Technician [25%] | 46.25h |  |
| 775 | 6.3.1.1.6.2.14 | Commission RF with Dummy Load |  | 4.62d | 2014-07-17 | 2014-07-23 | 774 | 1157.1d | 0d |  | Electrical Engineer [25%] | 9.25h |  |
| 776 | 6.3.1.1.7 | **RF System #4 - Installation** |  | 432.9d | 2013-08-13 | 2015-04-09 |  | 1157.1d |  |  |  | 1609.5h | 8,000 |
| 777 | 6.3.1.1.7.1 | **4616 Amplifier system #4** |  | 58.27d | 2014-07-23 | 2014-10-14 |  | 1157.1d |  |  |  | 703h | 4,000 |
| 778 | 6.3.1.1.7.1.1 | RF System #4 Integration starts | milestone | 0d | 2014-07-23 | 2014-07-23 | 775 | 1157.1d | 0d |  |  |  |  |
| 779 | 6.3.1.1.7.1.2 | Design cable management |  | 1.85d | 2014-07-23 | 2014-07-25 | 778 | 1157.1d | 0d |  | Electrical Engineer; Electrical Designer | 29.6h |  |
| 780 | 6.3.1.1.7.1.3 | Install cable management |  | 2.77d | 2014-07-25 | 2014-07-30 | 779 | 1157.1d | 0d |  | Electrical Designer; Electrical Technician | 44.4h | 1,000 |
| 781 | 6.3.1.1.7.1.4 | Design AC distribution |  | 1.85d | 2014-07-30 | 2014-08-01 | 780 | 1157.1d | 0d |  | Electrical Designer; Electrical Engineer | 29.6h |  |
| 782 | 6.3.1.1.7.1.5 | Install AC distribution |  | 4.62d | 2014-08-01 | 2014-08-08 | 781 | 1157.1d | 0d |  | Electrical Technician; Electrical Designer | 74h | 1,000 |
| 783 | 6.3.1.1.7.1.6 | Produce cable schedules - controls interface |  | 9.25d | 2014-08-08 | 2014-08-21 | 782 | 1157.1d | 0d |  | Electrical Designer; Electrical Engineer | 148h |  |
| 784 | 6.3.1.1.7.1.7 | Install controls cables |  | 9.25d | 2014-08-21 | 2014-09-03 | 783 | 1157.1d | 0d |  | Electrical Designer; Electrical Technician | 148h | 1,500 |
| 785 | 6.3.1.1.7.1.8 | System #4 4616 Racks ready | milestone | 0d | 2014-09-03 | 2014-09-03 | 784 | 1157.1d | 0d | start no earlier than 2011-01-24 |  |  |  |
| 786 | 6.3.1.1.7.1.9 | Install HV Rack |  | 1.85d | 2014-09-03 | 2014-09-05 | 785 | 1157.1d | 0d |  | Electrical Technician | 14.8h |  |
| 787 | 6.3.1.1.7.1.10 | Terminate HV Rack cables |  | 2.77d | 2014-09-05 | 2014-09-10 | 786 | 1157.1d | 0d |  | Electrical Technician | 22.2h |  |
| 788 | 6.3.1.1.7.1.11 | Install Auxiliary Rack |  | 1.85d | 2014-09-10 | 2014-09-12 | 787 | 1157.1d | 0d |  | Electrical Technician | 14.8h |  |
| 789 | 6.3.1.1.7.1.12 | Terminate Auxiliary Rack cables |  | 3.7d | 2014-09-12 | 2014-09-17 | 788 | 1157.1d | 0d |  | Electrical Technician | 29.6h | 500 |
| 790 | 6.3.1.1.7.1.13 | Prepare 4616 Dummy Load |  | 9.25d | 2014-09-17 | 2014-09-30 | 789 | 1157.1d | 0d |  | Electrical Technician; Electrical Engineer [25%] | 92.5h |  |
| 791 | 6.3.1.1.7.1.14 | Commission Electrical system |  | 4.62d | 2014-10-01 | 2014-10-07 | 790 | 1157.1d | 0d |  | Electrical Engineer; Electrical Technician [25%] | 46.25h |  |
| 792 | 6.3.1.1.7.1.15 | Commission RF with Dummy Load |  | 4.62d | 2014-10-07 | 2014-10-14 | 791 | 1157.1d | 0d |  | Electrical Engineer [25%] | 9.25h |  |

| ID | WBS | Task | Type | Duration | Start | Finish | Predecessors | Total slack | Free slack | Constraint | Resources | Work | Cost |
| --- | --- | --- | --- | --- | --- | --- | --- | --- | --- | --- | --- | --- | --- |
| 793 | 6.3.1.1.7.2 | **TH116 Amplifier system #4** |  | 363.52d | 2013-08-13 | 2015-01-02 |  | 1226.47d |  |  |  | 703h | 4,000 |
| 794 | 6.3.1.1.7.2.1 | Design cable management |  | 1.85d | 2014-10-14 | 2014-10-16 | 792 | 1157.1d | 0d |  | Electrical Engineer; Electrical Designer | 29.6h |  |
| 795 | 6.3.1.1.7.2.2 | Install cable management |  | 2.77d | 2014-10-16 | 2014-10-20 | 794 | 1157.1d | 0d |  | Electrical Designer; Electrical Technician | 44.4h | 1,000 |
| 796 | 6.3.1.1.7.2.3 | Design AC distribution |  | 1.85d | 2014-10-20 | 2014-10-22 | 795 | 1157.1d | 0d |  | Electrical Designer; Electrical Engineer | 29.6h |  |
| 797 | 6.3.1.1.7.2.4 | Install AC distribution |  | 4.62d | 2014-10-22 | 2014-10-29 | 796 | 1157.1d | 0d |  | Electrical Technician; Electrical Designer | 74h | 1,000 |
| 798 | 6.3.1.1.7.2.5 | Produce cable schedules - controls interface |  | 9.25d | 2014-10-29 | 2014-11-11 | 797 | 1157.1d | 0d |  | Electrical Designer; Electrical Engineer | 148h |  |
| 799 | 6.3.1.1.7.2.6 | Install controls cables |  | 9.25d | 2014-11-11 | 2014-11-24 | 798 | 1157.1d | 0d |  | Electrical Designer; Electrical Technician | 148h | 1,500 |
| 800 | 6.3.1.1.7.2.7 | System #4 TH116 Racks ready | milestone | 0d | 2014-11-24 | 2014-11-24 | 799 | 1157.1d | 0d | start no earlier than 2011-10-17 |  |  |  |
| 801 | 6.3.1.1.7.2.8 | Install HV Rack |  | 1.85d | 2014-11-24 | 2014-11-26 | 800 | 1157.1d | 0d |  | Electrical Technician | 14.8h |  |
| 802 | 6.3.1.1.7.2.9 | Terminate HV Rack cables |  | 2.77d | 2014-11-26 | 2014-12-01 | 801 | 1157.1d | 0d |  | Electrical Technician | 22.2h |  |
| 803 | 6.3.1.1.7.2.10 | Install Auxiliary Rack |  | 1.85d | 2014-12-01 | 2014-12-03 | 802 | 1157.1d | 0d |  | Electrical Technician | 14.8h |  |
| 804 | 6.3.1.1.7.2.11 | Terminate Auxiliary Rack cables |  | 3.7d | 2014-12-03 | 2014-12-09 | 803 | 1157.1d | 0d |  | Electrical Technician | 29.6h | 500 |
| 805 | 6.3.1.1.7.2.12 | Prepare TH116 Dummy Load |  | 9.25d | 2013-08-13 | 2013-08-26 | 707 | 1580.75d |  |  | Electrical Technician; Electrical Engineer [25%] | 92.5h |  |
| 806 | 6.3.1.1.7.2.13 | Commission Electrical system |  | 4.62d | 2014-12-22 | 2014-12-26 | 816 | 1157.1d | 0d |  | Electrical Engineer; Electrical Technician [25%] | 46.25h |  |
| 807 | 6.3.1.1.7.2.14 | Commission RF with Dummy Load |  | 4.62d | 2014-12-26 | 2015-01-02 | 806 | 1157.1d | 0d |  | Electrical Engineer [25%] | 9.25h |  |
| 808 | 6.3.1.1.7.3 | **RF Waveguide -Systems #3&4** |  | 13.88d | 2015-01-02 | 2015-01-22 | 807 | 1157.1d |  |  |  | 111h |  |
| 809 | 6.3.1.1.7.3.1 | Review waveguide controls interface |  | 9.25d | 2015-01-02 | 2015-01-15 |  | 1157.1d | 0d | start no earlier than 2012-06-25 | Electrical Engineer | 74h |  |
| 810 | 6.3.1.1.7.3.2 | RF Waveguide Installation complete | milestone | 0d | 2015-01-15 | 2015-01-15 | 809 | 1157.1d | 0d | finish no earlier than 2012-08-06 |  |  |  |
| 811 | 6.3.1.1.7.3.3 | Install Waveguide controls wiring |  | 4.62d | 2015-01-15 | 2015-01-22 | 810 | 1157.1d | 0d |  | Electrical Technician | 37h |  |
| 812 | 6.3.1.1.7.4 | **RF Cavity Commissioning** |  | 87.88d | 2014-12-09 | 2015-04-09 |  | 1157.1d |  |  |  | 92.5h |  |
| 813 | 6.3.1.1.7.4.1 | Cavity Delivered | milestone | 0d | 2015-01-22 | 2015-01-22 | 811 | 1157.1d | 0d |  |  |  |  |
| 814 | 6.3.1.1.7.4.2 | Install and prepare cavity for tests |  | 18.5d | 2015-01-22 | 2015-02-17 | 813 | 1157.1d | 0d |  |  |  |  |
| 815 | 6.3.1.1.7.4.3 | Commission RF system into Cavity |  | 37d | 2015-02-17 | 2015-04-09 | 814 | 1157.1d |  |  |  |  |  |
| 816 | 6.3.1.1.7.4.4 | Prepare TH116 Dummy Load |  | 9.25d | 2014-12-09 | 2014-12-22 | 804 | 1157.1d | 0d |  | Electrical Technician; Electrical Engineer [25%] | 92.5h |  |

| ID | WBS | Task | Type | Duration | Start | Finish | Predecessors | Complete | Total slack | Free slack | Constraint | Resources | Work |
| --- | --- | --- | --- | --- | --- | --- | --- | --- | --- | --- | --- | --- | --- |
| 817 | 6.3.1.2 | **RF Hall Mechanical Infrastructure** |  | 15d | 2011-03-01 A | 2011-03-21 A |  | 100% |  |  |  |  |  |
| 818 | 6.3.1.2.1 | Install mezzanine/supports/floor plates |  | 15d | 2011-03-01 A | 2011-03-21 A |  | 100% |  |  | start no earlier than 2011-03-01 |  |  |
| 819 | 6.3.2 | **Amplifiers** |  | 446d | 2013-03-05 | 2014-11-18 |  |  | 1222d |  |  |  | 160h |
| 820 | 6.3.2.1 | **System #1** |  | 10d | 2013-03-05 | 2013-03-18 |  |  | 1658d |  |  | STEP V - TIARA | 80h |
| 821 | 6.3.2.1.1 | Install amplfiier in position on platform |  | 10d | 2013-03-05 | 2013-03-18 | 818, 100 |  | 1658d | 0d | start no earlier than 2012-07-03 |  |  |
| 822 | 6.3.2.1.2 | Amplfier#1 installation complete | milestone | 0d | 2013-03-18 | 2013-03-18 | 821 |  | 1658d | 0d |  |  |  |
| 823 | 6.3.2.2 | **System #2** |  | 10d | 2013-10-03 | 2013-10-16 |  |  | 1506d |  |  | STEP V - TIARA | 80h |
| 824 | 6.3.2.2.1 | Install amplfiier in position on platform |  | 10d | 2013-10-03 | 2013-10-16 | 103 |  | 1506d | 0d |  |  |  |
| 825 | 6.3.2.2.2 | Amplfier#2 installation complete | milestone | 0d | 2013-10-16 | 2013-10-16 | 824 |  | 1506d | 0d |  |  |  |
| 826 | 6.3.2.3 | **System #3** |  | 10d | 2014-05-07 | 2014-05-20 |  |  | 1352d |  |  |  |  |
| 827 | 6.3.2.3.1 | Install amplfiier in position on platform |  | 10d | 2014-05-07 | 2014-05-20 | 106 |  | 1352d | 0d |  |  |  |
| 828 | 6.3.2.3.2 | Amplfier#3 installation complete | milestone | 0d | 2014-05-20 | 2014-05-20 | 827 |  | 1352d | 0d |  |  |  |
| 829 | 6.3.2.4 | **System #4** |  | 10d | 2014-11-05 | 2014-11-18 |  |  | 1222d |  |  |  |  |
| 830 | 6.3.2.4.1 | Install amplfiier in position on platform |  | 10d | 2014-11-05 | 2014-11-18 | 109 |  | 1222d | 0d |  |  |  |
| 831 | 6.3.2.4.2 | Amplfier#4 installation complete | milestone | 0d | 2014-11-18 | 2014-11-18 | 830 |  | 1222d | 0d |  |  |  |
| 832 | 6.3.3 | **Waveguides** |  | 1115d | 2013-01-17 | 2017-04-26 |  |  | 623d |  |  |  | 8920h |
| 833 | 6.3.3.1 | **System#1** |  | 1115d | 2013-01-17 | 2017-04-26 |  |  | 623d |  |  | STEP V - TIARA | 8920h |
| 834 | 6.3.3.1.1 | Install waveguides |  | 5d | 2013-01-17 | 2013-01-23 | 113 |  | 1728d | 0d |  |  |  |
| 835 | 6.3.3.1.2 | install dummy loads |  | 5d | 2013-01-24 | 2013-01-30 | 834 |  | 1728d |  |  |  |  |
| 836 | 6.3.3.1.3 | couple up to cavity |  | 2d | 2017-04-25 | 2017-04-26 | 1030 |  | 623d |  |  |  |  |
| 837 | 6.3.3.2 | **System#2** |  | 1115d | 2013-01-17 | 2017-04-26 |  |  | 623d |  |  |  |  |
| 838 | 6.3.3.2.1 | Install all waveguides |  | 5d | 2013-01-17 | 2013-01-23 | 116 |  | 1728d | 0d |  |  |  |
| 839 | 6.3.3.2.2 | install dummy loads |  | 5d | 2013-01-24 | 2013-01-30 | 838 |  | 1728d |  |  |  |  |
| 840 | 6.3.3.2.3 | couple up to cavity |  | 2d | 2017-04-25 | 2017-04-26 | 1030 |  | 623d |  |  |  |  |

| ID | WBS | Task | Type | Duration | Start | Finish | Predecessors | Complete | Remaining | Baseline start | Baseline finish | Baseline duration | Total slack | Constraint | Resources | Work | Actual work | Cost | Actual cost |
| --- | --- | --- | --- | --- | --- | --- | --- | --- | --- | --- | --- | --- | --- | --- | --- | --- | --- | --- | --- |
| 841 | 6.4 | **MICE Step IV Installation** |  | 1503d | 2008-09-01 A | 2014-06-04 |  | 32% | 1029.52d |  |  |  | 1378d |  | Step IV | 11898.9h | 1476.19h | 27,500 | 27,500 |
| 842 | 6.4.1 | **Step IV Base plate installation** |  | 232d | 2011-01-17 A | 2011-12-06 A |  | 100% |  |  |  |  |  |  |  |  |  | 27,500 | 27,500 |
| 843 | 6.4.1.1 | Update MICE hall CAD model with new floor configuration |  | 40d | 2011-01-17 A | 2011-03-11 A |  | 100% |  |  |  |  |  | start no earlier than 2011-01-17 |  |  |  |  |  |
| 844 | 6.4.1.2 | Manufacture Al intermediate plates for the false floor |  | 15d | 2011-03-14 A | 2011-04-01 A | 843 | 100% |  |  |  |  |  | start no earlier than 2011-02-21 |  |  |  | 6,000 | 6,000 |
| 845 | 6.4.1.3 | Manufacture new floor beam design (2 off) |  | 30d | 2011-08-22 A | 2011-09-30 A | 844 | 100% |  |  |  |  |  | start no earlier than 2011-08-22 |  |  |  |  |  |
| 846 | 6.4.1.4 | Modify spectrometer #2 base plate for levelling |  | 20d | 2011-10-03 A | 2011-10-28 A | 845 | 100% |  |  |  |  |  | start no earlier than 2011-10-03 |  |  |  |  |  |
| 847 | 6.4.1.5 | Fit intermediate surface (tiled Aluminium plates) for the false floor step IV position |  | 3d | 2011-09-26 A | 2011-09-28 A |  | 100% |  |  |  |  |  | start no earlier than 2011-09-26 |  |  |  |  |  |
| 848 | 6.4.1.6 | Remove existing shear plate |  | 1d | 2011-09-01 A | 2011-09-01 A |  | 100% |  |  |  |  |  | start no earlier than 2011-09-01 |  |  |  |  |  |
| 849 | 6.4.1.7 | Seal checker plate floor over the trench |  | 3d | 2011-09-02 A | 2011-09-06 A | 848 | 100% |  |  |  |  |  | start no earlier than 2011-09-01 |  |  |  |  |  |
| 850 | 6.4.1.8 | Carry out any remedial work to existing concrete floor |  | 3d | 2011-09-07 A | 2011-09-09 A | 849 | 100% |  |  |  |  |  |  |  |  |  |  |  |
| 851 | 6.4.1.9 | Survey and marking out |  | 2d | 2011-09-12 A | 2011-09-13 A | 850 | 100% |  |  |  |  |  |  |  |  |  |  |  |
| 852 | 6.4.1.10 | Trial AFC base plate Installation including survey and marking out (on and off line) |  | 5d | 2011-09-14 A | 2011-09-20 A | 851 | 100% |  |  |  |  |  | start no earlier than 2011-01-20 |  |  |  | 2,500 | 2,500 |
| 853 | 6.4.1.11 | Carry out anchor hole drilling in the concrete for the AFC |  | 5d | 2011-09-21 A | 2011-09-27 A | 852 | 100% |  |  |  |  |  |  |  |  |  | 3,000 | 3,000 |
| 854 | 6.4.1.12 | Replace AFC base plate anchor and grout (on and off line?) |  | 10d | 2011-09-28 A | 2011-10-11 A | 853 | 100% |  |  |  |  |  | start no earlier than 2011-02-09 |  |  |  | 6,000 | 6,000 |
| 855 | 6.4.1.13 | Carry out anchor hole drilling for second floor beam |  | 5d | 2011-10-12 A | 2011-10-18 A | 854 | 100% |  |  |  |  |  |  |  |  |  |  |  |
| 856 | 6.4.1.14 | AFC base plate installation complete | milestone | 0d | 2011-10-18 A | 2011-10-18 A | 855 | 100% |  |  |  |  |  |  |  |  |  |  |  |
| 857 | 6.4.1.15 | Trial spectrometer #2 base plate Installation including survey and marking out (on and off line) |  | 10d | 2011-10-19 A | 2011-11-01 A | 856 | 100% |  |  |  |  |  | start no earlier than 2011-02-09 |  |  |  | 3,000 | 3,000 |
| 858 | 6.4.1.16 | Anchor hole drilling in concrete floor and false floor plates (on and off line) |  | 10d | 2011-11-02 A | 2011-11-15 A | 857 | 100% |  |  |  |  |  | start no earlier than 2011-02-09 |  |  |  | 4,000 | 4,000 |
| 859 | 6.4.1.17 | Create level surface with washers at bolt locations (survey level) |  | 10d | 2011-11-16 A | 2011-11-29 A | 858 | 100% |  |  |  |  |  | start no earlier than 2011-02-09 |  |  |  | 2,000 | 2,000 |
| 860 | 6.4.1.18 | Re-Install spectrometer #2 base plate |  | 2d | 2011-11-30 A | 2011-12-01 A | 859 | 100% |  |  |  |  |  | start no earlier than 2011-02-09 |  |  |  |  |  |
| 861 | 6.4.1.19 | Install through bolts and survey, level and tighten the complete arrangement |  | 3d | 2011-12-02 A | 2011-12-06 A | 860 | 100% |  |  |  |  |  | start no earlier than 2011-02-09 |  |  |  | 1,000 | 1,000 |
| 862 | 6.4.1.20 | Down stream Spectrometer Solenoid installation plate complete | milestone | 0d | 2011-12-06 A | 2011-12-06 A | 861 | 100% |  |  |  |  |  |  |  |  |  |  |  |
| 863 | 6.4.2 | **AFC #1 Rail System Installation** |  | 5d | 2012-01-16 A | 2012-01-20 A |  | 100% |  | 2009-12-01 | 2011-03-31 | 348d? |  |  |  |  |  |  |  |
| 864 | 6.4.2.1 | Remove grouted intermediate floor plate (500mm plate inbetween the two spectrometers) |  | 1d | 2012-01-16 A | 2012-01-16 A | 861 | 100% |  |  |  |  |  | start no earlier than 2012-01-16 |  |  |  |  |  |
| 865 | 6.4.2.2 | Install AFC #1 rail system |  | 2d | 2012-01-17 A | 2012-01-18 A | 864 | 100% |  |  |  |  |  |  |  |  |  |  |  |
| 866 | 6.4.2.3 | Install AFC #1 supports to floor |  | 2d | 2012-01-19 A | 2012-01-20 A | 865 | 100% |  | 2010-02-22 | 2010-02-26 | 5d |  | finish no earlier than 2010-02-26 |  |  |  |  |  |
| 867 | 6.4.2.4 | AFC#1 rail system installation complete | milestone | 0d | 2012-01-20 A | 2012-01-20 A | 866 | 100% |  | 2010-04-09 | 2010-04-12 | 2d |  | start no earlier than 2010-03-01 |  |  |  |  |  |

| ID | WBS | Task | Type | Duration | Start | Finish | Predecessors | Complete | Total slack | Free slack | Constraint | Calendar | Resources | Work |
| --- | --- | --- | --- | --- | --- | --- | --- | --- | --- | --- | --- | --- | --- | --- |
| 868 | 6.4.3 | **Spectrometer Solenoid Rail System Installation** |  | 1010d | 2008-09-01 A | 2012-07-13 A |  | 100% |  |  |  |  |  |  |
| 869 | 6.4.3.1 | Disconnect all services to KL & TOF 02 |  | 2d | 2012-01-23 A | 2012-01-24 A | 867 | 100% |  |  |  |  |  |  |
| 870 | 6.4.3.2 | Remove KL & TOF 02 from stepII position & store |  | 2d | 2012-01-25 A | 2012-01-26 A | 869 | 100% |  |  |  |  |  |  |
| 871 | 6.4.3.3 | Install SS#1 rolling platform |  | 2d | 2008-09-01 A | 2008-09-02 A |  | 100% |  |  |  |  |  |  |
| 872 | 6.4.3.4 | Install SS#2 rolling platform |  | 2d | 2012-02-06 A | 2012-02-07 A | 871 | 100% |  |  |  |  |  |  |
| 873 | 6.4.3.5 | Spectrometer Solenoid rolling platform installation complete | milestone | 0d | 2012-02-07 A | 2012-02-07 A | 872 | 100% |  |  |  |  |  |  |
| 874 | 6.4.3.6 | Install Solenoid support frames 2 off |  | 5d | 2012-07-09 A | 2012-07-13 A |  | 100% |  |  | start no earlier than 2012-07-09 |  |  |  |
| 875 | 6.4.4 | **EMR** |  | 25d | 2013-03-29 | 2013-05-02 |  |  | 147d |  |  |  | EMR | 280h |
| 876 | 6.4.4.1 | Install EMR in step IV position |  | 2w | 2013-03-29 | 2013-04-11 | 147, 870 |  | 147d | 0d |  |  |  |  |
| 877 | 6.4.4.2 | EMR installed in step IV position | milestone | 0d | 2013-04-11 | 2013-04-11 | 876 |  | 147d | 0d |  |  |  |  |
| 878 | 6.4.4.3 | EMR final test |  | 10d | 2013-04-12 | 2013-04-25 | 877 |  | 147d | 0d | start no earlier than 2012-11-20 | ISIS Run Cycle | ISIS Run Cycle | 80h |
| 879 | 6.4.4.4 | EMR final tests complete | milestone | 0d | 2013-04-25 | 2013-04-25 | 878 |  | 147d | 0d |  | ISIS Run Cycle |  |  |
| 880 | 6.4.4.5 | Remove EMR for mag field tests SS's & AFC |  | 5d | 2013-04-26 | 2013-05-02 | 879 |  | 147d | 0d |  |  |  |  |
| 881 | 6.4.5 | **AFC - Focus coil for step IV** |  | 322.37d | 2013-01-17 | 2014-04-14 |  |  | 190.37d |  |  |  | Focus Coils | 2578.93h |
| 882 | 6.4.5.1 | **AFC#1 Installation** |  | 27d | 2013-01-17 | 2013-02-25 |  |  | 190.37d |  |  |  |  |  |
| 883 | 6.4.5.1.1 | Installation, survey & alignment of AFC#1 |  | 10d | 2013-01-17 | 2013-01-31 | 182 |  | 190.37d | 0d | start no earlier than 2011-07-01 |  |  |  |
| 884 | 6.4.5.1.2 | Connection of services |  | 10d | 2013-01-31 | 2013-02-14 | 883 |  | 190.37d | 0d |  |  |  |  |
| 885 | 6.4.5.1.3 | Cool down |  | 5d | 2013-02-14 | 2013-02-21 | 884 |  | 190.37d | 0d |  |  |  |  |
| 886 | 6.4.5.1.4 | Ramp up current |  | 2d | 2013-02-21 | 2013-02-25 | 885 |  | 190.37d | 0d |  |  |  |  |
| 887 | 6.4.5.2 | **Field Mapping at full field** |  | 53.37d | 2013-02-25 | 2013-05-09 | 886 |  | 147d | 0d |  |  |  |  |
| 888 | 6.4.5.2.1 | Set-up |  | 5d | 2013-02-25 | 2013-03-04 |  |  | 190.37d | 43.37d |  |  |  |  |
| 889 | 6.4.5.2.2 | Clean up area of magnetic components |  | 2d | 2013-02-25 | 2013-02-27 | 886 |  | 193.37d | 46.37d |  |  |  |  |
| 890 | 6.4.5.2.3 | Mapping |  | 5d | 2013-05-03 | 2013-05-09 | 889, 888, 880 |  | 147d | 0d |  |  |  |  |
| 891 | 6.4.5.3 | AFC #1 moved to parked position |  | 2d | 2013-05-10 | 2013-05-13 | 890 |  | 147d | 0d |  |  |  |  |

Notes:
- 869: Need to agree that EMR final test run can be in step IV position without solenoids or AFC module
- 881: Testing now proposed in R9 and then final testing in MICE hall

| ID | WBS | Task | Duration | Start | Finish | Predecessors | Total slack | Free slack |
| --- | --- | --- | --- | --- | --- | --- | --- | --- |
| 892 | 6.4.5.4 | **Absorber integration** | 18d | 2013-05-14 | 2013-06-06 | 890, 1086 | 1628d |  |
| 893 | 6.4.5.4.1 | Fit absorber | 5d | 2013-05-14 | 2013-05-20 | 890 | 1650d |  |
| 894 | 6.4.5.4.2 | Integrate with Transfer line | 10d | 2013-05-14 | 2013-05-27 | 890 | 1628d | 0d |
| 895 | 6.4.5.4.3 | Leak check and pump | 5d | 2013-05-28 | 2013-06-03 | 894 | 1628d | 0d |
| 896 | 6.4.5.4.4 | Instrumentation check | 3d | 2013-06-04 | 2013-06-06 | 895 | 1628d | 0d |
| 897 | 6.4.5.5 | **Safety windows** | 5d | 2013-06-07 | 2013-06-13 | 896 | 1628d |  |
| 898 | 6.4.5.5.1 | Installation | 2d | 2013-06-07 | 2013-06-10 |  | 1628d | 0d |
| 899 | 6.4.5.5.2 | Leak check | 3d | 2013-06-11 | 2013-06-13 | 898 | 1628d | 0d |
| 900 | 6.4.5.6 | **Cover plate installation** | 4d | 2013-06-14 | 2013-06-19 | 899 | 1628d |  |
| 901 | 6.4.5.6.1 | Install | 1d | 2013-06-14 | 2013-06-14 |  | 1628d | 0d |
| 902 | 6.4.5.6.2 | Pump down and leak check | 3d | 2013-06-17 | 2013-06-19 | 901 | 1628d |  |
| 903 | 6.4.5.7 | Reposition AFC#1 in step IV position | 2d | 2014-02-12 | 2014-02-13 | 962 | 1378d | 0d |
| 904 | 6.4.5.8 | **Preliminary cool-down** | 19d | 2014-02-14 | 2014-03-12 | 903 | 1378d | 0d |
| 905 | 6.4.5.8.1 | Base temperature test | 10d | 2014-02-14 | 2014-02-27 |  | 1378d | 0d |
| 906 | 6.4.5.8.2 | Helium condensation | 3d | 2014-02-28 | 2014-03-04 | 905 | 1378d | 0d |
| 907 | 6.4.5.8.3 | Cooling power at 20K | 2d | 2014-03-05 | 2014-03-06 | 906 | 1378d | 0d |
| 908 | 6.4.5.8.4 | Warm-up H2 system | 4d | 2014-03-07 | 2014-03-12 | 907 | 1378d |  |
| 909 | 6.4.5.9 | **Hydrogen System test** | 23d | 2014-03-13 | 2014-04-14 | 904, 1095 | 1378d |  |
| 910 | 6.4.5.9.1 | Cool down | 3d | 2014-03-13 | 2014-03-17 |  | 1378d | 0d |
| 911 | 6.4.5.9.2 | Part fill with hydrogen | 3d | 2014-03-18 | 2014-03-20 | 910 | 1378d | 0d |
| 912 | 6.4.5.9.3 | Warm-up H2 system | 2d | 2014-03-21 | 2014-03-24 | 911 | 1378d | 0d |
| 913 | 6.4.5.9.4 | Purge | 1d | 2014-03-25 | 2014-03-25 | 912 | 1378d | 0d |
| 914 | 6.4.5.9.5 | Cool & Fill with hydrogen | 8d | 2014-03-26 | 2014-04-04 | 913 | 1378d | 0d |
| 915 | 6.4.5.9.6 | Hold for two days | 2d | 2014-04-07 | 2014-04-08 | 914 | 1378d | 0d |
| 916 | 6.4.5.9.7 | Ramp up field and hold | 1d | 2014-04-09 | 2014-04-09 | 915 | 1378d | 0d |
| 917 | 6.4.5.9.8 | Warm-up H2 system | 2d | 2014-04-10 | 2014-04-11 | 916 | 1378d | 0d |
| 918 | 6.4.5.9.9 | purge | 1d | 2014-04-14 | 2014-04-14 | 917 | 1378d | 0d |

Notes:
- 904: These tasks maybe done after the solenoid and tracker #1 have been installed to avoid slipping the schedule for installing solenoid and tracker. Needs to be confirmed.
- 909: These tasks maybe done after the solenoid and tracker #1 have been installed to avoid slipping the schedule for installing solenoid and tracker. Needs to be confirmed.

| ID | WBS | Task | Type | Duration | Start | Finish | Predecessors | Baseline start | Baseline finish | Baseline duration | Total slack | Free slack | Constraint | Resources | Work |
| --- | --- | --- | --- | --- | --- | --- | --- | --- | --- | --- | --- | --- | --- | --- | --- |
| 919 | 6.4.6 | **Spectrometer Solenoid - Upstream** |  | 79d | 2013-08-26 | 2013-12-12 |  |  |  |  | 17d |  |  | Spectrometer | 712h |
| 920 | 6.4.6.1 | Upstream Spectrometer Solenoid & Virostek plate Installation |  | 20d | 2013-09-09 | 2013-10-04 | 121FS+10d, 235, 231 |  |  |  | 7d | 0d | start no earlier than 2012-01-16 |  |  |
| 921 | 6.4.6.2 | Clean up area of magnetic components |  | 2d | 2013-08-26 | 2013-08-27 | 920SS-10d |  |  |  | 1579d |  | start no earlier than 2013-01-01 |  |  |
| 922 | 6.4.6.3 | Vacuum pump down |  | 10d | 2013-10-07 | 2013-10-18 | 920 |  |  |  | 1541d |  |  |  |  |
| 923 | 6.4.6.4 | Cool down spectrometer |  | 6d | 2013-10-07 | 2013-10-14 | 920 |  |  |  | 7d | 0d |  |  |  |
| 924 | 6.4.6.5 | magnetic field set up (5wks training) |  | 5w | 2013-10-15 | 2013-11-18 | 923 |  |  |  | 7d | 0d |  |  |  |
| 925 | 6.4.6.6 | magnet field mapping |  | 5d | 2013-11-19 | 2013-11-25 | 924 |  |  |  | 7d | 0d |  |  |  |
| 926 | 6.4.6.7 | Install diffuser |  | 10d | 2013-11-26 | 2013-12-09 | 925 |  |  |  | 1502d | 0d |  | Diffuser | 80h |
| 927 | 6.4.6.8 | Move Upstream Spectrometer to parked position |  | 3d | 2013-12-10 | 2013-12-12 | 926 |  |  |  | 1502d | 0d |  |  |  |
| 928 | 6.4.7 | **Tracker Installation - Upstream** |  | 49d | 2013-11-26 | 2014-01-31 | 925 |  |  |  | 1463d |  |  | Tracker | 392h |
| 929 | 6.4.7.1 | Clear area for tracker installation |  | 1d | 2013-11-26 | 2013-11-26 |  | 2009-08-11 | 2009-08-13 | 3d? | 1463d | 0d | start no earlier than 2009-05-25 |  |  |
| 930 | 6.4.7.2 | Move Spectrometer Solenoid into parked position |  | 1d | 2013-11-27 | 2013-11-27 | 929 |  |  |  | 1463d | 0d |  |  |  |
| 931 | 6.4.7.3 | Fit and seal patch panel to the solenoid front plate |  | 1d | 2013-11-28 | 2013-11-28 | 930 | 2009-08-14 | 2009-08-17 | 2d | 1463d | 0d |  |  |  |
| 932 | 6.4.7.4 | Survey the bore of the solenoid using the tracker alignment tools |  | 2d | 2013-11-29 | 2013-12-02 | 931 | 2009-08-18 | 2009-08-24 | 5d? | 1463d | 0d | start no earlier than 2009-05-25 |  |  |
| 933 | 6.4.7.5 | Fit the far hall probes collar into the bore |  | 1d | 2013-12-03 | 2013-12-03 | 932 | 2009-08-25 | 2009-08-31 | 5d? | 1463d | 0d | start no earlier than 2009-06-01 |  |  |
| 934 | 6.4.7.6 | Fit the helium window |  | 1d | 2013-12-04 | 2013-12-04 | 933 | 2009-09-01 | 2009-09-01 | 1d? | 1463d | 0d |  |  |  |
| 935 | 6.4.7.7 | Connect the tracker volume helium supply |  | 1d | 2013-12-05 | 2013-12-05 | 934 | 2009-09-02 | 2009-09-08 | 5d | 1463d | 0d |  |  |  |
| 936 | 6.4.7.8 | Erect blockout tent |  | 1d | 2013-12-06 | 2013-12-06 | 935 | 2009-09-09 | 2009-09-10 | 2d | 1463d | 0d |  |  |  |
| 937 | 6.4.7.9 | Fit yellow lighting inside the tent |  | 1d | 2013-12-09 | 2013-12-09 | 936 | 2009-09-11 | 2009-09-16 | 4d? | 1463d | 0d | start no earlier than 2009-06-09 |  |  |
| 938 | 6.4.7.10 | install the tracker installation platform inside the tent |  | 1d | 2013-12-10 | 2013-12-10 | 937 |  |  |  | 1463d | 0d |  |  |  |
| 939 | 6.4.7.11 | Install the tracker replacing any faulty internal waveguides |  | 5d | 2013-12-11 | 2013-12-17 | 938 |  |  |  | 1463d | 0d |  |  |  |
| 940 | 6.4.7.12 | Fit and seal the patch panel cover plus crown for diffuser |  | 1d | 2013-12-18 | 2013-12-18 | 939 |  |  |  | 1463d | 0d |  |  |  |
| 941 | 6.4.7.13 | Remove the blackout tent |  | 1d | 2013-12-19 | 2013-12-19 | 940 |  |  |  | 1463d | 0d |  |  |  |
| 942 | 6.4.7.14 | Position and fit the VLPC and Cryo-coolers onto the rolling platform |  | 5d | 2013-12-20 | 2013-12-26 | 941 |  |  |  | 1463d | 0d |  |  |  |
| 943 | 6.4.7.15 | Position and fit the services required fir the Cryo-coolers |  | 5d | 2013-12-27 | 2014-01-02 | 942 |  |  |  | 1463d | 0d |  |  |  |
| 944 | 6.4.7.16 | Errect the trellis to support the external waveguides |  | 3d | 2014-01-03 | 2014-01-07 | 943 |  |  |  | 1463d | 0d |  |  |  |
| 945 | 6.4.7.17 | Fit the external waveguides |  | 2d | 2014-01-08 | 2014-01-09 | 944 |  |  |  | 1463d | 0d |  |  |  |
| 946 | 6.4.7.18 | Set up micetkpc1 (server PC for AFEllts & cryo system) |  | 2d | 2014-01-10 | 2014-01-13 | 945 |  |  |  | 1463d | 0d |  |  |  |
| 947 | 6.4.7.19 | AFEllt trigger distribution |  | 3d | 2014-01-14 | 2014-01-16 | 946 |  |  |  | 1463d | 0d |  |  |  |
| 948 | 6.4.7.20 | Prepare 3 phase & chilled water for compressors (cold head) |  | 1d | 2014-01-17 | 2014-01-17 | 947 |  |  |  | 1463d | 0d |  |  |  |
| 949 | 6.4.7.21 | Install compressors |  | 2d | 2014-01-20 | 2014-01-21 | 948 |  |  |  | 1463d | 0d |  |  |  |
| 950 | 6.4.7.22 | Install cryo insulating vacuum pump sets |  | 1d | 2014-01-22 | 2014-01-22 | 949 |  |  |  | 1463d | 0d |  |  |  |
| 951 | 6.4.7.23 | Move and position tracker rack |  | 1d | 2014-01-23 | 2014-01-23 | 950 |  |  |  | 1463d | 0d |  |  |  |
| 952 | 6.4.7.24 | Connect network, electrical & He services for tracker rack |  | 2d | 2014-01-24 | 2014-01-27 | 951 |  |  |  | 1463d | 0d |  |  |  |
| 953 | 6.4.7.25 | Integration & testing of tracker safety interlocks |  | 4d | 2014-01-28 | 2014-01-31 | 952 |  |  |  | 1463d | 0d |  |  |  |
| 954 | 6.4.8 | Upstream Tracker & Solenoid Installation complete | milestone | 0d | 2014-01-31 | 2014-01-31 | 953 | 2010-05-26 | 2010-05-27 | 2d | 1463d | 0d |  |  |  |
| 955 | 6.4.9 | Upstream Spectrometer solenoid magnet moved to parked position |  | 3d | 2014-02-03 | 2014-02-05 | 954 |  |  |  | 1463d |  |  |  |  |

Notes:
- 926: Diffuser not delivered until 15/8/12. Does this need to be installed before mag field tests?? If so schedule may be delayed.

| ID | WBS | Task | Type | Duration | Start | Finish | Predecessors | Baseline start | Baseline finish | Baseline duration | Total slack | Free slack | Constraint | Resources | Work |
| --- | --- | --- | --- | --- | --- | --- | --- | --- | --- | --- | --- | --- | --- | --- | --- |
| 956 | 6.4.10 | **Spectrometer Solenoid - Downstream** |  | 61d | 2013-11-19 | 2014-02-11 | 125, 891 |  |  |  | 12d |  |  | Spectrometer | 488h |
| 957 | 6.4.10.1 | Downstream Spectrometer Solenoid & Virostek plate Installation |  | 20d | 2013-11-26 | 2013-12-23 | 125, 239, 925 | 2010-05-28 | 2010-05-31 | 2d | 7d | 0d |  |  |  |
| 958 | 6.4.10.2 | Clean up area of magnetic components |  | 2d | 2013-11-19 | 2013-11-20 | 957SS-5d |  |  |  | 1518d |  |  |  |  |
| 959 | 6.4.10.3 | Vacuum pump down |  | 10d | 2013-12-24 | 2014-01-06 | 957 |  |  |  | 1485d |  |  |  |  |
| 960 | 6.4.10.4 | Cool down spectrometer |  | 6d | 2013-12-24 | 2013-12-31 | 957 |  |  |  | 7d | 0d |  |  |  |
| 961 | 6.4.10.5 | magnetic field set up (5wks training) |  | 5w | 2014-01-01 | 2014-02-04 | 960 |  |  |  | 7d | 0d |  |  |  |
| 962 | 6.4.10.6 | magnet field mapping |  | 5d | 2014-02-05 | 2014-02-11 | 961 |  |  |  | 7d | 0d |  |  |  |
| 963 | 6.4.11 | **Tracker Installation - Downstream** |  | 48d | 2014-02-12 | 2014-04-18 |  |  |  |  | 7d | 0d |  | Tracker | 384h |
| 964 | 6.4.11.1 | Clear area for tracker installation |  | 1d | 2014-02-12 | 2014-02-12 | 962 | 2009-08-11 | 2009-08-13 | 3d? | 7d | 0d | start no earlier than 2009-05-25 |  |  |
| 965 | 6.4.11.2 | Fit and seal patch panel to the solenoid front plate |  | 1d | 2014-02-13 | 2014-02-13 | 964 | 2009-08-14 | 2009-08-17 | 2d | 7d | 0d |  |  |  |
| 966 | 6.4.11.3 | Survey the bore of the solenoid using the tracker alignment tools |  | 2d | 2014-02-14 | 2014-02-17 | 965 | 2009-08-18 | 2009-08-24 | 5d? | 7d | 0d | start no earlier than 2009-05-25 |  |  |
| 967 | 6.4.11.4 | Fit the far hall probes on their collar |  | 1d | 2014-02-18 | 2014-02-18 | 966 | 2009-08-25 | 2009-08-31 | 5d? | 7d | 0d | start no earlier than 2009-06-01 |  |  |
| 968 | 6.4.11.5 | Fit the helium window |  | 1d | 2014-02-19 | 2014-02-19 | 967 | 2009-09-01 | 2009-09-01 | 1d? | 7d | 0d |  |  |  |
| 969 | 6.4.11.6 | Connect the tracker volume helium supply |  | 1d | 2014-02-20 | 2014-02-20 | 968 | 2009-09-02 | 2009-09-08 | 5d | 7d | 0d |  |  |  |
| 970 | 6.4.11.7 | Erect blockout tent |  | 1d | 2014-02-21 | 2014-02-21 | 969 | 2009-09-09 | 2009-09-10 | 2d | 7d | 0d |  |  |  |
| 971 | 6.4.11.8 | Fit yellow lighting inside the tent |  | 1d | 2014-02-24 | 2014-02-24 | 970 | 2009-09-11 | 2009-09-16 | 4d? | 7d | 0d | start no earlier than 2009-06-09 |  |  |
| 972 | 6.4.11.9 | install the tracker installation platform inside the tent |  | 1d | 2014-02-25 | 2014-02-25 | 971 |  |  |  | 7d | 0d |  |  |  |
| 973 | 6.4.11.10 | Install the tracker replacing any faulty waveguides |  | 5d | 2014-02-26 | 2014-03-04 | 972 |  |  |  | 7d | 0d |  |  |  |
| 974 | 6.4.11.11 | Fit and seal the patch panel cover plus bulkhead connector covers |  | 1d | 2014-03-05 | 2014-03-05 | 973 |  |  |  | 7d | 0d |  |  |  |
| 975 | 6.4.11.12 | Remove the blackout tent |  | 1d | 2014-03-06 | 2014-03-06 | 974 |  |  |  | 7d | 0d |  |  |  |
| 976 | 6.4.11.13 | Position and fit the VLPC and Cryo-coolers onto the rolling platform |  | 5d | 2014-03-07 | 2014-03-13 | 975 |  |  |  | 7d | 0d |  |  |  |
| 977 | 6.4.11.14 | Position and fit the services required fir the Cryo-coolers |  | 5d | 2014-03-14 | 2014-03-20 | 976 |  |  |  | 7d | 0d |  |  |  |
| 978 | 6.4.11.15 | Errect the trellis to support the external waveguides |  | 3d | 2014-03-21 | 2014-03-25 | 977 |  |  |  | 7d | 0d |  |  |  |
| 979 | 6.4.11.16 | Fit the external waveguides |  | 2d | 2014-03-26 | 2014-03-27 | 978 |  |  |  | 7d | 0d |  |  |  |
| 980 | 6.4.11.17 | Set up micetkpc1 (server PC for AFEllts & cryo system) |  | 2d | 2014-03-28 | 2014-03-31 | 979 |  |  |  | 7d | 0d |  |  |  |
| 981 | 6.4.11.18 | AFEllt trigger distribution |  | 3d | 2014-04-01 | 2014-04-03 | 980 |  |  |  | 7d | 0d |  |  |  |
| 982 | 6.4.11.19 | Prepare 3 phase & chilled water for compressors (cold head) |  | 1d | 2014-04-04 | 2014-04-04 | 981 |  |  |  | 7d | 0d |  |  |  |
| 983 | 6.4.11.20 | Install compressors |  | 2d | 2014-04-07 | 2014-04-08 | 982 |  |  |  | 7d | 0d |  |  |  |
| 984 | 6.4.11.21 | Install cryo insulating vacuum pump sets |  | 1d | 2014-04-09 | 2014-04-09 | 983 |  |  |  | 7d | 0d |  |  |  |
| 985 | 6.4.11.22 | Move and position tracker rack |  | 1d | 2014-04-10 | 2014-04-10 | 984 |  |  |  | 7d | 0d |  |  |  |
| 986 | 6.4.11.23 | Connect network, electrical & He services for tracker rack |  | 2d | 2014-04-11 | 2014-04-14 | 985 |  |  |  | 7d | 0d |  |  |  |
| 987 | 6.4.11.24 | Integration & testing of tracker safety interlocks |  | 4d | 2014-04-15 | 2014-04-18 | 986 |  |  |  | 7d | 0d |  |  |  |
| 988 | 6.4.12 | Re-install TOF2, KL & EMR |  | 5d | 2014-04-21 | 2014-04-25 | 963 | 2010-06-01 | 2010-06-14 | 10d? | 7d | 0d | finish no earlier than 2010-03-12 |  |  |
| 989 | 6.4.13 | Reposition spectrometer #1 and align |  | 3d | 2014-04-28 | 2014-04-30 | 988 |  |  |  | 7d | 0d |  |  |  |
| 990 | 6.4.14 | Re train all magnets |  | 5w | 2014-05-01 | 2014-06-04 | 989 |  |  |  | 7d | 0d |  |  |  |
| 991 | 6.4.15 | MICE step IV installation complete | milestone | 0d | 2014-06-04 | 2014-06-04 | 990 | 2010-06-15 | 2010-06-15 | 0d | 7d | 0d |  |  |  |

| ID | WBS | Task | Type | Duration | Start | Finish | Predecessors | Baseline start | Baseline finish | Baseline duration | Total slack | Free slack | Constraint | Resources | Work | Cost |
| --- | --- | --- | --- | --- | --- | --- | --- | --- | --- | --- | --- | --- | --- | --- | --- | --- |
| 992 | 6.5 | **MICE Step V Installation** |  | 233d | 2016-08-04 | 2017-06-26 |  | 2009-11-02 | 2011-05-02 | 391d? | 7d |  |  | Step V | 2640h | 27,000 |
| 993 | 6.5.1 | Remove TOF1 & KL & EMR |  | 2d | 2016-08-04 | 2016-08-05 | 1187 | 2010-08-09 | 2010-08-13 | 5d? | 7d | 0d |  |  |  |  |
| 994 | 6.5.2 | Move spectrometer #1 to parked position |  | 2d | 2016-08-08 | 2016-08-09 | 993 |  |  |  | 7d | 0d |  |  |  |  |
| 995 | 6.5.3 | Move AFC to parked position |  | 1d | 2016-08-10 | 2016-08-10 | 994 |  |  |  | 7d | 0d |  |  |  |  |
| 996 | 6.5.4 | Remove spectrometer #2 |  | 1d | 2016-08-11 | 2016-08-11 | 995 |  |  |  | 7d | 0d |  |  |  |  |
| 997 | 6.5.5 | **Step V Base plate installation** |  | 56d | 2016-08-11 | 2016-10-28 |  |  |  |  | 7d |  |  |  |  | 27,000 |
| 998 | 6.5.5.1 | Procure steel plates for the false floor intermediate surface | milestone | 0d | 2016-08-11 | 2016-08-11 | 996 |  |  |  | 807d |  | start no earlier than 2013-04-01 |  |  | 14,000 |
| 999 | 6.5.5.2 | Remove step IV false floor plates |  | 2d | 2016-08-12 | 2016-08-15 | 996 |  |  |  | 7d | 0d |  |  |  |  |
| 1000 | 6.5.5.3 | Begin drilling and tapping holes in the false floor suffcient for step V |  | 8d | 2016-08-16 | 2016-08-25 | 999 |  |  |  | 7d | 0d |  |  |  |  |
| 1001 | 6.5.5.4 | Fit intermediate surface (tiled steel plates) for the false floor step V position |  | 5d | 2016-08-26 | 2016-09-01 | 1000 |  |  |  | 7d | 0d |  |  |  |  |
| 1002 | 6.5.5.5 | Trial RFCC #1 base plate Installation including survey and marking out |  | 2d | 2016-09-02 | 2016-09-05 | 1001 |  |  |  | 7d | 0d |  |  |  | 2,000 |
| 1003 | 6.5.5.6 | Drill and tap threaded holes in the false floor intermediate surface |  | 3d | 2016-09-06 | 2016-09-08 | 1002 |  |  |  | 7d | 0d |  |  |  |  |
| 1004 | 6.5.5.7 | Create level surface with washers at bolt locations (survey level) |  | 5d | 2016-09-09 | 2016-09-15 | 1003 |  |  |  | 7d | 0d |  |  |  | 2,000 |
| 1005 | 6.5.5.8 | Re-Install base plate |  | 2d | 2016-09-16 | 2016-09-19 | 1004 |  |  |  | 7d | 0d |  |  |  |  |
| 1006 | 6.5.5.9 | Install through bolts and survey, level and tighten the complete arrangement |  | 3d | 2016-09-20 | 2016-09-22 | 1005 |  |  |  | 7d | 0d |  |  |  |  |
| 1007 | 6.5.5.10 | Trial AFC #2 base plate installation including survey and marking out |  | 3d | 2016-09-23 | 2016-09-27 | 1006 |  |  |  | 7d | 0d |  |  |  | 2,000 |
| 1008 | 6.5.5.11 | Drill and tap threaded holes in the false floor intermediate surface |  | 3d | 2016-09-28 | 2016-09-30 | 1007 |  |  |  | 7d | 0d |  |  |  |  |
| 1009 | 6.5.5.12 | Create level surface with washers at bolt locations (survey level) |  | 2d | 2016-10-03 | 2016-10-04 | 1008 |  |  |  | 7d | 0d |  |  |  | 2,000 |
| 1010 | 6.5.5.13 | Re-Install base plate |  | 2d | 2016-10-05 | 2016-10-06 | 1009 |  |  |  | 7d | 0d |  |  |  |  |
| 1011 | 6.5.5.14 | Install through bolts and survey, level and tighten the complete arrangement |  | 2d | 2016-10-07 | 2016-10-10 | 1010 |  |  |  | 7d | 0d |  |  |  | 2,000 |
| 1012 | 6.5.5.15 | Trial spectrometer #2 base plate Installation including survey and marking out |  | 3d | 2016-10-11 | 2016-10-13 | 1011 |  |  |  | 7d | 0d |  |  |  |  |
| 1013 | 6.5.5.16 | Drill and tap threaded holes in the false floor intermediate surface |  | 3d | 2016-10-14 | 2016-10-18 | 1012 |  |  |  | 7d | 0d |  |  |  |  |
| 1014 | 6.5.5.17 | Create level surface with washers at bolt locations (survey level) |  | 3d | 2016-10-19 | 2016-10-21 | 1013 |  |  |  | 7d | 0d |  |  |  | 2,000 |
| 1015 | 6.5.5.18 | Re-Install base plate |  | 2d | 2016-10-24 | 2016-10-25 | 1014 |  |  |  | 7d | 0d |  |  |  |  |
| 1016 | 6.5.5.19 | Install through bolts and survey, level and tighten the complete arrangement |  | 3d | 2016-10-26 | 2016-10-28 | 1015 |  |  |  | 7d | 0d |  |  |  | 1,000 |

| ID | WBS | Task | Type | Duration | Start | Finish | Predecessors | Baseline start | Baseline finish | Baseline duration | Total slack | Free slack | Constraint | Resources | Work | Cost |
| --- | --- | --- | --- | --- | --- | --- | --- | --- | --- | --- | --- | --- | --- | --- | --- | --- |
| 1017 | 6.5.6 | **AFC #2 Installation** |  | 54d | 2016-10-31 | 2017-01-12 |  | 2009-12-01 | 2011-03-31 | 348d? | 7d | 0d |  |  |  |  |
| 1018 | 6.5.6.1 | Install AFC #2 rail system |  | 2d | 2016-10-31 | 2016-11-01 | 1016 |  |  |  | 7d | 0d |  |  |  |  |
| 1019 | 6.5.6.2 | Install AFC #2supports to floor |  | 2d | 2016-11-02 | 2016-11-03 | 1018 | 2010-02-22 | 2010-02-26 | 5d | 7d | 0d | finish no earlier than 2010-02-26 |  |  |  |
| 1020 | 6.5.6.3 | Install AFC #2 module and align |  | 5d | 2016-11-04 | 2016-11-10 | 1019 | 2010-04-09 | 2010-04-12 | 2d | 7d | 0d | start no earlier than 2010-03-01 |  |  |  |
| 1021 | 6.5.6.4 | Cooldown AFC #2 |  | 20d | 2016-11-11 | 2016-12-08 | 1020 |  |  |  | 7d | 0d |  |  |  |  |
| 1022 | 6.5.6.5 | AFC magnet test period |  | 20d | 2016-12-09 | 2017-01-05 | 1021 | 2010-04-26 | 2010-05-21 | 20d | 7d | 0d | start no earlier than 2010-04-26 |  |  |  |
| 1023 | 6.5.6.6 | Connect R&D LH2 system |  | 5d | 2017-01-06 | 2017-01-12 | 1022 | 2010-05-24 | 2010-05-25 | 2d | 7d | 0d |  |  |  |  |
| 1024 | 6.5.7 | **RFCC #1 Installation** |  | 97d | 2017-01-13 | 2017-05-29 | 1023 |  |  |  | 2d | 0d |  | RF System | 776h |  |
| 1025 | 6.5.7.1 | Install RFFC rail system |  | 2d | 2017-01-13 | 2017-01-16 |  |  |  |  | 7d | 0d |  |  |  |  |
| 1026 | 6.5.7.2 | Install RFFC supports to floor |  | 5d | 2017-01-17 | 2017-01-23 | 1025 | 2010-02-22 | 2010-02-26 | 5d | 7d |  | finish no earlier than 2010-02-26 |  |  |  |
| 1027 | 6.5.7.3 | Install RFFC module #1 and align |  | 5d | 2017-01-31 | 2017-02-06 | 1026, 143FS+4w | 2010-04-09 | 2010-04-12 | 2d | 2d | 0d | start no earlier than 2010-03-01 |  |  |  |
| 1028 | 6.5.7.4 | Cooldown RFFC #1 |  | 20d | 2017-02-07 | 2017-03-06 | 1027 |  |  |  | 2d | 0d |  |  |  |  |
| 1029 | 6.5.7.5 | RFFC magnet test period |  | 20d | 2017-03-07 | 2017-04-03 | 1028 | 2010-04-26 | 2010-05-21 | 20d | 2d | 0d | start no earlier than 2010-04-26 |  |  |  |
| 1030 | 6.5.7.6 | Connect RF wave guides |  | 15d | 2017-04-04 | 2017-04-24 | 1029 | 2010-05-24 | 2010-05-25 | 2d | 2d | 0d |  |  |  |  |
| 1031 | 6.5.7.7 | RF Amplifier test period |  | 10d | 2017-04-25 | 2017-05-08 | 1030 |  |  |  | 2d | 0d |  |  |  |  |
| 1032 | 6.5.7.8 | RFFC test period |  | 15d | 2017-05-09 | 2017-05-29 | 1031 |  |  |  | 2d | 0d |  |  |  |  |
| 1033 | 6.5.8 | Spectrometer Solenoid #2 installation |  | 15d | 2017-05-30 | 2017-06-19 | 1032 |  |  |  | 2d | 0d |  |  |  |  |
| 1034 | 6.5.9 | Re-install TOF2, KL & EMR |  | 5d | 2017-06-20 | 2017-06-26 | 1033 | 2010-06-01 | 2010-06-14 | 10d? | 2d | 0d | finish no earlier than 2010-03-12 |  |  |  |
| 1035 | 6.5.10 | MICE step V installation complete | milestone | 0d | 2017-06-26 | 2017-06-26 | 1034 | 2010-06-15 | 2010-06-15 | 0d | 2d | 0d | start no earlier than 2010-05-07 |  |  |  |
| 1036 | 6.6 | **MICE Step VI Installation** |  | 230d | 2017-10-31 | 2018-09-17 |  |  |  |  | 0d |  |  | Step VI | 2592h | 27,000 |
| 1037 | 6.6.1 | Remove TOF1 & KL & EMR |  | 2d | 2017-10-31 | 2017-11-01 | 1203 | 2010-08-09 | 2010-08-13 | 5d? | 2d | 0d | start no earlier than 2013-04-01 |  |  |  |
| 1038 | 6.6.2 | Move spectrometer #1 to parked position |  | 2d | 2017-11-02 | 2017-11-03 | 1037 |  |  |  | 2d | 0d |  |  |  |  |
| 1039 | 6.6.3 | Move AFC#1to parked position |  | 2d | 2017-11-06 | 2017-11-07 | 1038 |  |  |  | 2d | 0d |  |  |  |  |
| 1040 | 6.6.4 | Move RFCC #1 to parked position |  | 2d | 2017-11-08 | 2017-11-09 | 1039 |  |  |  | 2d | 0d |  |  |  |  |
| 1041 | 6.6.5 | Move AFC#2 to parked position |  | 1d | 2017-11-10 | 2017-11-10 | 1040 |  |  |  | 2d | 0d |  |  |  |  |
| 1042 | 6.6.6 | Remove spectrometer #2 |  | 1d | 2017-11-13 | 2017-11-13 | 1041 |  |  |  | 2d | 0d |  |  |  |  |

| ID | WBS | Task | Type | Duration | Start | Finish | Predecessors | Baseline start | Baseline finish | Baseline duration | Total slack | Free slack | Constraint | Resources | Work | Cost |
| --- | --- | --- | --- | --- | --- | --- | --- | --- | --- | --- | --- | --- | --- | --- | --- | --- |
| 1043 | 6.6.7 | **Base plate installation** |  | 49d | 2017-11-13 | 2018-01-19 |  |  |  |  | 2d | 0d |  |  |  | 27,000 |
| 1044 | 6.6.7.1 | Procure Aluminium plates for the false floor intermediate surface | milestone | 0d | 2017-11-13 | 2017-11-13 | 1042 |  |  |  | 2d | 0d | start no earlier than 2013-04-01 |  |  | 14,000 |
| 1045 | 6.6.7.2 | Remove step V false floor plates under spectrometer #2 |  | 2d | 2017-11-14 | 2017-11-15 | 1044 |  |  |  | 2d | 0d |  |  |  |  |
| 1046 | 6.6.7.3 | Fit intermediate surface (tiled aluminium plates) for the false floor step VI position |  | 5d | 2017-11-16 | 2017-11-22 | 1045 |  |  |  | 2d | 0d |  |  |  |  |
| 1047 | 6.6.7.4 | Trial RFCC #1 base plate Installation including survey and marking out |  | 2d | 2017-11-23 | 2017-11-24 | 1046 |  |  |  | 2d | 0d |  |  |  | 2,000 |
| 1048 | 6.6.7.5 | Drill and tap threaded holes in the false floor intermediate surface |  | 3d | 2017-11-27 | 2017-11-29 | 1047 |  |  |  | 2d | 0d |  |  |  |  |
| 1049 | 6.6.7.6 | Create level surface with washers at bolt locations (survey level) |  | 5d | 2017-11-30 | 2017-12-06 | 1048 |  |  |  | 2d | 0d |  |  |  | 2,000 |
| 1050 | 6.6.7.7 | Re-Install base plate |  | 2d | 2017-12-07 | 2017-12-08 | 1049 |  |  |  | 2d | 0d |  |  |  |  |
| 1051 | 6.6.7.8 | Install through bolts and survey, level and tighten the complete arrangement |  | 3d | 2017-12-11 | 2017-12-13 | 1050 |  |  |  | 2d | 0d |  |  |  |  |
| 1052 | 6.6.7.9 | Trial AFC #2 base plate installation including survey and marking out |  | 3d | 2017-12-14 | 2017-12-18 | 1051 |  |  |  | 2d | 0d |  |  |  | 2,000 |
| 1053 | 6.6.7.10 | Drill and tap threaded holes in the false floor intermediate surface |  | 3d | 2017-12-19 | 2017-12-21 | 1052 |  |  |  | 2d | 0d |  |  |  |  |
| 1054 | 6.6.7.11 | Create level surface with washers at bolt locations (survey level) |  | 2d | 2017-12-22 | 2017-12-25 | 1053 |  |  |  | 2d | 0d |  |  |  | 2,000 |
| 1055 | 6.6.7.12 | Re-Install base plate |  | 2d | 2017-12-26 | 2017-12-27 | 1054 |  |  |  | 2d | 0d |  |  |  |  |
| 1056 | 6.6.7.13 | Install through bolts and survey, level and tighten the complete arrangement |  | 2d | 2017-12-28 | 2017-12-29 | 1055 |  |  |  | 2d | 0d |  |  |  | 2,000 |
| 1057 | 6.6.7.14 | Trial spectrometer #2 base plate Installation including survey and marking out |  | 3d | 2018-01-01 | 2018-01-03 | 1056 |  |  |  | 2d | 0d |  |  |  |  |
| 1058 | 6.6.7.15 | Drill and tap threaded holes in the false floor intermediate surface |  | 3d | 2018-01-04 | 2018-01-08 | 1057 |  |  |  | 2d | 0d |  |  |  |  |
| 1059 | 6.6.7.16 | Create level surface with washers at bolt locations (survey level) |  | 3d | 2018-01-09 | 2018-01-11 | 1058 |  |  |  | 2d | 0d |  |  |  | 2,000 |
| 1060 | 6.6.7.17 | Re-Install base plate |  | 2d | 2018-01-12 | 2018-01-15 | 1059 |  |  |  | 2d | 0d |  |  |  |  |
| 1061 | 6.6.7.18 | Grout in base plate |  | 1d | 2018-01-16 | 2018-01-16 | 1060 |  |  |  | 2d | 0d |  |  |  |  |
| 1062 | 6.6.7.19 | Install through bolts and survey, level and tighten the complete arrangement |  | 3d | 2018-01-17 | 2018-01-19 | 1061 |  |  |  | 2d | 0d |  |  |  | 1,000 |
| 1063 | 6.6.8 | **RFCC #2 Installation** |  | 94d | 2018-01-22 | 2018-05-31 |  |  |  |  | 0d |  |  | RF System | 752h |  |
| 1064 | 6.6.8.1 | Install RFFC #2 rail system |  | 2d | 2018-01-22 | 2018-01-23 | 1062 |  |  |  | 2d | 0d |  |  |  |  |
| 1065 | 6.6.8.2 | Install RFFC #2 supports to floor |  | 5d | 2018-01-24 | 2018-01-30 | 1064 | 2010-02-22 | 2010-02-26 | 5d | 2d |  | finish no earlier than 2010-02-26 |  |  |  |
| 1066 | 6.6.8.3 | Install RFFC module #2 and align |  | 5d | 2018-02-02 | 2018-02-08 | 1065, 144FS+4w | 2010-04-09 | 2010-04-12 | 2d | 0d |  | start no earlier than 2010-03-01 |  |  |  |
| 1067 | 6.6.8.4 | Cooldown RFFC #2 |  | 20d | 2018-02-09 | 2018-03-08 | 1066 |  |  |  | 0d |  |  |  |  |  |
| 1068 | 6.6.8.5 | RFFC magnet test period |  | 20d | 2018-03-09 | 2018-04-05 | 1067 | 2010-04-26 | 2010-05-21 | 20d | 0d |  | start no earlier than 2010-04-26 |  |  |  |
| 1069 | 6.6.8.6 | Connect RF wave guides |  | 15d | 2018-04-06 | 2018-04-26 | 1068 | 2010-05-24 | 2010-05-25 | 2d | 0d |  |  |  |  |  |
| 1070 | 6.6.8.7 | RF Amplifier test period |  | 10d | 2018-04-27 | 2018-05-10 | 1069 |  |  |  | 0d |  |  |  |  |  |
| 1071 | 6.6.8.8 | RFFC absorber test period |  | 15d | 2018-05-11 | 2018-05-31 | 1070 |  |  |  | 0d |  |  |  |  |  |

| ID | WBS | Task | Type | Duration | Start | Finish | Predecessors | Complete | Remaining | Baseline start | Baseline finish | Baseline duration | Total slack | Free slack | Constraint | Resources | Work | Actual work | Cost | Actual cost |
| --- | --- | --- | --- | --- | --- | --- | --- | --- | --- | --- | --- | --- | --- | --- | --- | --- | --- | --- | --- | --- |
| 1072 | 6.6.9 | **AFC #3 Installation** |  | 57d | 2018-06-01 | 2018-08-20 |  |  |  | 2009-12-01 | 2011-03-31 | 348d? | 0d |  |  |  |  |  |  |  |
| 1073 | 6.6.9.1 | Install AFC #3 rail system |  | 2d | 2018-06-01 | 2018-06-04 | 1071 |  |  |  |  |  | 0d |  |  |  |  |  |  |  |
| 1074 | 6.6.9.2 | Install AFC #3 supports to floor |  | 5d | 2018-06-05 | 2018-06-11 | 1073 |  |  | 2010-02-22 | 2010-02-26 | 5d | 0d |  | finish no earlier than 2010-02-26 |  |  |  |  |  |
| 1075 | 6.6.9.3 | Install AFC #3 module and align |  | 5d | 2018-06-12 | 2018-06-18 | 1074 |  |  | 2010-04-09 | 2010-04-12 | 2d | 0d |  | start no earlier than 2010-03-01 |  |  |  |  |  |
| 1076 | 6.6.9.4 | Cooldown AFC #3 |  | 20d | 2018-06-19 | 2018-07-16 | 1075 |  |  |  |  |  | 0d |  |  |  |  |  |  |  |
| 1077 | 6.6.9.5 | AFC #3 magnet test period |  | 20d | 2018-07-17 | 2018-08-13 | 1076 |  |  | 2010-04-26 | 2010-05-21 | 20d | 0d |  | start no earlier than 2010-04-26 |  |  |  |  |  |
| 1078 | 6.6.9.6 | Connect R&D LH2 system |  | 5d | 2018-08-14 | 2018-08-20 | 1077 |  |  | 2010-05-24 | 2010-05-25 | 2d | 0d |  |  |  |  |  |  |  |
| 1079 | 6.6.10 | Spectrometer Solenoid #2 Installation |  | 15d | 2018-08-21 | 2018-09-10 | 1078 |  |  |  |  |  | 0d |  |  |  |  |  |  |  |
| 1080 | 6.6.11 | Re-install TOF2, KL & EMR |  | 5d | 2018-09-11 | 2018-09-17 | 1079 |  |  | 2010-06-01 | 2010-06-14 | 10d? | 0d |  | finish no earlier than 2010-03-12 |  |  |  |  |  |
| 1081 | 6.6.12 | MICE step VI installation complete | milestone | 0d | 2018-09-17 | 2018-09-17 | 1080 |  |  | 2010-06-15 | 2010-06-15 | 0d | 0d |  | start no earlier than 2010-05-07 |  |  |  |  |  |
| 1083 | 7 | **Magnet Measurement & movement of magnets** |  | 351.37d | 2012-12-25 | 2014-04-30 |  |  |  |  |  |  | 1403d |  |  | Magnet Measurement | 2810.93h |  |  |  |
| 1084 | 7.1 | Focus coil magnet measured in R9 |  | 10d | 2012-12-25 | 2013-01-08 | 174SS |  |  |  |  |  | 1744.37d |  |  |  |  |  |  |  |
| 1085 | 7.2 | Focus coil magnet measured in step IV position |  | 10d | 2013-02-25 | 2013-03-11 | 887SS |  |  |  |  |  | 1700.37d | 0d |  |  |  |  |  |  |
| 1086 | 7.3 | Focus coil moved to parked position |  | 2d | 2013-05-10 | 2013-05-13 | 891SS |  |  |  |  |  | 1628d | 0d |  |  |  |  |  |  |
| 1087 | 7.4 | Spectrometer solenoid magnet (upstream) measured in step IV position |  | 10d | 2013-10-15 | 2013-10-28 | 924SS |  |  |  |  |  | 1535d |  |  |  |  |  |  |  |
| 1088 | 7.5 | Spectrometer solenoid magnet (upstream) moved to parked position |  | 3d | 2013-12-10 | 2013-12-12 | 927SS |  |  |  |  |  | 1502d |  |  |  |  |  |  |  |
| 1089 | 7.6 | Spectrometer solenoid magnet (downstream) measured in step IV position |  | 10d | 2014-01-01 | 2014-01-14 | 961SS |  |  |  |  |  | 1479d |  |  |  |  |  |  |  |
| 1090 | 7.7 | Reposition AFC#1 in step IV position |  | 2d | 2014-02-12 | 2014-02-13 | 903SS |  |  |  |  |  | 1457d |  |  |  |  |  |  |  |
| 1091 | 7.8 | Reposition spectrometer (upstream) and align |  | 3d | 2014-04-28 | 2014-04-30 | 989SS |  |  |  |  |  | 1403d |  |  |  |  |  |  |  |
| 1093 | 8 | **Commissioing** |  | 2166d | 2011-05-30 A | 2019-09-16 |  | 4% | 2068.83d |  |  |  | 0d |  |  | Commissioning | 40626h | 2494.64h | 126,130.5 | 56,936.06 |
| 1094 | 8.1 | **Hydrogen System Commissioning** |  | 1757d | 2011-05-30 A | 2018-02-20 |  | 46% | 954.13d |  |  |  | 409d |  |  | Hydrogen System | 15682h | 1717.25h | 126,130.5 | 56,936.06 |
| 1095 | 8.1.1 | **R&D Tests** |  | 317d | 2011-05-30 A | 2012-08-14 |  | 99% | 0d |  |  |  | 1789d | 0d |  |  | 1070h | 1070h | 56,936.06 | 56,936.06 |
| 1096 | 8.1.1.1 | **Helium Tests - Prior to Safety Review** |  | 29d | 2011-05-30 A | 2011-07-07 A | 573FS+14d | 100% |  |  |  |  |  |  |  |  | 464h | 464h | 24,705.68 | 24,705.68 |
| 1097 | 8.1.1.1.1 | Check instrumentation |  | 3d | 2011-05-30 A | 2011-06-01 A |  | 100% |  |  |  |  |  |  |  | Mike Courthold; Matt Hills | 48h | 48h | 2,555.76 | 2,555.76 |
| 1098 | 8.1.1.1.2 | Pump and purge |  | 1d | 2011-06-02 A | 2011-06-02 A | 1097 | 100% |  |  |  |  |  |  |  | Mike Courthold; Matt Hills | 16h | 16h | 851.92 | 851.92 |
| 1099 | 8.1.1.1.3 | Check relief valve settings |  | 1d | 2011-06-03 A | 2011-06-03 A | 1098 | 100% |  |  |  |  |  |  |  | Matt Hills; Mike Courthold | 16h | 16h | 851.92 | 851.92 |
| 1100 | 8.1.1.1.4 | Check cryocooler operation at LH2 and LHe temperatures |  | 2d | 2011-06-06 A | 2011-06-07 A | 1099 | 100% |  |  |  |  |  |  |  | Mike Courthold; Matt Hills | 32h | 32h | 1,703.84 | 1,703.84 |
| 1101 | 8.1.1.1.5 | Liquify helium in the cryostat |  | 10d | 2011-06-08 A | 2011-06-21 A | 1100 | 100% |  |  |  |  |  |  |  | Mike Courthold; Matt Hills | 160h | 160h | 8,519.2 | 8,519.2 |
| 1102 | 8.1.1.1.6 | Test emptying sequence |  | 2d | 2011-06-22 A | 2011-06-23 A | 1101 | 100% |  |  |  |  |  |  |  | Mike Courthold; Matt Hills | 32h | 32h | 1,703.84 | 1,703.84 |
| 1103 | 8.1.1.1.7 | Thermal cycling to check for leaks from thermal stresses |  | 10d | 2011-06-24 A | 2011-07-07 A | 1102 | 100% |  |  |  |  |  |  |  | Mike Courthold; Matt Hills | 160h | 160h | 8,519.2 | 8,519.2 |
| 1104 | 8.1.1.2 | Hydrogen System Safety Review Procedural Changes Complete | milestone | 0d | 2012-03-29 | 2012-03-29 | 1096 |  |  |  |  |  | 1888d |  | start no earlier than 2012-03-29 |  |  |  |  |  |

| ID | WBS | Task | Duration | Start | Finish | Predecessors | Complete | Total slack | Free slack | Constraint | Calendar | Resources | Work | Actual work | Cost | Actual cost |
| --- | --- | --- | --- | --- | --- | --- | --- | --- | --- | --- | --- | --- | --- | --- | --- | --- |
| 1105 | 8.1.1.3 | **Helium Tests** | 81d | 2012-01-31 A | 2012-05-22 A |  | 100% |  |  | start no earlier than 2012-01-31 |  |  | 272h | 272h | 14,482.64 | 14,482.64 |
| 1106 | 8.1.1.3.1 | Check instrumentation | 1d | 2012-01-31 A | 2012-01-31 A |  | 100% |  |  |  |  | Mike Courthold; Matt Hills | 16h | 16h | 851.92 | 851.92 |
| 1107 | 8.1.1.3.2 | Pump and purge | 1d | 2012-02-01 A | 2012-02-01 A | 1106 | 100% |  |  |  |  | Mike Courthold; Matt Hills | 16h | 16h | 851.92 | 851.92 |
| 1108 | 8.1.1.3.3 | Check relief valve settings | 1d | 2012-02-02 A | 2012-02-02 A | 1107 | 100% |  |  |  |  | Matt Hills; Mike Courthold | 16h | 16h | 851.92 | 851.92 |
| 1109 | 8.1.1.3.4 | Check cryocooler operation at LH2 and LHe temperatures | 2d | 2012-02-03 A | 2012-02-06 A | 1108 | 100% |  |  |  |  | Mike Courthold; Matt Hills | 32h | 32h | 1,703.84 | 1,703.84 |
| 1110 | 8.1.1.3.5 | Liquify helium in the cryostat | 10d | 2012-05-07 A | 2012-05-18 A | 1109 | 100% |  |  | finish no earlier than 2012-05-18 |  | Mike Courthold; Matt Hills | 160h | 160h | 8,519.2 | 8,519.2 |
| 1111 | 8.1.1.3.6 | Test emptying sequence | 2d | 2012-05-21 A | 2012-05-22 A | 1110 | 100% |  |  |  |  | Mike Courthold; Matt Hills | 32h | 32h | 1,703.84 | 1,703.84 |
| 1112 | 8.1.1.4 | **Hydrogen Tests** | 23d | 2012-07-23 A | 2012-08-14 A |  | 100% |  |  |  | 7 day |  | 334h | 334h | 17,747.74 | 17,747.74 |
| 1113 | 8.1.1.4.1 | Bottle operations | 1d | 2012-07-23 A | 2012-07-23 A | 1105, 1104 | 100% |  |  | start no earlier than 2012-07-23 | 7 day | Mike Courthold; Matt Hills | 16h | 16h | 851.92 | 851.92 |
| 1114 | 8.1.1.4.2 | Hydride bed charging | 2d | 2012-07-24 A | 2012-07-25 A | 1113 | 100% |  |  |  | 7 day | Mike Courthold; Matt Hills | 32h | 32h | 1,703.84 | 1,703.84 |
| 1115 | 8.1.1.4.3 | Hydrogen purge | 1d | 2012-07-26 A | 2012-07-26 A | 1114 | 100% |  |  |  | 7 day | Mike Courthold; Matt Hills | 16h | 16h | 851.92 | 851.92 |
| 1116 | 8.1.1.4.4 | Helium purge | 1d | 2012-07-27 A | 2012-07-27 A | 1115 | 100% |  |  |  | 7 day | Mike Courthold; Matt Hills | 16h | 16h | 851.92 | 851.92 |
| 1117 | 8.1.1.4.5 | Hydrogen fill | 14d | 2012-07-28 A | 2012-08-10 A | 1116 | 100% |  |  |  | 7 day | Mike Courthold; Matt Hills | 224h | 224h | 11,926.88 | 11,926.88 |
| 1118 | 8.1.1.4.6 | Hydrogen empty | 3d | 2012-08-11 A | 2012-08-13 A | 1117 | 100% |  |  |  | 7 day | Mike Courthold [50%]; Matt Hills [75%] | 30h | 30h | 1,561.26 | 1,561.26 |
| 1119 | 8.1.1.4.7 | Helium purge | 1d | 2012-08-14 A | 2012-08-14 A | 1118 | 100% |  |  |  | 7 day |  |  |  |  |  |
| 1120 | 8.1.2 | **Hydrogen system B Commissioning (with AFC)** | 39d | 2016-09-29 | 2016-11-22 | 630, 640 |  | 734d | 0d |  |  |  | 644h |  | 34,265.72 |  |
| 1121 | 8.1.2.1 | **Helium Tests** | 25d | 2016-09-29 | 2016-11-02 |  |  | 734d | 0d |  |  |  | 400h |  | 21,298 |  |
| 1122 | 8.1.2.1.1 | Check instrumentation | 3d | 2016-09-29 | 2016-10-03 |  |  | 734d | 0d |  |  | Mike Courthold; Matt Hills | 48h |  | 2,555.76 |  |
| 1123 | 8.1.2.1.2 | Pump and purge | 2d | 2016-10-04 | 2016-10-05 | 1122 |  | 734d | 0d |  |  | Mike Courthold; Matt Hills | 32h |  | 1,703.84 |  |
| 1124 | 8.1.2.1.3 | Check relief valve settings | 1d | 2016-10-06 | 2016-10-06 | 1123 |  | 734d | 0d |  |  | Matt Hills; Mike Courthold | 16h |  | 851.92 |  |
| 1125 | 8.1.2.1.4 | Check cryocooler operation at LH2 and LHe temperatures | 4d | 2016-10-07 | 2016-10-12 | 1124 |  | 734d | 0d |  |  | Mike Courthold; Matt Hills | 64h |  | 3,407.68 |  |
| 1126 | 8.1.2.1.5 | Liquify helium in the cryostat | 4d | 2016-10-13 | 2016-10-18 | 1125 |  | 734d | 0d |  |  | Mike Courthold; Matt Hills | 64h |  | 3,407.68 |  |
| 1127 | 8.1.2.1.6 | Test emptying sequence | 1d | 2016-10-19 | 2016-10-19 | 1126 |  | 734d | 0d |  |  | Mike Courthold; Matt Hills | 16h |  | 851.92 |  |
| 1128 | 8.1.2.1.7 | Thermal cycling to check for leaks from thermal stresses | 10d | 2016-10-20 | 2016-11-02 | 1127 |  | 734d |  |  |  | Mike Courthold; Matt Hills | 160h |  | 8,519.2 |  |

Notes:
- 1117: Fill cryostat completely from Hydride Bed
- 1118: Empty full cryostat back to Hydride Bed.

| ID | WBS | Task | Duration | Start | Finish | Predecessors | Baseline start | Baseline finish | Baseline duration | Total slack | Free slack | Constraint | Resources | Work | Cost |
| --- | --- | --- | --- | --- | --- | --- | --- | --- | --- | --- | --- | --- | --- | --- | --- |
| 1129 | 8.1.2.2 | **Hydrogen Tests** | 14d | 2016-11-03 | 2016-11-22 | 1121 |  |  |  | 734d |  |  |  | 244h | 12,967.72 |
| 1130 | 8.1.2.2.1 | Liquify hydrogen in the cryostat | 3d | 2016-11-03 | 2016-11-07 | 1121 |  |  |  | 734d | 0d |  | Mike Courthold; Matt Hills | 48h | 2,555.76 |
| 1131 | 8.1.2.2.2 | Check empty and purge sequence | 2d | 2016-11-08 | 2016-11-09 | 1130 |  |  |  | 734d | 0d |  | Mike Courthold; Matt Hills | 32h | 1,703.84 |
| 1132 | 8.1.2.2.3 | Tests to determine effects of using Helium top-up gas | 5d | 2016-11-10 | 2016-11-16 | 1131 |  |  |  | 734d | 0d |  | Mike Courthold; Matt Hills | 80h | 4,259.6 |
| 1133 | 8.1.2.2.4 | Check alarms and interlocks | 2d | 2016-11-17 | 2016-11-18 | 1132 |  |  |  | 734d | 0d |  | Mike Courthold; Matt Hills | 32h | 1,703.84 |
| 1134 | 8.1.2.2.5 | Measure H2 desorption rate | 2d | 2016-11-21 | 2016-11-22 | 1133 |  |  |  | 734d |  |  | Mike Courthold; Matt Hills | 32h | 1,703.84 |
| 1135 | 8.1.2.2.6 | Measure H2 absorption rate | 2d | 2016-11-03 | 2016-11-04 |  |  |  |  | 746d |  |  | Mike Courthold [50%]; Matt Hills [75%] | 20h | 1,040.84 |
| 1136 | 8.1.3 | **Hydrogen system C Commissioning (with AFC)** | 41d | 2017-12-26 | 2018-02-20 | 650, 660 |  |  |  | 409d | 0d |  |  | 656h | 34,928.72 |
| 1137 | 8.1.3.1 | **Helium Tests** | 25d | 2017-12-26 | 2018-01-29 |  |  |  |  | 409d | 0d |  |  | 400h | 21,298 |
| 1138 | 8.1.3.1.1 | Check instrumentation | 3d | 2017-12-26 | 2017-12-28 |  |  |  |  | 409d | 0d |  | Mike Courthold; Matt Hills | 48h | 2,555.76 |
| 1139 | 8.1.3.1.2 | Pump and purge | 2d | 2017-12-29 | 2018-01-01 | 1138 |  |  |  | 409d | 0d |  | Mike Courthold; Matt Hills | 32h | 1,703.84 |
| 1140 | 8.1.3.1.3 | Check relief valve settings | 1d | 2018-01-02 | 2018-01-02 | 1139 |  |  |  | 409d | 0d |  | Matt Hills; Mike Courthold | 16h | 851.92 |
| 1141 | 8.1.3.1.4 | Check cryocooler operation at LH2 and LHe temperatures | 4d | 2018-01-03 | 2018-01-08 | 1140 |  |  |  | 409d | 0d |  | Mike Courthold; Matt Hills | 64h | 3,407.68 |
| 1142 | 8.1.3.1.5 | Liquify helium in the cryostat | 4d | 2018-01-09 | 2018-01-12 | 1141 |  |  |  | 409d | 0d |  | Mike Courthold; Matt Hills | 64h | 3,407.68 |
| 1143 | 8.1.3.1.6 | Test emptying sequence | 1d | 2018-01-15 | 2018-01-15 | 1142 |  |  |  | 409d | 0d |  | Mike Courthold; Matt Hills | 16h | 851.92 |
| 1144 | 8.1.3.1.7 | Thermal cycling to check for leaks from thermal stresses | 10d | 2018-01-16 | 2018-01-29 | 1143 |  |  |  | 409d |  |  | Mike Courthold; Matt Hills | 160h | 8,519.2 |
| 1145 | 8.1.3.2 | **Hydrogen Tests** | 16d | 2018-01-30 | 2018-02-20 | 1137 |  |  |  | 409d |  |  |  | 256h | 13,630.72 |
| 1146 | 8.1.3.2.1 | Liquify hydrogen in the cryostat | 3d | 2018-01-30 | 2018-02-01 | 1137 |  |  |  | 409d | 0d |  | Mike Courthold; Matt Hills | 48h | 2,555.76 |
| 1147 | 8.1.3.2.2 | Check empty and purge sequence | 2d | 2018-02-02 | 2018-02-05 | 1146 |  |  |  | 409d | 0d |  | Mike Courthold; Matt Hills | 32h | 1,703.84 |
| 1148 | 8.1.3.2.3 | Tests to determine effects of using Helium top-up gas | 5d | 2018-02-06 | 2018-02-12 | 1147 |  |  |  | 409d | 0d |  | Mike Courthold; Matt Hills | 80h | 4,259.6 |
| 1149 | 8.1.3.2.4 | Check alarms and interlocks | 2d | 2018-02-13 | 2018-02-14 | 1148 |  |  |  | 409d | 0d |  | Mike Courthold; Matt Hills | 32h | 1,703.84 |
| 1150 | 8.1.3.2.5 | Measure H2 desorption rate | 2d | 2018-02-15 | 2018-02-16 | 1149 |  |  |  | 409d | 0d |  | Mike Courthold; Matt Hills | 32h | 1,703.84 |
| 1151 | 8.1.3.2.6 | Measure H2 absorption rate | 2d | 2018-02-19 | 2018-02-20 | 1150 |  |  |  | 409d |  |  | Mike Courthold; Matt Hills | 32h | 1,703.84 |
| 1152 | 8.2 | **RF Commissioning** | 355.45d | 2014-01-22 | 2015-06-03 |  |  |  |  | 1118d |  |  | RF System | 296h |  |
| 1153 | 8.2.1 | Commission RF system #1 | 37d | 2014-01-22 | 2014-03-14 | 739, 822, 825 |  |  |  | 1436.45d |  |  | STEP V - TIARA | 296h |  |
| 1154 | 8.2.2 | Commission RF system #2 | 37d | 2014-12-22 | 2015-02-11 | 775, 816, 828, 831 |  |  |  | 1198.72d |  |  |  |  |  |
| 1155 | 8.2.3 | Step IV Detector commissioning/data run | 52w | 2014-06-05 | 2015-06-03 | 991 | 2010-06-01 | 2010-06-15 | 11d? | 1118d | 0d | finish no earlier than 2013-11-29 |  |  |  |

Notes:
- 1134: Fill cryostat completely from Hydride Bed
- 1135: Empty full cryostat back to Hydride Bed.
- 1150: Fill cryostat completely from Hydride Bed
- 1151: Empty full cryostat back to Hydride Bed.

| ID | WBS | Task | Type | Duration | Start | Finish | Predecessors | Baseline start | Baseline finish | Baseline duration | Total slack | Free slack | Resources | Work |
| --- | --- | --- | --- | --- | --- | --- | --- | --- | --- | --- | --- | --- | --- | --- |
| 1156 | 8.2.4 | **AFC #1 LiH2 Absorber installation** |  | 37d | 2014-04-15 | 2014-06-04 |  |  |  |  | 1378d | 260d |  |  |
| 1157 | 8.2.4.1 | Move AFC #1 into parked position |  | 1d | 2014-04-15 | 2014-04-15 | 918, 920SS-1d |  |  |  | 1378d | 0d |  |  |
| 1158 | 8.2.4.2 | Remove AFC outer vacuum windows |  | 1d | 2014-04-16 | 2014-04-16 | 1157, 920 |  |  |  | 1378d | 0d |  |  |
| 1159 | 8.2.4.3 | Insert absorber and fit mountings |  | 3d | 2014-04-17 | 2014-04-21 | 1158 |  |  |  | 1378d | 0d |  |  |
| 1160 | 8.2.4.4 | Make gas connections |  | 1d | 2014-04-22 | 2014-04-22 | 1159 |  |  |  | 1378d | 0d |  |  |
| 1161 | 8.2.4.5 | Make electrical connections |  | 2d | 2014-04-23 | 2014-04-24 | 1160 |  |  |  | 1378d | 0d |  |  |
| 1162 | 8.2.4.6 | Re-fit outer vacuum windows and fit bellows |  | 2d | 2014-04-25 | 2014-04-28 | 1161 |  |  |  | 1378d | 0d |  |  |
| 1163 | 8.2.4.7 | Return module to beamline position |  | 1d | 2014-04-29 | 2014-04-29 | 1162 |  |  |  | 1378d | 0d |  |  |
| 1164 | 8.2.4.8 | Connect H2 transfer line, crycooler lines and vacuum/relief line |  | 1d | 2014-04-30 | 2014-04-30 | 1163 |  |  |  | 1378d | 0d |  |  |
| 1165 | 8.2.4.9 | Pump down vacuum spaces |  | 3d | 2014-05-01 | 2014-05-05 | 1164 |  |  |  | 1378d | 0d |  |  |
| 1166 | 8.2.4.10 | Leak check vacuum spaces |  | 1d | 2014-05-06 | 2014-05-06 | 1165 |  |  |  | 1378d | 0d |  |  |
| 1167 | 8.2.4.11 | Leak check cryocooler circuit |  | 1d | 2014-05-07 | 2014-05-07 | 1166 |  |  |  | 1378d | 0d |  |  |
| 1168 | 8.2.4.12 | Cool down of magnet and absorber |  | 10d | 2014-05-08 | 2014-05-21 | 1167 |  |  |  | 1378d | 0d |  |  |
| 1169 | 8.2.4.13 | LiH2 Absorber test period |  | 10d | 2014-05-22 | 2014-06-04 | 1168 |  |  |  | 1378d |  |  |  |
| 1170 | 8.2.5 | Step IV Detector commissioning Complete | milestone | 0d | 2015-06-03 | 2015-06-03 | 1155, 1156 | 2010-06-01 | 2010-06-15 | 11d? | 1118d |  |  |  |
| 1171 | 8.3 | **MICE Step IV Commissioning/data run** |  | 565d | 2014-06-05 | 2016-08-03 |  |  |  |  | 7d | 0d | Step V | 4520h |
| 1172 | 8.3.1 | Step IV Detector commissioning/data run |  | 113w | 2014-06-05 | 2016-08-03 | 991 | 2010-06-01 | 2010-06-15 | 11d? | 7d | 0d |  |  |
| 1173 | 8.3.2 | **AFC #1 LiH2 Absorber installation** |  | 37d | 2014-08-28 | 2014-10-17 | 1172SS+3mo |  |  |  | 1202d |  |  |  |
| 1174 | 8.3.2.1 | Movel AFC #2 into parked position |  | 1d | 2014-08-28 | 2014-08-28 |  |  |  |  | 1202d | 0d |  |  |
| 1175 | 8.3.2.2 | Remove AFC outer vacuum windows |  | 1d | 2014-08-29 | 2014-08-29 | 1174 |  |  |  | 1202d | 0d |  |  |
| 1176 | 8.3.2.3 | Insert absorber and fit mountings |  | 3d | 2014-09-01 | 2014-09-03 | 1175 |  |  |  | 1202d | 0d |  |  |
| 1177 | 8.3.2.4 | Make gas connections |  | 1d | 2014-09-04 | 2014-09-04 | 1176 |  |  |  | 1202d | 0d |  |  |
| 1178 | 8.3.2.5 | Make electrical connections |  | 2d | 2014-09-05 | 2014-09-08 | 1177 |  |  |  | 1202d | 0d |  |  |
| 1179 | 8.3.2.6 | Re-fit outer vacuum windows and fit bellows |  | 2d | 2014-09-09 | 2014-09-10 | 1178 |  |  |  | 1202d | 0d |  |  |
| 1180 | 8.3.2.7 | Return module to beamline position |  | 1d | 2014-09-11 | 2014-09-11 | 1179 |  |  |  | 1202d | 0d |  |  |
| 1181 | 8.3.2.8 | Connect H2 transfer line, crycooler lines and vacuum/relief line |  | 1d | 2014-09-12 | 2014-09-12 | 1180 |  |  |  | 1202d | 0d |  |  |
| 1182 | 8.3.2.9 | Pump down vacuum spaces |  | 3d | 2014-09-15 | 2014-09-17 | 1181 |  |  |  | 1202d | 0d |  |  |
| 1183 | 8.3.2.10 | Leak check vacuum spaces |  | 1d | 2014-09-18 | 2014-09-18 | 1182 |  |  |  | 1202d | 0d |  |  |
| 1184 | 8.3.2.11 | Leak check cryocooler circuit |  | 1d | 2014-09-19 | 2014-09-19 | 1183 |  |  |  | 1202d | 0d |  |  |
| 1185 | 8.3.2.12 | Cool down of magnet and absorber |  | 10d | 2014-09-22 | 2014-10-03 | 1184 |  |  |  | 1202d | 0d |  |  |
| 1186 | 8.3.2.13 | LiH2 Absorber test period |  | 10d | 2014-10-06 | 2014-10-17 | 1185 |  |  |  | 1202d |  |  |  |
| 1187 | 8.3.3 | Step IV Detector commissioning Complete | milestone | 0d | 2016-08-03 | 2016-08-03 | 1172 | 2010-06-01 | 2010-06-15 | 11d? | 7d | 0d |  |  |

Notes:
- 1158: Due to congestion in the area. Solenoid to be installed before any more work is carried out on AFC.

| ID | WBS | Task | Type | Duration | Start | Finish | Predecessors | Baseline start | Baseline finish | Baseline duration | Total slack | Free slack | Resources | Work |
| --- | --- | --- | --- | --- | --- | --- | --- | --- | --- | --- | --- | --- | --- | --- |
| 1188 | 8.4 | **MICE Step V Commissioning/data run** |  | 90d | 2017-06-27 | 2017-10-30 |  |  |  |  | 2d |  | Step IV | 720h |
| 1189 | 8.4.1 | Step V Detector commissioning/data run |  | 18w | 2017-06-27 | 2017-10-30 | 1035 | 2010-06-01 | 2010-06-15 | 11d? | 2d | 0d |  |  |
| 1190 | 8.4.2 | **AFC #2 LiH2 Absorber installation** |  | 27d | 2017-09-19 | 2017-10-25 | 1189SS+3mo |  |  |  | 493d |  |  |  |
| 1191 | 8.4.2.1 | Movel AFC #2 into parked position |  | 1d | 2017-09-19 | 2017-09-19 |  |  |  |  | 493d | 0d |  |  |
| 1192 | 8.4.2.2 | Remove AFC outer vacuum windows |  | 1d | 2017-09-20 | 2017-09-20 | 1191 |  |  |  | 493d | 0d |  |  |
| 1193 | 8.4.2.3 | Insert absorber and fit mountings |  | 3d | 2017-09-21 | 2017-09-25 | 1192 |  |  |  | 493d | 0d |  |  |
| 1194 | 8.4.2.4 | Make gas connections |  | 1d | 2017-09-26 | 2017-09-26 | 1193 |  |  |  | 493d | 0d |  |  |
| 1195 | 8.4.2.5 | Make electrical connections |  | 2d | 2017-09-27 | 2017-09-28 | 1194 |  |  |  | 493d | 0d |  |  |
| 1196 | 8.4.2.6 | Re-fit outer vacuum windows and fit bellows |  | 2d | 2017-09-29 | 2017-10-02 | 1195 |  |  |  | 493d | 0d |  |  |
| 1197 | 8.4.2.7 | Return module to beamline position |  | 1d | 2017-10-03 | 2017-10-03 | 1196 |  |  |  | 493d | 0d |  |  |
| 1198 | 8.4.2.8 | Connect H2 transfer line, crycooler lines and vacuum/relief line |  | 1d | 2017-10-04 | 2017-10-04 | 1197 |  |  |  | 493d | 0d |  |  |
| 1199 | 8.4.2.9 | Pump down vacuum spaces |  | 3d | 2017-10-05 | 2017-10-09 | 1198 |  |  |  | 493d | 0d |  |  |
| 1200 | 8.4.2.10 | Leak check vacuum spaces |  | 1d | 2017-10-10 | 2017-10-10 | 1199 |  |  |  | 493d | 0d |  |  |
| 1201 | 8.4.2.11 | Leak check cryocooler circuit |  | 1d | 2017-10-11 | 2017-10-11 | 1200 |  |  |  | 493d | 0d |  |  |
| 1202 | 8.4.2.12 | Cool down of magnet and absorber |  | 10d | 2017-10-12 | 2017-10-25 | 1201 |  |  |  | 493d |  |  |  |
| 1203 | 8.4.3 | Step V Detector commissioning Complete | milestone | 0d | 2017-10-30 | 2017-10-30 | 1189 | 2010-06-01 | 2010-06-15 | 11d? | 2d | 0d |  |  |
| 1204 | 8.5 | **MICE Step VI Commissioning/data run** |  | 260d | 2018-09-18 | 2019-09-16 |  |  |  |  | 0d |  | Step VI | 2080h |
| 1205 | 8.5.1 | Step VI Detector commissioning/data run |  | 52w | 2018-09-18 | 2019-09-16 | 1081 | 2010-06-01 | 2010-06-15 | 11d? | 0d |  |  |  |
| 1206 | 8.5.2 | **AFC #3 LiH2 Absorber installation** |  | 10d | 2018-12-11 | 2018-12-24 | 1205SS+3mo |  |  |  | 190d |  |  |  |
| 1207 | 8.5.2.1 | Movel AFC #3 into parked position |  | 1d | 2018-12-11 | 2018-12-11 |  |  |  |  | 199d |  |  |  |
| 1208 | 8.5.2.2 | Remove AFC outer vacuum windows |  | 1d | 2018-12-11 | 2018-12-11 |  |  |  |  | 199d |  |  |  |
| 1209 | 8.5.2.3 | Insert absorber and fit mountings |  | 3d | 2018-12-11 | 2018-12-13 |  |  |  |  | 197d |  |  |  |
| 1210 | 8.5.2.4 | Make gas connections |  | 1d | 2018-12-11 | 2018-12-11 |  |  |  |  | 199d |  |  |  |
| 1211 | 8.5.2.5 | Make electrical connections |  | 2d | 2018-12-11 | 2018-12-12 |  |  |  |  | 198d |  |  |  |
| 1212 | 8.5.2.6 | Re-fit outer vacuum windows and fit bellows |  | 2d | 2018-12-11 | 2018-12-12 |  |  |  |  | 198d |  |  |  |
| 1213 | 8.5.2.7 | Return module to beamline position |  | 1d | 2018-12-11 | 2018-12-11 |  |  |  |  | 199d |  |  |  |
| 1214 | 8.5.2.8 | Connect H2 transfer line, crycooler lines and vacuum/relief line |  | 1d | 2018-12-11 | 2018-12-11 |  |  |  |  | 199d |  |  |  |
| 1215 | 8.5.2.9 | Pump down vacuum spaces |  | 3d | 2018-12-11 | 2018-12-13 |  |  |  |  | 197d |  |  |  |
| 1216 | 8.5.2.10 | Leak check vacuum spaces |  | 1d | 2018-12-11 | 2018-12-11 |  |  |  |  | 199d |  |  |  |
| 1217 | 8.5.2.11 | Leak check cryocooler circuit |  | 1d | 2018-12-11 | 2018-12-11 |  |  |  |  | 199d |  |  |  |
| 1218 | 8.5.2.12 | Cool down of magnet and absorber |  | 10d | 2018-12-11 | 2018-12-24 |  |  |  |  | 190d |  |  |  |
| 1219 | 8.5.2.13 | LiH2 Absorber test period |  | 10d | 2018-12-11 | 2018-12-24 |  |  |  |  | 190d |  |  |  |
| 1220 | 8.5.3 | Step VI Detector commissioning Complete | milestone | 0d | 2019-09-16 | 2019-09-16 | 1205 | 2010-06-01 | 2010-06-15 | 11d? | 0d |  |  |  |
